# IMPACT Master Schedule

How a schedule from MS Project changed from version to version. A marks actual dates.

## Version 1 (data date 2003-12-31, saved 2004-01-22, file IMPACT Master Schedule_January 22 2004.mpp)

| ID | WBS | Task | Duration | Start | Finish | Predecessors | Complete | Total float | Constraint |
| --- | --- | --- | --- | --- | --- | --- | --- | --- | --- |
| 1 | 1 | **IMPACT - Dave Curtis (UCB) & Lil Reichenthal (GSFC)** | 443d | 2003-02-26 A | 2004-11-26 |  | 39% | 0d |  |
| 2 | 1.1 | **Suite Deliveries to APL** | 25d | 2004-08-31 | 2004-10-06 |  |  | 15d |  |
| 3 |  | Boom Suite FM 1 Ready for Delivery to APL | 0d | 2004-09-13 | 2004-09-13 | 358 |  | 18d | finish no later than 2004-10-07 |
| 4 |  | Boom Suite FM 2 Ready for Delivery to APL | 0d | 2004-08-31 | 2004-08-31 | 365 |  | 40d | finish no later than 2004-10-28 |
| 5 |  | SEP Suite FM 1 Ready for Delivery to APL | 0d | 2004-09-30 | 2004-09-30 | 863, 678, 607 |  | 5d | finish no later than 2004-10-07 |
| 6 |  | SEP Suite FM 2 Ready for Delivery to APL | 0d | 2004-10-06 | 2004-10-06 | 871, 681, 610 |  | 15d | finish no later than 2004-10-28 |
| 7 | 1.2 | **Environmental Testing - PER, Impact Suite EMC, Snapshots of Boom & SEP Suite Test Flows** | 187d | 2004-01-14 A | 2004-10-06 |  |  | 34d |  |
| 8 | 1.2.1 | **Reviews (PER and TRR's) - TRR Dates are Tentative** | 137d | 2004-01-14 A | 2004-07-27 |  | 14% | 84d |  |
| 9 |  | Instrument PER at UCB | 1d | 2004-01-14 A | 2004-01-14 A |  | 100% |  | start no earlier than 2004-01-14 |
| 10 |  | TRR 1 - Prior to FM 1 SEPT Vibration/Acoustics | 1d | 2004-02-02 | 2004-02-02 | 38SS-5d |  | 208d |  |
| 11 |  | TRR 2 - Prior to FM 1 IDPU Vibration | 1d | 2004-03-08 | 2004-03-08 | 18SS-5d |  | 184d |  |
| 12 |  | TRR 3 - Prior to FM 1 STE-U Thermal Vac/Thermal Balance | 1d | 2004-03-10 | 2004-03-10 | 21SS-5d |  | 182d |  |
| 13 |  | TRR 4 - Prior to FM 1 Boom Structure Vibration | 1d | 2004-04-08 | 2004-04-08 | 20SS-5d |  | 161d |  |
| 14 |  | TRR 5 - Prior to FM 1 SWEA Vibration | 1d | 2004-05-03 | 2004-05-03 | 23SS-5d |  | 144d |  |
| 15 |  | TRR 6 - Prior to FM 2 SEP Suite EMC | 1d | 2004-07-27 | 2004-07-27 | 55SS-5d |  | 84d |  |
| 16 |  | IMPACT Suite FM 1 EMC Testing at UCB | 10d | 2004-07-20 | 2004-08-02 | 839, 356 |  | 10d |  |
| 17 | 1.2.3 | **Boom Suite FM 1 Environmental Test Flow Snapshot - UCB** | 119d | 2004-03-15 | 2004-08-27 |  |  | 61d |  |
| 18 |  | IDPU Vibration | 5d | 2004-03-15 | 2004-03-19 | 177SS |  | 175d |  |
| 19 |  | IDPU Thermal Vac | 10d | 2004-03-22 | 2004-04-02 | 178SS |  | 165d |  |
| 20 |  | Boom Structure Vibration | 4d | 2004-04-15 | 2004-04-20 | 216SS |  | 153d |  |
| 21 |  | STE-U Thermal Vac and Thermal Balance | 14d | 2004-03-17 | 2004-04-05 | 276SS |  | 164d |  |
| 22 |  | Boom Structure Thermal Vac | 30d | 2004-04-21 | 2004-06-02 | 217SS |  | 123d |  |
| 23 |  | SWEA/STE Vibration | 5d | 2004-05-10 | 2004-05-14 | 342SS |  | 135d |  |
| 24 |  | SWEA/STE Thermal Vac and Thermal Balance | 14d | 2004-08-03 | 2004-08-20 | 343SS |  | 66d |  |
| 25 |  | IDPU Bake Out | 5d | 2004-08-03 | 2004-08-09 | 179SS |  | 75d |  |
| 26 |  | Boom Suite Bake Out | 5d | 2004-08-23 | 2004-08-27 | 357SS |  | 61d |  |
| 27 | 1.2.4 | **Boom Suite FM 2 Environmental Test Flow Snapshot - UCB** | 87d | 2004-04-16 | 2004-08-17 |  |  | 69d |  |
| 28 |  | Boom Structure Vibration | 4d | 2004-04-16 | 2004-04-21 | 238SS |  | 152d |  |
| 29 |  | IDPU Vibration | 5d | 2004-05-10 | 2004-05-14 | 182SS |  | 135d |  |
| 30 |  | IDPU Thermal Vac | 10d | 2004-05-17 | 2004-05-28 | 183SS |  | 125d |  |
| 31 |  | Boom Structure Thermal Vac | 30d | 2004-05-12 | 2004-06-23 | 239SS |  | 108d |  |
| 32 |  | SWEA/STE Vibration | 5d | 2004-06-23 | 2004-06-29 | 350SS |  | 104d |  |
| 33 |  | SWEA/STE Thermal Vac | 10d | 2004-06-30 | 2004-07-13 | 351SS |  | 94d |  |
| 34 |  | Boom Suite FM 2 EMC | 5d | 2004-08-04 | 2004-08-10 | 363SS |  | 74d |  |
| 35 |  | IDPU Bake Out | 5d | 2004-08-11 | 2004-08-17 | 184SS |  | 69d |  |
| 36 |  | Boom Suite Bake Out | 5d | 2004-08-11 | 2004-08-17 | 364SS |  | 69d |  |
| 37 | 1.2.5 | **SEP Suite FM 1 Environmental Test Flow Snapshot** | 162d | 2004-02-09 | 2004-09-24 |  |  | 42d |  |
| 38 |  | SEPT Vibe and Acoustics (in Europe) | 10d | 2004-02-09 | 2004-02-23 | 648SS, 655SS |  | 194d |  |
| 39 |  | SEPT Thermal Vac (in Europe) | 10d | 2004-02-24 | 2004-03-08 | 649SS, 656SS |  | 184d |  |
| 40 |  | SEPT Bake Out (in Europe) | 3d | 2004-03-09 | 2004-03-11 | 650SS, 657SS |  | 181d |  |
| 41 |  | SEPT Thermal Balance (at GSFC) | 10d | 2004-08-03 | 2004-08-16 | 651SS, 658SS |  | 70d |  |
| 42 |  | LET/HET/SEP Cen Vibe and Acoustics (at JPL) | 10d | 2004-08-06 | 2004-08-19 | 858SS |  | 67d |  |
| 43 |  | LET/HET/SEP Cen Thermal Balance (at JPL) | 5d | 2004-08-20 | 2004-08-26 | 859SS |  | 62d |  |
| 44 |  | LET/HET/SEP Cen Thermal Vac (at JPL) | 15d | 2004-08-27 | 2004-09-17 | 860SS |  | 47d |  |
| 45 |  | LET/HET/SEP Cen Bake Out (at JPL) | 3d | 2004-09-20 | 2004-09-22 | 863SS |  | 44d |  |
| 46 |  | LET/HET/SEP Cen Accelerator Test (at MSU) | 10d | 2004-07-15 | 2004-07-28 | 873SS |  | 83d |  |
| 47 |  | SIT Vibe and Acoustics (at GSFC) | 10d | 2004-08-12 | 2004-08-25 | 799SS |  | 63d |  |
| 48 |  | SIT Thermal Balance (at GSFC) | 5d | 2004-08-27 | 2004-09-02 | 801SS |  | 57d |  |
| 49 |  | SIT Thermal Vac (at GSFC) | 10d | 2004-09-03 | 2004-09-17 | 802SS |  | 47d |  |
| 50 |  | SIT Bake Out (at GSFC) | 3d | 2004-09-22 | 2004-09-24 | 804SS |  | 42d |  |
| 51 | 1.2.6 | **SEP Suite FM 2 Environmental Test Flow Snapshot** | 174d | 2004-02-03 | 2004-10-06 |  |  | 34d |  |
| 52 |  | SEPT Vibe and Acoustics (in Europe) | 10d | 2004-02-03 | 2004-02-17 | 663SS, 670SS |  | 198d |  |
| 53 |  | SEPT Thermal Vac (in Europe) | 10d | 2004-02-18 | 2004-03-02 | 664SS, 671SS |  | 188d |  |
| 54 |  | SEPT Bake Out (in Europe) | 3d | 2004-03-03 | 2004-03-05 | 665SS, 672SS |  | 185d |  |
| 55 |  | SEP Suite FM 2 EMC (at Caltech) | 5d | 2004-08-03 | 2004-08-09 | 865SS |  | 75d |  |
| 56 |  | SEPT Thermal Balance (at GSFC) | 10d | 2004-08-03 | 2004-08-16 | 666SS, 673SS |  | 70d |  |
| 57 |  | LET/HET/SEP Cen Vibe and Acoustics (at JPL) | 10d | 2004-08-20 | 2004-09-02 | 866SS |  | 57d |  |
| 58 |  | LET/HET/SEP Cen Thermal Balance (at JPL) | 5d | 2004-09-03 | 2004-09-10 | 867SS |  | 52d |  |
| 59 |  | LET/HET/SEP Cen Thermal Vac (at JPL) | 15d | 2004-09-13 | 2004-10-01 | 868SS |  | 37d |  |
| 60 |  | LET/HET/SEP Cen Bake Out (at JPL) | 3d | 2004-10-04 | 2004-10-06 | 871SS |  | 34d |  |
| 61 |  | SIT Vibe and Acoustics (at GSFC) | 10d | 2004-08-12 | 2004-08-25 | 799SS |  | 63d |  |
| 62 |  | SIT Thermal Balance (at GSFC) | 5d | 2004-08-27 | 2004-09-02 | 801SS |  | 57d |  |
| 63 |  | SIT Thermal Vac (at GSFC) | 10d | 2004-09-03 | 2004-09-17 | 802SS |  | 47d |  |
| 64 |  | SIT Bake Out (at GSFC) | 3d | 2004-09-22 | 2004-09-24 | 804SS |  | 42d |  |
| 65 | 1.3 | **Power Converters - UCB** | 355d | 2003-02-26 A | 2004-07-21 |  | 44% | 88d |  |
| 66 | 1.3.1 | **Deliveries** | 100d | 2003-12-09 A | 2004-04-30 |  | 20% | 145d |  |
| 67 | 1.3.1.1 | **FM 1** | 70d | 2003-12-09 A | 2004-03-19 |  | 40% | 175d |  |
| 68 |  | Deliver IDPU FM 1 LVPS (stays at UCB) | 0d | 2004-03-05 | 2004-03-05 | 122 |  | 74d |  |
| 69 |  | Deliver SEP FM 1 LVPS (to Cal Tech) | 1d | 2004-03-17 | 2004-03-17 | 126 |  | 62d |  |
| 70 |  | Deliver SWEA/STE FM 1 LVPS (stays at UCB) | 0d | 2004-03-19 | 2004-03-19 | 130 |  | 49d |  |

| ID | WBS | Task | Duration | Start | Finish | Predecessors | Complete | Total float | Constraint |
| --- | --- | --- | --- | --- | --- | --- | --- | --- | --- |
| 71 |  | Deliver PLASTIC FM 1 LVPS (to UNH) | 2d | 2004-03-04 | 2004-03-05 | 134 |  | 185d |  |
| 72 |  | Deliver SIT FM 1 HVPS (to UMD) | 2d | 2003-12-09 A | 2003-12-10 A | 136 | 100% |  |  |
| 73 | 1.3.1.2 | **FM 2** | 28d | 2004-03-24 | 2004-04-30 |  |  | 34d |  |
| 74 |  | Deliver IDPU FM 2 LVPS (stays at UCB) | 0d | 2004-04-30 | 2004-04-30 | 143 |  | 40d |  |
| 75 |  | Deliver SEP FM 2 LVPS (to Cal Tech) | 1d | 2004-04-19 | 2004-04-19 | 147 |  | 77d |  |
| 76 |  | Deliver SWEA/STE FM 2 LVPS (stays at UCB) | 0d | 2004-04-26 | 2004-04-26 | 151 |  | 49d |  |
| 77 |  | Deliver PLASTIC FM 2 LVPS (to UNH) | 2d | 2004-04-12 | 2004-04-13 | 155 |  | 158d |  |
| 78 |  | Deliver SIT FM 2 HVPS (to UMD) | 2d | 2004-03-24 | 2004-03-25 | 159 |  | 34d |  |
| 79 | 1.3.2 | **Remaining Flight Procurements** | 44d | 2003-10-24 A | 2003-12-29 |  | 75% | 74d |  |
| 80 |  | Procure IDPU Flight Printed Wiring Board | 10d | 2003-12-15 | 2003-12-29 | 86 |  | 74d | start no earlier than 2003-12-15 |
| 81 |  | Procure SEP Flight Printed Wiring Board | 10d | 2003-11-24 A | 2003-12-08 A | 87 | 100% |  | start no earlier than 2003-11-24 |
| 82 |  | Procure SWEA Flight Printed Wiring Board | 10d | 2003-12-04 A | 2003-12-17 A | 88 | 100% |  |  |
| 83 |  | Procure PLASTIC Flight Printed Wiring Board | 10d | 2003-10-24 A | 2003-11-06 A |  | 100% |  | start no earlier than 2003-10-24 |
| 84 | 1.3.3 | **Fabrication** | 226d | 2003-02-26 A | 2004-01-20 |  | 86% | 171d |  |
| 85 | 1.3.3.1 | **FM 1 & FM 2** | 195d | 2003-02-26 A | 2003-12-03 A |  | 100% |  |  |
| 86 |  | Re-layout IDPU LVPS Flight Printed Wiring Board | 186d | 2003-02-26 A | 2003-11-19 A |  | 100% |  | start no earlier than 2003-02-26 |
| 87 |  | Re-layout SEP LVPS Flight Printed Wiring Board | 32d | 2003-09-24 A | 2003-11-07 A |  | 100% |  | start no earlier than 2003-09-24 |
| 88 |  | Re-layout SWEA LVPS Flight Printed Wiring Board | 5d | 2003-11-26 A | 2003-12-03 A |  | 100% |  | start no earlier than 2003-11-26 |
| 89 | 1.3.3.2 | **FM 1** | 45d | 2003-09-29 A | 2003-12-03 A |  | 100% |  |  |
| 90 |  | Wind IDPU LVPS FM 1 Magnets | 10d | 2003-10-17 A | 2003-10-30 A |  | 100% |  | start no earlier than 2003-10-17 |
| 91 |  | Wind SEP LVPS FM 1 Magnets | 15d | 2003-09-29 A | 2003-10-20 A |  | 100% |  | start no earlier than 2003-09-29 |
| 92 |  | Wind SWEA LVPS FM 1 Magnets | 5d | 2003-11-26 A | 2003-12-03 A |  | 100% |  | start no earlier than 2003-11-26 |
| 93 |  | Wind PLASTIC LVPS FM 1 Magnets | 45d | 2003-09-29 A | 2003-12-03 A |  | 100% |  | start no earlier than 2003-09-29 |
| 94 | 1.3.3.3 | **FM 2** | 15d | 2003-12-29 A | 2004-01-20 |  | 30% | 171d |  |
| 95 |  | Wind HVPS FM 2 Magnets | 15d | 2003-12-29 A | 2004-01-20 |  | 30% | 34d | start no earlier than 2003-12-29 |
| 96 |  | Wind IDPU LVPS FM 2 Magnets | 15d | 2003-12-29 A | 2004-01-20 | 95SS | 30% | 67d |  |
| 97 |  | Wind SEP LVPS FM 2 Magnets | 15d | 2003-12-29 A | 2004-01-20 | 95SS | 30% | 94d |  |
| 98 |  | Wind SWEA LVPS FM 2 Magnets | 15d | 2003-12-29 A | 2004-01-20 | 95SS | 30% | 72d |  |
| 99 |  | Wind PLASTIC LVPS FM 2 Magnets | 15d | 2003-12-29 A | 2004-01-20 | 95SS | 30% | 171d |  |
| 100 | 1.3.4 | **Assembly** | 57d | 2003-12-29 A | 2004-03-19 |  | 2% | 143d |  |
| 101 | 1.3.4.1 | **FM 1** | 27d | 2003-12-29 A | 2004-02-05 |  | 5% | 173d |  |
| 102 |  | Assemble IDPU FM 1 LVPS | 12d | 2004-01-06 | 2004-01-22 | 90, 114 |  | 74d |  |
| 103 |  | Assemble SEP FM 1 LVPS | 15d | 2004-01-12 | 2004-02-02 | 115, 91 |  | 62d | start no earlier than 2004-01-12 |
| 104 |  | Assemble SWEA FM 1 LVPS | 14d | 2004-01-16 | 2004-02-05 | 92, 116 |  | 49d | start no earlier than 2004-01-12 |
| 105 |  | Assemble PLASTIC FM 1 LVPS | 15d | 2003-12-29 A | 2004-01-20 | 117, 93 | 20% | 185d | start no earlier than 2003-12-29 |
| 106 | 1.3.4.2 | **FM 2** | 42d | 2004-01-21 | 2004-03-19 |  |  | 34d |  |
| 107 |  | Assemble IDPU FM 2 LVPS | 15d | 2004-03-01 | 2004-03-19 | 96 |  | 40d | start no earlier than 2004-03-01 |
| 108 |  | Assemble SEP FM 2 LVPS | 15d | 2004-02-13 | 2004-03-05 | 97 |  | 77d | start no earlier than 2004-02-13 |
| 109 |  | Assemble SWEA FM 2 LVPS | 15d | 2004-02-24 | 2004-03-15 | 98 |  | 49d | start no earlier than 2004-02-24 |
| 110 |  | Assemble PLASTIC FM 2 LVPS | 14d | 2004-02-09 | 2004-02-27 | 99 |  | 158d | start no earlier than 2004-02-09 |
| 111 |  | Assemble SIT FM 2 HVPS | 14d | 2004-01-21 | 2004-02-09 | 95 |  | 34d |  |
| 112 | 1.3.5 | **Testing** | 182d | 2003-10-31 A | 2004-07-21 |  | 11% | 88d |  |
| 113 | 1.3.5.1 | **FM 1 & FM 2** | 36d | 2003-11-24 A | 2004-01-15 |  | 53% | 66d |  |
| 114 |  | Coupon Test IDPU Flight Printed Wiring Board | 4d | 2003-12-30 | 2004-01-05 | 80 |  | 74d |  |
| 115 |  | Coupon Test SEP Flight Printed Wiring Board | 5d | 2003-12-09 A | 2003-12-15 A | 81 | 100% |  |  |
| 116 |  | Coupon Test SWEA Flight Printed Wiring Board | 5d | 2004-01-09 | 2004-01-15 | 82 |  | 49d | start no earlier than 2004-01-09 |
| 117 |  | Coupon Test PLASTIC Flight Printed Wiring Board | 5d | 2003-11-24 A | 2003-12-01 A | 83 | 100% |  | start no earlier than 2003-11-24 |
| 118 | 1.3.5.2 | **FM 1** | 182d | 2003-10-31 A | 2004-07-21 |  | 16% | 88d |  |
| 119 | 1.3.5.2.1 | **IDPU** | 30d | 2004-01-23 | 2004-03-05 |  |  | 74d |  |
| 120 |  | Test IDPU FM 1 LVPS | 15d | 2004-01-23 | 2004-02-12 | 102 |  | 74d |  |
| 121 |  | Coat & Stake IDPU LVPS FM 1 Boards | 5d | 2004-02-13 | 2004-02-20 | 120 |  | 74d |  |
| 122 |  | Retest IDPU LVPS FM 1 Boards | 10d | 2004-02-23 | 2004-03-05 | 121 |  | 74d |  |
| 123 | 1.3.5.2.2 | **SEP** | 30d | 2004-02-03 | 2004-03-16 |  |  | 62d |  |
| 124 |  | Test SEP FM 1 LVPS | 15d | 2004-02-03 | 2004-02-24 | 103 |  | 62d |  |
| 125 |  | Coat & Stake SEP LVPS FM 1 Boards | 5d | 2004-02-25 | 2004-03-02 | 124 |  | 62d |  |
| 126 |  | Retest SEP LVPS FM 1 Boards | 10d | 2004-03-03 | 2004-03-16 | 125, 377 |  | 62d |  |
| 127 | 1.3.5.2.3 | **SWEA** | 30d | 2004-02-06 | 2004-03-19 |  |  | 49d |  |
| 128 |  | Test SWEA FM 1 LVPS | 15d | 2004-02-06 | 2004-02-27 | 104 |  | 49d |  |
| 129 |  | Coat & Stake SWEA LVPS FM 1 Boards | 5d | 2004-03-01 | 2004-03-05 | 128 |  | 49d |  |
| 130 |  | Retest SWEA LVPS FM 1 Boards | 10d | 2004-03-08 | 2004-03-19 | 129 |  | 49d |  |
| 131 | 1.3.5.2.4 | **PLASTIC** | 30d | 2004-01-21 | 2004-03-03 |  |  | 185d |  |
| 132 |  | Test PLASTIC FM 1 LVPS | 15d | 2004-01-21 | 2004-02-10 | 105 |  | 185d |  |
| 133 |  | Coat & Stake PLASTIC LVPS FM 1 Boards | 5d | 2004-02-11 | 2004-02-18 | 132 |  | 185d |  |
| 134 |  | Retest PLASTIC LVPS FM 1 Boards | 10d | 2004-02-19 | 2004-03-03 | 133 |  | 185d |  |
| 135 | 1.3.5.2.5 | **SIT** | 182d | 2003-10-31 A | 2004-07-21 |  | 63% | 88d |  |
| 136 |  | Test SIT FM 1 HVPS | 25d | 2003-10-31 A | 2003-12-08 A |  | 100% |  | start no earlier than 2003-10-31 |
| 137 |  | Coat & Stake SIT FM 1 HVPS Boards (at UMD) | 5d | 2004-07-01 | 2004-07-07 | 772SS |  | 88d |  |
| 138 |  | Retest SIT FM 1 HVPS Boards (at UMD) | 10d | 2004-07-08 | 2004-07-21 | 137 |  | 88d |  |
| 139 | 1.3.5.3 | **FM 2** | 58d | 2004-02-10 | 2004-04-30 |  |  | 34d |  |
| 140 | 1.3.5.3.1 | **IDPU** | 30d | 2004-03-22 | 2004-04-30 |  |  | 40d |  |

| ID | WBS | Task | Duration | Start | Finish | Predecessors | Complete | Total float | Constraint |
| --- | --- | --- | --- | --- | --- | --- | --- | --- | --- |
| 141 |  | Test IDPU FM 2 LVPS | 15d | 2004-03-22 | 2004-04-09 | 107 |  | 40d |  |
| 142 |  | Coat & Stake IDPU LVPS FM 2 Boards | 5d | 2004-04-12 | 2004-04-16 | 141 |  | 40d |  |
| 143 |  | Retest IDPU LVPS FM 2 Boards | 10d | 2004-04-19 | 2004-04-30 | 142 |  | 40d |  |
| 144 | 1.3.5.3.2 | **SEP** | 30d | 2004-03-08 | 2004-04-16 |  |  | 77d |  |
| 145 |  | Test SEP FM 2 LVPS | 15d | 2004-03-08 | 2004-03-26 | 108 |  | 77d |  |
| 146 |  | Coat & Stake SEP LVPS FM 2 Boards | 5d | 2004-03-29 | 2004-04-02 | 145 |  | 77d |  |
| 147 |  | Retest SEP LVPS FM 2 Boards | 10d | 2004-04-05 | 2004-04-16 | 146, 377 |  | 77d |  |
| 148 | 1.3.5.3.3 | **SWEA** | 30d | 2004-03-16 | 2004-04-26 |  |  | 49d |  |
| 149 |  | Test SWEA FM 2 LVPS | 15d | 2004-03-16 | 2004-04-05 | 109 |  | 49d |  |
| 150 |  | Coat & Stake SWEA LVPS FM 2 Boards | 5d | 2004-04-06 | 2004-04-12 | 149 |  | 49d |  |
| 151 |  | Retest SWEA LVPS FM 2 Boards | 10d | 2004-04-13 | 2004-04-26 | 150 |  | 49d |  |
| 152 | 1.3.5.3.4 | **PLASTIC** | 30d | 2004-03-01 | 2004-04-09 |  |  | 158d |  |
| 153 |  | Test PLASTIC FM 2 LVPS | 15d | 2004-03-01 | 2004-03-19 | 110 |  | 158d |  |
| 154 |  | Coat & Stake PLASTIC LVPS FM 2 Boards | 5d | 2004-03-22 | 2004-03-26 | 153 |  | 158d |  |
| 155 |  | Retest PLASTIC LVPS FM 2 Boards | 10d | 2004-03-29 | 2004-04-09 | 154 |  | 158d |  |
| 156 | 1.3.5.3.5 | **SIT** | 30d | 2004-02-10 | 2004-03-23 |  |  | 34d |  |
| 157 |  | Test SIT FM 2 HVPS | 15d | 2004-02-10 | 2004-03-02 | 111 |  | 34d |  |
| 158 |  | Coat & Stake SIT FM 2 HVPS Boards | 5d | 2004-03-03 | 2004-03-09 | 157 |  | 34d |  |
| 159 |  | Retest SIT FM 2 HVPS Boards | 10d | 2004-03-10 | 2004-03-23 | 158 |  | 34d |  |
| 160 | 1.4 | **IDPU - UCB** | 340d | 2003-05-05 A | 2004-09-07 |  | 59% | 55d |  |
| 161 | 1.4.1 | **Deliveries** | 78d | 2004-02-09 | 2004-05-28 |  |  | 112d |  |
| 162 |  | IDPU FM 1 Complete (to CIT for SEP I&T, then to UCB for Boom I&T, Suite EMC, BO & Final Boom I&T) | 0d | 2004-04-02 | 2004-04-02 | 178 |  | 74d |  |
| 163 |  | IDPU FM 2 Complete (to CIT for SEP I&T, then to UCB for Boom I&T, Boom EMC, BO & Final Boom I&T) | 0d | 2004-05-28 | 2004-05-28 | 183 |  | 40d |  |
| 164 |  | Deliver IDPU S/W Build 3 (to UNH) | 0d | 2004-02-09 | 2004-02-09 | 167 |  | 203d |  |
| 165 | 1.4.2 | **Flight Software** | 192d | 2003-05-05 A | 2004-02-09 |  | 81% | 108d |  |
| 166 |  | IDPU S/W Build #2.5 | 131d | 2003-05-05 A | 2003-11-07 A |  | 100% |  | start no earlier than 2003-05-05 |
| 167 |  | IDPU S/W Build #3 | 120d | 2003-08-15 A | 2004-02-09 |  | 60% | 108d | start no earlier than 2003-08-15 |
| 168 | 1.4.3 | **GSE** | 301d | 2003-06-30 A | 2004-09-07 |  | 50% | 55d |  |
| 169 |  | STE Science Display | 27d | 2003-10-23 A | 2003-12-02 A |  | 100% |  | start no earlier than 2003-10-23 |
| 170 |  | SWEA Science Display | 140d | 2003-06-30 A | 2004-01-21 |  | 62% | 216d | start no earlier than 2003-06-30 |
| 171 |  | GSE Continued Development | 291d | 2003-07-15 A | 2004-09-07 |  | 40% | 55d | start no earlier than 2003-07-15 |
| 172 | 1.4.4 | **Integration & Test** | 218d | 2003-10-07 A | 2004-08-17 |  | 33% | 40d |  |
| 173 |  | IDPU DCB FM 2 Board Level Testing | 15d | 2003-10-07 A | 2003-10-28 A |  | 100% |  | start no earlier than 2003-10-07 |
| 174 |  | IDPU DCB Clean/Stake/Coat (FM 1 & FM 2) | 10d | 2003-12-26 A | 2004-01-09 A | 173 | 100% |  | start no earlier than 2003-12-26 |
| 175 | 1.4.4.3 | **FM 1** | 110d | 2004-03-08 | 2004-08-09 |  |  | 32d |  |
| 176 |  | IDPU FM 1 I & T | 5d | 2004-03-08 | 2004-03-12 | 166, 68, 243, 287, 174 |  | 74d |  |
| 177 |  | IDPU FM 1 Vibration | 5d | 2004-03-15 | 2004-03-19 | 176 |  | 74d |  |
| 178 |  | IDPU FM 1 Thermal Vacuum | 10d | 2004-03-22 | 2004-04-02 | 177 |  | 74d |  |
| 179 |  | IDPU FM 1 Bakeout | 5d | 2004-08-03 | 2004-08-09 | 16, 178 |  | 32d |  |
| 180 | 1.4.4.4 | **FM 2** | 76d | 2004-05-03 | 2004-08-17 |  |  | 40d |  |
| 181 |  | IDPU FM 2 I & T | 5d | 2004-05-03 | 2004-05-07 | 74, 244, 288, 173, 174 |  | 40d |  |
| 182 |  | IDPU FM 2 Vibration | 5d | 2004-05-10 | 2004-05-14 | 181 |  | 40d |  |
| 183 |  | IDPU FM 2 Thermal Vacuum | 10d | 2004-05-17 | 2004-05-28 | 167, 182 |  | 40d |  |
| 184 |  | IDPU FM 2 Bakeout | 5d | 2004-08-11 | 2004-08-17 | 183, 364SS |  | 40d |  |
| 185 | 1.5 | **BOOM Suite - UCB** | 304d | 2003-07-01 A | 2004-09-13 |  | 56% | 32d |  |
| 186 | 1.5.1 | **BOOM Structure - UCB** | 187d | 2003-09-10 A | 2004-06-08 |  | 59% | 74d |  |
| 187 | 1.5.1.1 | **Deliveries** | 104d | 2004-01-09 A | 2004-06-08 |  |  | 74d |  |
| 188 |  | Protoflight Boom available for I&T (if needed) | 0d | 2004-01-09 A | 2004-01-09 A | 193 | 100% |  |  |
| 189 |  | Deliver Boom Structure FM 1 (stays at UCB for Boom Suite FM 1 I&T) | 0d | 2004-05-17 | 2004-05-17 | 218 |  | 48d |  |
| 190 |  | Deliver Boom Structure FM 2 (stays at UCB for Boom Suite FM 2 I&T) | 0d | 2004-06-08 | 2004-06-08 | 240 |  | 74d |  |
| 191 | 1.5.1.2 | **Protoflight** | 79d | 2003-09-16 A | 2004-01-09 A |  | 100% |  |  |
| 192 |  | Protoflight Boom Post Environmental Deployment Test | 35d | 2003-09-16 A | 2003-11-04 A |  | 100% |  | start no earlier than 2003-09-16 |
| 193 |  | Document Protoflight Boom Test Results | 44d | 2003-11-05 A | 2004-01-09 A | 192 | 100% |  |  |
| 194 | 1.5.1.3 | **Flight Procurements** | 40d | 2003-09-10 A | 2003-11-05 A |  | 100% |  |  |
| 195 |  | Receive and Inspect Flight Boom Structure Tubes (FM 1) | 32d | 2003-09-10 A | 2003-10-24 A |  | 100% |  | start no earlier than 2003-09-10 |
| 196 |  | Receive and Inspect Flight Boom Structure Tubes (FM 2) | 40d | 2003-09-10 A | 2003-11-05 A |  | 100% |  | start no earlier than 2003-09-10 |
| 197 | 1.5.1.4 | **FM 1** | 159d | 2003-09-29 A | 2004-05-17 |  | 46% | 48d |  |
| 198 | 1.5.1.4.1 | **Telescoping** | 81d | 2003-10-27 A | 2004-02-24 |  | 59% | 50d |  |
| 199 | 1.5.1.4.1.1 | **Fabrication, Assembly & Test** | 81d | 2003-10-27 A | 2004-02-24 |  | 59% | 50d |  |
| 200 |  | Machine FM 1 Boom Structure Tubes as necessary | 5d | 2003-10-27 A | 2003-10-31 A | 195 | 100% |  |  |
| 201 |  | Machine FM 1 Boom Structure Parts (Rings) | 38d | 2003-11-07 A | 2004-01-05 A | 195FF+47d | 100% |  |  |
| 202 |  | Assemble FM 1 Boom Structure Telescoping Assembly | 20d | 2004-01-12 | 2004-02-09 | 200, 201 |  | 50d | start no earlier than 2004-01-12 |
| 203 |  | Test FM 1 Boom Structure Telescoping Assembly | 10d | 2004-02-10 | 2004-02-24 | 202 |  | 50d |  |
| 204 | 1.5.1.4.2 | **Harness** | 102d | 2003-09-29 A | 2004-02-26 |  | 41% | 48d |  |
| 205 | 1.5.1.4.2.1 | **Fabrication** | 72d | 2003-09-29 A | 2004-01-13 |  | 59% | 48d |  |
| 206 |  | Machine FM 1 Harness Parts | 72d | 2003-09-29 A | 2004-01-13 |  | 59% | 48d | start no earlier than 2003-09-29 |
| 207 | 1.5.1.4.2.2 | **Assembly & Test** | 30d | 2004-01-14 | 2004-02-26 |  |  | 48d |  |
| 208 |  | Assemble FM 1 Harness subassembly | 20d | 2004-01-14 | 2004-02-11 | 206 |  | 48d |  |
| 209 |  | FM1 Harness Test | 10d | 2004-02-12 | 2004-02-26 | 208 |  | 48d |  |
| 210 | 1.5.1.4.3 | **Mounting** | 38d | 2003-09-29 A | 2003-11-21 A |  | 100% |  |  |

| ID | WBS | Task | Duration | Start | Finish | Predecessors | Complete | Total float | Constraint |
| --- | --- | --- | --- | --- | --- | --- | --- | --- | --- |
| 211 |  | FM 1Boom Structure Mounting Fabrication | 28d | 2003-09-29 A | 2003-11-06 A |  | 100% |  | start no earlier than 2003-09-29 |
| 212 |  | FM 1Boom Structure Mounting Assembly | 10d | 2003-11-07 A | 2003-11-21 A | 211 | 100% |  |  |
| 213 | 1.5.1.4.4 | **Integration & Test** | 57d | 2004-02-27 | 2004-05-17 |  |  | 48d |  |
| 214 |  | Integrate FM 1 Boom Structure subassemblies | 20d | 2004-02-27 | 2004-03-25 | 203, 209 |  | 48d |  |
| 215 |  | FM 1 Boom Structure Deployment Test | 10d | 2004-03-26 | 2004-04-08 | 214 |  | 48d |  |
| 216 |  | FM 1 Boom Structure Vibration Testing Completed | 4d | 2004-04-15 | 2004-04-20 | 215, 354 |  | 48d |  |
| 217 |  | FM 1 Boom Structure Themal Vac Testing Completed | 15d | 2004-04-21 | 2004-05-11 | 216 |  | 48d |  |
| 218 |  | FM 1 Boom Structure Post Environmental Deployment Test Completed | 4d | 2004-05-12 | 2004-05-17 | 217 |  | 48d |  |
| 219 | 1.5.1.5 | **FM 2** | 174d | 2003-09-29 A | 2004-06-08 |  | 47% | 74d |  |
| 220 | 1.5.1.5.1 | **Telescoping** | 73d | 2003-11-06 A | 2004-02-24 |  | 62% | 91d |  |
| 221 | 1.5.1.5.1.1 | **Fabrication, Assembly & Test** | 73d | 2003-11-06 A | 2004-02-24 |  | 62% | 91d |  |
| 222 |  | Machine FM 2 Boom Structure Tubes as necessary | 11d | 2003-11-06 A | 2003-11-21 A | 196 | 100% |  |  |
| 223 |  | Machine FM 2 Boom Structure Parts (Rings) | 38d | 2003-11-07 A | 2004-01-05 A | 201SS | 100% |  |  |
| 224 |  | Assemble FM 2 Boom Structure Telescoping Assembly | 20d | 2004-01-12 | 2004-02-09 | 222, 223 |  | 91d | start no earlier than 2004-01-12 |
| 225 |  | Test FM 2 Boom Structure Telescoping Assembly | 10d | 2004-02-10 | 2004-02-24 | 224 |  | 91d |  |
| 226 | 1.5.1.5.2 | **Harness** | 102d | 2003-09-29 A | 2004-02-26 |  | 41% | 89d |  |
| 227 | 1.5.1.5.2.1 | **Fabrication** | 72d | 2003-09-29 A | 2004-01-13 |  | 59% | 89d |  |
| 228 |  | Machine FM 2 Harness Parts | 72d | 2003-09-29 A | 2004-01-13 | 206SS | 59% | 89d |  |
| 229 | 1.5.1.5.2.2 | **Assembly & Test** | 30d | 2004-01-14 | 2004-02-26 |  |  | 89d |  |
| 230 |  | Assemble FM 2 Harness subassembly | 20d | 2004-01-14 | 2004-02-11 | 228 |  | 89d |  |
| 231 |  | FM 2 Harness Test | 10d | 2004-02-12 | 2004-02-26 | 230 |  | 89d |  |
| 232 | 1.5.1.5.3 | **Mounting** | 38d | 2003-09-29 A | 2003-11-21 A |  | 100% |  |  |
| 233 |  | FM 2 Boom Structure Mountings Fabrication | 28d | 2003-09-29 A | 2003-11-06 A | 211SS | 100% |  |  |
| 234 |  | FM 2 Boom Structure Mountings Assembly | 10d | 2003-11-07 A | 2003-11-21 A | 233 | 100% |  |  |
| 235 | 1.5.1.5.4 | **Integration & Test** | 72d | 2004-02-27 | 2004-06-08 |  |  | 74d |  |
| 236 |  | Integrate FM 2 Boom Structure subassemblies | 20d | 2004-02-27 | 2004-03-25 | 225, 231 |  | 89d |  |
| 237 |  | FM 2 Boom Structure Deployment Test | 10d | 2004-03-26 | 2004-04-08 | 236 |  | 89d |  |
| 238 |  | FM 2 Boom Structure Vibration Test | 4d | 2004-04-16 | 2004-04-21 | 237, 360 |  | 88d |  |
| 239 |  | FM 2 Boom Structure Themal Vac Testing | 15d | 2004-05-12 | 2004-06-02 | 238, 217 |  | 74d |  |
| 240 |  | FM 2 Boom Structure Post Environmental Deployment Test | 4d | 2004-06-03 | 2004-06-08 | 239 |  | 74d |  |
| 241 | 1.5.2 | **MAG - GSFC** | 47d | 2004-01-09 | 2004-03-17 |  |  | 72d |  |
| 242 | 1.5.2.1 | **Deliveries** | 22d | 2004-02-17 | 2004-03-17 |  |  | 72d |  |
| 243 |  | Deliver MAG FM 1 (to UCB for IDPU/BOOM Suite FM 1 I&T) | 2d | 2004-02-17 | 2004-02-18 | 247 |  | 84d |  |
| 244 |  | Deliver MAG FM 2 (to UCB for IDPU/BOOM Suite FM 2 I&T) | 2d | 2004-03-16 | 2004-03-17 | 250 |  | 72d |  |
| 245 | 1.5.2.2 | **FM 1** | 25d | 2004-01-09 | 2004-02-13 |  |  | 84d |  |
| 246 |  | FM 1 MAG Testing | 10d | 2004-01-09 | 2004-01-23 |  |  | 84d | start no earlier than 2004-01-09 |
| 247 |  | MAG FM 1 Calibration | 15d | 2004-01-26 | 2004-02-13 | 246 |  | 84d |  |
| 248 | 1.5.2.3 | **FM 2** | 25d | 2004-02-09 | 2004-03-15 |  |  | 72d |  |
| 249 |  | FM 2 MAG Testing | 10d | 2004-02-09 | 2004-02-23 |  |  | 72d | start no earlier than 2004-02-09 |
| 250 |  | MAG FM 2 Calibration | 15d | 2004-02-24 | 2004-03-15 | 249 |  | 72d |  |
| 251 | 1.5.3 | **SWEA - CESR** | 79d | 2003-12-08 A | 2004-03-31 |  | 6% | 77d |  |
| 252 | 1.5.3.1 | **Deliveries** | 79d | 2003-12-08 A | 2004-03-31 |  | 50% | 77d |  |
| 253 |  | SWEA FM 1 Delivery to UCB | 3d | 2003-12-08 A | 2003-12-10 A |  | 100% |  | start no earlier than 2003-12-08 |
| 254 |  | SWEA FM 2 Delivery to UCB | 3d | 2004-03-29 | 2004-03-31 | 257 |  | 77d |  |
| 255 | 1.5.3.2 | **FM 2** | 47d | 2004-01-21 | 2004-03-26 |  |  | 77d |  |
| 256 |  | SWEA FM 2 Final Assembly (Block 2) | 3d | 2004-01-21 | 2004-01-23 |  |  | 77d | start no earlier than 2004-01-21 |
| 257 |  | SWEA FM 2 Calibration | 44d | 2004-01-26 | 2004-03-26 | 256 |  | 77d |  |
| 258 | 1.5.4 | **STE - UCB** | 153d | 2003-08-29 A | 2004-04-09 |  | 55% | 88d |  |
| 259 | 1.5.4.1 | **Deliveries** | 8d | 2004-03-30 | 2004-04-09 |  |  | 52d |  |
| 260 |  | Deliver STE-D FM 1 (stays at UCB for SWEA/STE-D FM 1 I&T) | 0d | 2004-03-30 | 2004-03-30 | 275 |  | 52d |  |
| 261 |  | Deliver STE-D FM 2 (stays at UCB for SWEA/STE-D FM 2 I&T) | 0d | 2004-04-09 | 2004-04-09 | 283 |  | 70d |  |
| 262 |  | Deliver STE-U FM 1 (stays at UCB for BOOM Suite FM 1 I&T) | 0d | 2004-04-05 | 2004-04-05 | 276 |  | 51d |  |
| 263 |  | Deliver STE-U FM 2 (stays at UCB for BOOM Suite FM 2 I&T) | 0d | 2004-04-09 | 2004-04-09 | 284 |  | 88d |  |
| 264 | 1.5.4.2 | **STE-U/D Housing** | 38d | 2003-11-21 A | 2004-01-16 |  | 71% | 100d |  |
| 265 |  | Fabricate STE FM 1 Box | 38d | 2003-11-21 A | 2004-01-16 |  | 71% | 61d | start no earlier than 2003-11-21 |
| 266 |  | Fabricate STE FM 2 Box | 38d | 2003-11-21 A | 2004-01-16 |  | 71% | 100d | start no earlier than 2003-11-21 |
| 267 | 1.5.4.3 | **STE-U/D Detector Boards** | 153d | 2003-08-29 A | 2004-04-09 |  | 51% | 88d |  |
| 268 |  | Coupon Test STE FM 1 & FM 2 Detector Printed Wiring Board | 17d | 2003-10-10 A | 2003-11-04 A | 270, 278 | 100% |  | start no earlier than 2003-10-10 |
| 269 | 1.5.4.3.2 | **FM 1** | 149d | 2003-08-29 A | 2004-04-05 |  | 47% | 51d |  |
| 270 |  | Fabrication STE FM 1 Detector Printed Wiring Board | 29d | 2003-08-29 A | 2003-10-09 A |  | 100% |  | start no earlier than 2003-08-29 |
| 271 |  | Load STE FM 1 Detector Printed Wiring Board | 49d | 2003-11-05 A | 2004-01-16 | 268 | 78% | 51d |  |
| 272 |  | Test STE FM 1 Detector Printed Wiring Board | 10d | 2004-01-20 | 2004-02-02 | 271 |  | 51d |  |
| 273 | 1.5.4.3.2.4 | **Integration & Test** | 44d | 2004-02-03 | 2004-04-05 |  |  | 51d |  |
| 274 |  | Integrate & Test STE-U/D FM 1 Detectors W/ FM 1 Housings | 20d | 2004-02-03 | 2004-03-02 | 265, 272 |  | 51d |  |
| 275 |  | Calibrate STE-U/D FM 1 | 20d | 2004-03-03 | 2004-03-30 | 274 |  | 51d |  |
| 276 |  | STE-U FM 1 Thermal Vacuum/Balance | 14d | 2004-03-17 | 2004-04-05 | 275FS-10d |  | 51d |  |
| 277 | 1.5.4.3.3 | **FM 2** | 153d | 2003-08-29 A | 2004-04-09 |  | 48% | 88d |  |
| 278 |  | Fabricate STE FM 2 Detector Printed Wiring Board | 29d | 2003-08-29 A | 2003-10-09 A |  | 100% |  | start no earlier than 2003-08-29 |
| 279 |  | Load STE FM 2 Detector Printed Wiring Board | 63d | 2003-11-05 A | 2004-02-06 | 268 | 60% | 76d |  |
| 280 |  | Test STE FM 2 Detector Printed Wiring Board | 10d | 2004-02-09 | 2004-02-23 | 279 |  | 76d |  |

| ID | WBS | Task | Duration | Start | Finish | Predecessors | Complete | Total float | Constraint |
| --- | --- | --- | --- | --- | --- | --- | --- | --- | --- |
| 281 | 1.5.4.3.3.4 | **Integration & Test** | 28d | 2004-03-03 | 2004-04-09 |  |  | 70d |  |
| 282 |  | Integrate & Test STE-U/D FM 2 Detectors W/ FM 2 Housings | 10d | 2004-03-03 | 2004-03-16 | 266, 280, 274 |  | 70d |  |
| 283 |  | Calibrate STE-U/D FM 2 | 18d | 2004-03-17 | 2004-04-09 | 282 |  | 70d |  |
| 284 |  | STE-U FM 2 Thermal Vacuum | 10d | 2004-03-29 | 2004-04-09 | 283FS-10d |  | 88d |  |
| 285 | 1.5.5 | **STE and SWEA - UCB** | 289d | 2003-07-01 A | 2004-08-20 |  | 67% | 21d |  |
| 286 | 1.5.5.1 | **Deliveries** | 119d | 2004-01-26 | 2004-07-13 |  |  | 49d |  |
| 287 |  | Deliver STE-U FM 1 Interface (stays at UCB for IDPU FM 1 I&T) | 0d | 2004-01-26 | 2004-01-26 | 336 |  | 102d |  |
| 288 |  | Deliver STE-U FM 2 Interface (stays at UCB for IDPU FM 2 I&T) | 0d | 2004-01-26 | 2004-01-26 | 345 |  | 108d |  |
| 289 |  | Deliver SWEA/STE-D FM 1 (stays at UCB for Boom Suite FM 1 I&T) | 0d | 2004-05-14 | 2004-05-14 | 342 |  | 49d |  |
| 290 |  | Deliver SWEA/STE-D FM 2 (stays at UCB for Boom Suite FM 2 I&T) | 0d | 2004-07-13 | 2004-07-13 | 351 |  | 49d |  |
| 291 | 1.5.5.2 | **SWEA Pedestal** | 137d | 2003-07-01 A | 2004-01-16 |  | 92% | 98d |  |
| 292 |  | Fabricate SWEA FM 1 Baseplate | 137d | 2003-07-01 A | 2004-01-16 |  | 92% | 72d | start no earlier than 2003-07-01 |
| 293 |  | Fabricate SWEA FM 2 Baseplate | 137d | 2003-07-01 A | 2004-01-16 |  | 92% | 98d | start no earlier than 2003-07-01 |
| 294 | 1.5.5.3 | **STE-D Pre-Amp Board** | 54d | 2003-09-22 A | 2003-12-09 |  | 89% | 124d |  |
| 295 | 1.5.5.3.1 | **FM 1** | 54d | 2003-09-22 A | 2003-12-09 |  | 87% | 98d |  |
| 296 |  | Fabricate STE-D FM 1 Preamp Printed Wiring Board | 34d | 2003-09-22 A | 2003-11-07 A |  | 100% |  | start no earlier than 2003-09-22 |
| 297 |  | Load STE-D FM 1 Preamp Printed Wiring Board | 5d | 2003-12-03 | 2003-12-09 | 301 |  | 98d |  |
| 298 | 1.5.5.3.2 | **FM 2** | 54d | 2003-09-22 A | 2003-12-09 |  | 87% | 124d |  |
| 299 |  | Fabricate STE-D FM 2 Preamp Printed Wiring Board | 34d | 2003-09-22 A | 2003-11-07 A |  | 100% |  | start no earlier than 2003-09-22 |
| 300 |  | Load STE-D FM 2 Preamp Printed Wiring Board | 5d | 2003-12-03 | 2003-12-09 | 301 |  | 124d |  |
| 301 |  | Coupon Test STE-D FM 1 & FM 2 Pre-Amp Printed Wiring Boards | 15d | 2003-11-10 A | 2003-12-02 A | 296, 299 | 100% |  |  |
| 302 | 1.5.5.4 | **STE-D Shaper Board** | 30d | 2003-12-04 A | 2004-01-16 |  | 64% | 98d |  |
| 303 | 1.5.5.4.1 | **FM 1** | 30d | 2003-12-04 A | 2004-01-16 |  | 67% | 72d |  |
| 304 |  | Fabricate STE-D FM 1 Shaper Printed Wiring Board | 10d | 2003-12-04 A | 2003-12-17 A |  | 100% |  | start no earlier than 2003-12-04 |
| 305 |  | Load STE-D FM 1 Shaper Printed Wiring Board | 5d | 2004-01-12 | 2004-01-16 | 309 |  | 72d |  |
| 306 | 1.5.5.4.2 | **FM 2** | 30d | 2003-12-04 A | 2004-01-16 |  | 67% | 98d |  |
| 307 |  | Fabricate STE-D FM 2 Shaper Printed Wiring Board | 10d | 2003-12-04 A | 2003-12-17 A |  | 100% |  | start no earlier than 2003-12-04 |
| 308 |  | Load STE-D FM 2 Shaper Printed Wiring Board | 5d | 2004-01-12 | 2004-01-16 | 309 |  | 98d |  |
| 309 |  | Coupon Test STE-D FM 1 & FM 2 Shaper Printed Wiring Boards | 15d | 2003-12-18 A | 2004-01-09 | 304, 307 | 60% | 72d |  |
| 310 | 1.5.5.5 | **STE-D Interface Board** | 30d | 2003-12-04 A | 2004-01-16 |  | 64% | 98d |  |
| 311 | 1.5.5.5.1 | **FM 1** | 30d | 2003-12-04 A | 2004-01-16 |  | 67% | 72d |  |
| 312 |  | Fabricate SWEA / STE-D FM 1 Digital to Analog Converter Printed Wiring Board | 10d | 2003-12-04 A | 2003-12-17 A |  | 100% |  | start no earlier than 2003-12-04 |
| 313 |  | Load SWEA / STE-D FM 1 Digital to Analog Converter Printed Wiring Board | 5d | 2004-01-12 | 2004-01-16 | 317 |  | 72d |  |
| 314 | 1.5.5.5.2 | **FM 2** | 30d | 2003-12-04 A | 2004-01-16 |  | 67% | 98d |  |
| 315 |  | Fabricate SWEA / STE-D FM 2 Digital to Analog Converter Printed Wiring Board | 10d | 2003-12-04 A | 2003-12-17 A |  | 100% |  | start no earlier than 2003-12-04 |
| 316 |  | Load SWEA / STE-D FM 2 Digital to Analog Converter Printed Wiring Board | 5d | 2004-01-12 | 2004-01-16 | 317 |  | 98d |  |
| 317 |  | Coupon Test STE-D FM 1 & FM 2 D/A Converter Printed Wiring Boards | 15d | 2003-12-18 A | 2004-01-09 | 312, 315 | 60% | 72d |  |
| 318 | 1.5.5.6 | **STE-U Pre-Amp Board** | 79d | 2003-09-22 A | 2004-01-15 |  | 95% | 109d |  |
| 319 | 1.5.5.6.1 | **FM 1** | 79d | 2003-09-22 A | 2004-01-15 A |  | 100% |  |  |
| 320 |  | Fabricate STE-U FM 1 Preamp Printed Wiring Board | 34d | 2003-09-22 A | 2003-11-07 A |  | 100% |  | start no earlier than 2003-09-22 |
| 321 |  | Load STE-U FM 1 Preamp Printed Wiring Board | 4d | 2004-01-12 A | 2004-01-15 A | 325 | 100% |  | start no earlier than 2004-01-12 |
| 322 | 1.5.5.6.2 | **FM 2** | 54d | 2003-09-22 A | 2003-12-09 |  | 87% | 134d |  |
| 323 |  | Fabricate STE-U FM 2 Preamp Printed Wiring Board | 34d | 2003-09-22 A | 2003-11-07 A |  | 100% |  | start no earlier than 2003-09-22 |
| 324 |  | Load STE-U FM 2 Preamp Printed Wiring Board | 5d | 2003-12-03 | 2003-12-09 | 325 |  | 134d |  |
| 325 |  | Coupon Test STE-U FM 1 & FM 2 Pre-Amp Printed Wiring Boards | 15d | 2003-11-10 A | 2003-12-02 A | 320, 323 | 100% |  |  |
| 326 | 1.5.5.7 | **STE-U Shaper & Interface Board** | 30d | 2003-12-04 A | 2004-01-16 |  | 64% | 108d |  |
| 327 | 1.5.5.7.1 | **FM 1** | 30d | 2003-12-04 A | 2004-01-16 |  | 67% | 102d |  |
| 328 |  | Fabricate STE-U FM 1Shaper & Interface Printed Wiring Board | 10d | 2003-12-04 A | 2003-12-17 A |  | 100% |  | start no earlier than 2003-12-04 |
| 329 |  | Load STE-U FM 1 Shaper & Interface Printed Wiring Board | 5d | 2004-01-12 | 2004-01-16 | 333 |  | 102d |  |
| 330 | 1.5.5.7.2 | **FM 2** | 30d | 2003-12-04 A | 2004-01-16 |  | 67% | 108d |  |
| 331 |  | Fabricate STE-U FM 2 Shaper & Interface Printed Wiring Board | 10d | 2003-12-04 A | 2003-12-17 A |  | 100% |  | start no earlier than 2003-12-04 |
| 332 |  | Load STE-U FM 2 Shaper & Interface Printed Wiring Board | 5d | 2004-01-12 | 2004-01-16 | 333 |  | 108d |  |
| 333 |  | Coupon Test STE-U FM 1 & FM 2 Shaper & Interface Printed Wiring Boards | 15d | 2003-12-18 A | 2004-01-09 | 328, 331 | 60% | 102d |  |
| 334 | 1.5.5.8 | **Integration & Test** | 152d | 2004-01-20 | 2004-08-20 |  |  | 21d |  |
| 335 | 1.5.5.8.1 | **FM 1** | 152d | 2004-01-20 | 2004-08-20 |  |  | 18d |  |
| 336 |  | Integrate & Test STE-U FM 1 Interface Boards | 5d | 2004-01-20 | 2004-01-26 | 321, 329 |  | 102d |  |
| 337 |  | Integrate & Test SWEA/STE-D FM 1 Interface Boards | 20d | 2004-01-20 | 2004-02-17 | 292, 297, 305, 313 |  | 72d |  |
| 338 |  | Integrate & Test SWEA/STE-D FM 1 Interface with SWEA/STE-D FM 1 LVPS | 10d | 2004-03-22 | 2004-04-02 | 337, 70 |  | 49d |  |
| 339 |  | Clean/Coat/Stake SWEA/STE-D Interface | 10d | 2004-02-18 | 2004-03-02 | 337 |  | 72d |  |
| 340 |  | Integrate & Test SWEA/STE-D FM 1 Combined | 5d | 2004-04-05 | 2004-04-09 | 338, 339, 253, 260 |  | 49d |  |
| 341 |  | Calibrate SWEA/STE FM 1 | 20d | 2004-04-12 | 2004-05-07 | 340 |  | 49d |  |
| 342 |  | SWEA/STE FM 1 Vibration | 5d | 2004-05-10 | 2004-05-14 | 341 |  | 49d |  |
| 343 |  | SWEA/STE-D FM 1 Thermal Vac/Thermal Balance | 14d | 2004-08-03 | 2004-08-20 | 16 |  | 18d |  |
| 344 | 1.5.5.8.2 | **FM 2** | 124d | 2004-01-20 | 2004-07-13 |  |  | 49d |  |
| 345 |  | Integrate & Test STE-U FM 2 Interface Boards | 5d | 2004-01-20 | 2004-01-26 | 324, 332 |  | 108d |  |
| 346 |  | Integrate & Test SWEA/STE-D FM 2 Interface Boards | 20d | 2004-01-20 | 2004-02-17 | 293, 300, 308, 316 |  | 98d |  |
| 347 |  | Integrate & Test SWEA/STE-D FM 2 Interface with SWEA/STE-D FM 2 LVPS | 10d | 2004-04-27 | 2004-05-10 | 346, 76 |  | 49d |  |
| 348 |  | Integrate & Test SWEA/STE-D FM 2 Combined | 10d | 2004-05-11 | 2004-05-24 | 347, 254, 261 |  | 49d |  |
| 349 |  | Calibrate SWEA/STE FM 2 | 20d | 2004-05-25 | 2004-06-22 | 348 |  | 49d |  |
| 350 |  | SWEA/STE FM 2 Vibration | 5d | 2004-06-23 | 2004-06-29 | 349 |  | 49d |  |

| ID | WBS | Task | Duration | Start | Finish | Predecessors | Complete | Total float | Constraint |
| --- | --- | --- | --- | --- | --- | --- | --- | --- | --- |
| 351 |  | SWEA/STE-D FM 2 Thermal Vac | 10d | 2004-06-30 | 2004-07-13 | 350 |  | 49d |  |
| 352 | 1.5.6 | **Boom Suite I&T - UCB** | 110d | 2004-04-09 | 2004-09-13 |  |  | 32d |  |
| 353 | 1.5.6.1 | **FM 1** | 110d | 2004-04-09 | 2004-09-13 |  |  | 18d |  |
| 354 |  | FM 1 Boom/MAG/STE-U I&T | 4d | 2004-04-09 | 2004-04-14 | 215, 243, 262 |  | 48d |  |
| 355 |  | FM 1 Boom/SWEA/STE/MAG I&T | 2d | 2004-05-18 | 2004-05-19 | 289, 189 |  | 48d |  |
| 356 |  | FM 1 Integrated Boom/IDPU I&T | 4d | 2004-07-01 | 2004-07-06 | 355, 189, 836 |  | 19d |  |
| 357 |  | BOOM Suite FM 1 Bakeout | 5d | 2004-08-23 | 2004-08-27 | 356, 343 |  | 18d |  |
| 358 |  | Final BOOM Suite FM 1 I & T | 10d | 2004-08-30 | 2004-09-13 | 357, 179 |  | 18d |  |
| 359 | 1.5.6.2 | **FM 2** | 101d | 2004-04-12 | 2004-08-31 |  |  | 40d |  |
| 360 |  | FM 2 Boom/MAG/STE-U I&T | 4d | 2004-04-12 | 2004-04-15 | 237, 244, 263 |  | 88d |  |
| 361 |  | FM 2 Boom/SWEA/STE/MAG I&T | 2d | 2004-07-14 | 2004-07-15 | 290, 190 |  | 49d |  |
| 362 |  | FM 2 Integrated Boom/IDPU I&T | 4d | 2004-07-29 | 2004-08-03 | 361, 849, 190 |  | 40d |  |
| 363 |  | Boom Suite FM 2 EMC | 5d | 2004-08-04 | 2004-08-10 | 362 |  | 40d |  |
| 364 |  | BOOM Suite FM 2 Bakeout | 5d | 2004-08-11 | 2004-08-17 | 363 |  | 40d |  |
| 365 |  | Final BOOM Suite FM 2 I & T | 10d | 2004-08-18 | 2004-08-31 | 364, 184 |  | 40d |  |
| 366 | 1.6 | **SEP Suite - CIT** | 376d | 2003-06-02 A | 2004-11-26 |  | 31% | 0d |  |
| 367 | 1.6.1 | **SEP Mechanical - Sandy Shuman (GSFC)** | 82d | 2004-01-22 | 2004-05-17 |  |  | 5d |  |
| 368 | 1.6.1.1 | **SIT Electronics Enclosure (Priority 1)** | 21d | 2004-01-22 | 2004-02-20 |  |  | 5d |  |
| 369 |  | Complete Design/Drawings for SIT Enclosure | 5d | 2004-01-22 | 2004-01-28 |  |  | 5d | start no earlier than 2004-01-22 |
| 370 |  | Fabrication of SIT Enclosure | 10d | 2004-01-29 | 2004-02-11 | 369 |  | 53d |  |
| 371 |  | Inspection and Final Assembly of SIT Enclosure | 5d | 2004-02-12 | 2004-02-19 | 370 |  | 53d |  |
| 372 |  | Deliver SIT Enclosure to UMD | 1d | 2004-02-20 | 2004-02-20 | 371 |  | 53d |  |
| 373 | 1.6.1.2 | **SEP FM 1 & FM 2 LVPS Boxes (Priority 2)** | 23d | 2004-01-29 | 2004-03-02 |  |  | 5d |  |
| 374 |  | Complete Design/Drawings for SEP LVPS Boxes | 5d | 2004-01-29 | 2004-02-04 | 369 |  | 5d |  |
| 375 |  | Fabrication of SEP LVPS Boxes | 10d | 2004-02-05 | 2004-02-19 | 374 |  | 62d |  |
| 376 |  | Inspection and Final Assembly of SEP LVPS Boxes | 5d | 2004-02-20 | 2004-02-26 | 375 |  | 62d |  |
| 377 |  | Deliver SEP LVPS Boxes to UCB | 3d | 2004-02-27 | 2004-03-02 | 376 |  | 62d |  |
| 378 | 1.6.1.3 | **LET Telescope (Priority 3)** | 26d | 2004-02-05 | 2004-03-12 |  |  | 5d |  |
| 379 |  | Complete Design/Drawings for LET Telescope | 8d | 2004-02-05 | 2004-02-17 | 374 |  | 5d |  |
| 380 |  | Fabrication of LET Telescope | 10d | 2004-02-18 | 2004-03-02 | 379 |  | 47d |  |
| 381 |  | Inspection and Final Assembly of LET Telescope | 5d | 2004-03-03 | 2004-03-09 | 380 |  | 47d |  |
| 382 |  | Deliver LET Telescope to CIT | 3d | 2004-03-10 | 2004-03-12 | 381 |  | 47d |  |
| 383 | 1.6.1.4 | **SEP Central Bias Supply Shields (Priority 4)** | 20d | 2004-02-18 | 2004-03-16 |  |  | 5d |  |
| 384 |  | Complete Design/Drawings for Bias Supply Shields | 5d | 2004-02-18 | 2004-02-24 | 379 |  | 5d |  |
| 385 |  | Fabrication of Bias Supply Shields | 10d | 2004-02-25 | 2004-03-09 | 384 |  | 51d |  |
| 386 |  | Inspection and Delivery (to CIT) of Bias Supply Shields | 5d | 2004-03-10 | 2004-03-16 | 385 |  | 51d |  |
| 387 | 1.6.1.5 | **SEP Electronics Enclosure (Priority 5)** | 31d | 2004-02-25 | 2004-04-07 |  |  | 5d |  |
| 388 |  | Complete Design/Drawings for SEP Enclosure | 13d | 2004-02-25 | 2004-03-12 | 384 |  | 5d |  |
| 389 |  | Fabrication of SEP Enclosure | 10d | 2004-03-15 | 2004-03-26 | 388 |  | 47d |  |
| 390 |  | Inspection and Final Assembly of SEP Enclosure | 5d | 2004-03-29 | 2004-04-02 | 389 |  | 47d |  |
| 391 |  | Deliver SEP Enclosure to CIT | 3d | 2004-04-05 | 2004-04-07 | 390 |  | 47d |  |
| 392 | 1.6.1.6 | **HET Electronics Enclosure (Priority 6)** | 23d | 2004-03-15 | 2004-04-14 |  |  | 5d |  |
| 393 |  | Complete Design/Drawings for HET Enclosure | 8d | 2004-03-15 | 2004-03-24 | 388 |  | 5d |  |
| 394 |  | Fabrication of HET Enclosure | 10d | 2004-03-25 | 2004-04-07 | 393 |  | 23d |  |
| 395 |  | Inspection and Final Assembly of HET Enclosure | 5d | 2004-04-08 | 2004-04-14 | 394 |  | 23d |  |
| 396 |  | Deliver HET Enclosure (stays at GSFC) | 0d | 2004-04-14 | 2004-04-14 | 395 |  | 23d |  |
| 397 | 1.6.1.7 | **SIT Telescope (Priority 7)** | 34d | 2004-03-25 | 2004-05-11 |  |  | 5d |  |
| 398 |  | Complete Design/Drawings for SIT Telescope | 18d | 2004-03-25 | 2004-04-19 | 393 |  | 5d |  |
| 399 |  | Fabrication of SIT Telescope | 10d | 2004-04-20 | 2004-05-03 | 398 |  | 9d |  |
| 400 |  | Inspection and Final Assembly of SIT Telescope | 5d | 2004-05-04 | 2004-05-10 | 399 |  | 9d |  |
| 401 |  | Deliver SIT Telescope to UMD | 1d | 2004-05-11 | 2004-05-11 | 400 |  | 9d |  |
| 402 | 1.6.1.8 | **HET Telescope (Priority 8)** | 20d | 2004-04-20 | 2004-05-17 |  |  | 5d |  |
| 403 |  | Complete Design/Drawings for HET Telescope | 5d | 2004-04-20 | 2004-04-26 | 398 |  | 5d |  |
| 404 |  | Fabrication of HET Telescope | 10d | 2004-04-27 | 2004-05-10 | 403 |  | 5d |  |
| 405 |  | Inspection and Final Assembly of HET Telescope | 5d | 2004-05-11 | 2004-05-17 | 404, 396 |  | 5d |  |
| 406 |  | Deliver HET Telescope (stays at GSFC) | 0d | 2004-05-17 | 2004-05-17 | 405 |  | 5d |  |
| 407 | 1.6.2 | **SEP Central - CIT** | 176d | 2003-08-01 A | 2004-04-14 |  | 38% | 68d |  |
| 408 | 1.6.2.1 | **Deliveries** | 31d | 2004-03-02 | 2004-04-14 |  |  | 68d |  |
| 409 |  | Deliver SEP Cen FM 1 Logic Board (stays at CIT for SEP Suite I&T) | 0d | 2004-04-14 | 2004-04-14 | 435 |  | 42d |  |
| 410 |  | Deliver SEP Cen FM 2 Logic Board (stays at CIT for SEP Suite I&T) | 0d | 2004-04-14 | 2004-04-14 | 442 |  | 68d |  |
| 411 |  | Deliver SEP Cen FM 1 Analog/Post-Reg Board (stays at CIT for SEP Suite I&T) | 0d | 2004-04-09 | 2004-04-09 | 460 |  | 45d |  |
| 412 |  | Deliver SEP Cen FM 2 Analog/Post-Reg Board (stays at CIT for SEP Suite I&T) | 0d | 2004-04-09 | 2004-04-09 | 467 |  | 71d |  |
| 413 |  | Deliver SEP Cen FM 1 SSD Bias Supply Board (stays at CIT for SEP Suite I&T) | 0d | 2004-04-09 | 2004-04-09 | 485 |  | 45d |  |
| 414 |  | Deliver SEP Cen FM 2 SSD Bias Supply Board (stays at CIT for SEP Suite I&T) | 0d | 2004-04-09 | 2004-04-09 | 492 |  | 71d |  |
| 415 |  | Deliver Final SEP Central Flight Software to SEP I&T | 0d | 2004-03-02 | 2004-03-02 | 495 |  | 73d |  |
| 416 | 1.6.2.2 | **Logic Board** | 67d | 2004-01-09 | 2004-04-14 |  |  | 68d |  |
| 417 | 1.6.2.2.1 | **Assembly** | 26d | 2004-01-09 | 2004-02-17 |  |  | 86d |  |
| 418 | 1.6.2.2.1.1 | **FM 1** | 13d | 2004-01-09 | 2004-01-28 |  |  | 86d |  |
| 419 |  | Assemble FM 1 SEP Central Logic board | 5d | 2004-01-09 | 2004-01-15 |  |  | 86d | start no earlier than 2004-01-09 |
| 420 |  | Post-assembly QA inspection of FM 1 SEP Central Logic Board | 1d | 2004-01-16 | 2004-01-16 | 419 |  | 86d |  |

| ID | WBS | Task | Duration | Start | Finish | Predecessors | Complete | Total float | Constraint |
| --- | --- | --- | --- | --- | --- | --- | --- | --- | --- |
| 421 |  | Rework/haywire/trim FM 1 SEP Central Logic board | 1d | 2004-01-27 | 2004-01-27 | 430 |  | 86d |  |
| 422 |  | Post-rework QA inspection of FM 1 SEP Central Logic Board | 1d | 2004-01-28 | 2004-01-28 | 421 |  | 86d |  |
| 423 | 1.6.2.2.1.2 | **FM 2** | 21d | 2004-01-16 | 2004-02-17 |  |  | 99d |  |
| 424 |  | Assemble FM 2 SEP Central Logic board | 5d | 2004-01-16 | 2004-01-23 | 419 |  | 107d |  |
| 425 |  | Post-assembly QA inspection of FM 2 SEP Central Logic Board | 1d | 2004-01-26 | 2004-01-26 | 424 |  | 107d |  |
| 426 |  | Rework/haywire/trim FM 2 SEP Central Logic board | 1d | 2004-02-09 | 2004-02-09 | 437 |  | 103d | start no earlier than 2004-02-09 |
| 427 |  | Post-rework QA inspection of FM 2 SEP Central Logic Boards | 1d | 2004-02-17 | 2004-02-17 | 426 |  | 99d | start no earlier than 2004-02-17 |
| 428 | 1.6.2.2.2 | **Test** | 61d | 2004-01-20 | 2004-04-14 |  |  | 68d |  |
| 429 | 1.6.2.2.2.1 | **FM 1** | 61d | 2004-01-20 | 2004-04-14 |  |  | 42d |  |
| 430 |  | Test FM 1 SEP Central Logic board (initial) | 5d | 2004-01-20 | 2004-01-26 | 420 |  | 86d |  |
| 431 |  | Stake/conformal coat FM 1 SEP Central Logic board | 2d | 2004-04-01 | 2004-04-02 | 422 |  | 42d | start no earlier than 2004-04-01 |
| 432 |  | Bakeout FM 1 SEP Central Logic board | 1d | 2004-04-05 | 2004-04-05 | 431 |  | 42d |  |
| 433 |  | Post-conf. coat QA inspection of FM 1 SEP Central Logic Board | 1d | 2004-04-06 | 2004-04-06 | 432 |  | 42d |  |
| 434 |  | Test FM 1 SEP Central Logic board (final) | 5d | 2004-04-07 | 2004-04-13 | 433 |  | 42d |  |
| 435 |  | FM 1 SEP Central Logic Board Mass properties/photo | 1d | 2004-04-14 | 2004-04-14 | 434 |  | 42d |  |
| 436 | 1.6.2.2.2.2 | **FM 2** | 56d | 2004-01-27 | 2004-04-14 |  |  | 68d |  |
| 437 |  | Test FM 2 SEP Central Logic board (initial) | 5d | 2004-01-27 | 2004-02-02 | 425 |  | 107d |  |
| 438 |  | Stake/conformal coat FM 2 SEP Central Logic board | 2d | 2004-04-01 | 2004-04-02 | 427 |  | 68d | start no earlier than 2004-04-01 |
| 439 |  | Bakeout FM 2 SEP Central Logic board | 1d | 2004-04-05 | 2004-04-05 | 438 |  | 68d |  |
| 440 |  | Post-conf. coat QA inspection of FM 2 SEP Central Logic Board | 1d | 2004-04-06 | 2004-04-06 | 439 |  | 68d |  |
| 441 |  | Test FM 2 SEP Central Logic board (final) | 5d | 2004-04-07 | 2004-04-13 | 440 |  | 68d |  |
| 442 |  | FM 2 SEP Central Logic Board Mass properties/photo | 1d | 2004-04-14 | 2004-04-14 | 441 |  | 68d |  |
| 443 | 1.6.2.3 | **Analog/Post-Reg Board** | 88d | 2003-12-04 A | 2004-04-09 |  | 24% | 71d |  |
| 444 | 1.6.2.3.1 | **Assembly** | 45d | 2003-12-04 A | 2004-02-09 |  | 59% | 107d |  |
| 445 | 1.6.2.3.1.1 | **FM 1** | 45d | 2003-12-04 A | 2004-02-09 |  | 61% | 81d |  |
| 446 |  | Assemble Analog/Post-reg Flight Printed Circuit Board 1 | 5d | 2003-12-04 A | 2003-12-10 |  | 85% | 116d | start no earlier than 2003-12-04 |
| 447 |  | Rework/haywire/trim Analog/Post-reg Flight Board 1 | 1d | 2004-02-06 | 2004-02-06 | 455 |  | 81d |  |
| 448 |  | Post rework QA inspection Flight Board 1 | 1d | 2004-02-09 | 2004-02-09 | 447 |  | 81d |  |
| 449 | 1.6.2.3.1.2 | **FM 2** | 40d | 2003-12-11 A | 2004-02-09 |  | 57% | 107d |  |
| 450 |  | Assemble Analog/Post-reg Flight Printed Circuit Board 2 | 5d | 2003-12-11 A | 2003-12-17 | 446 | 80% | 137d |  |
| 451 |  | Rework/haywire/trim Analog/Post-reg Flight Board 2 | 1d | 2004-02-06 | 2004-02-06 | 462 |  | 107d |  |
| 452 |  | Post rework QA inspection Flight Board 2 | 1d | 2004-02-09 | 2004-02-09 | 451 |  | 107d |  |
| 453 | 1.6.2.3.2 | **Test** | 48d | 2004-02-03 | 2004-04-09 |  |  | 71d |  |
| 454 | 1.6.2.3.2.1 | **FM 1** | 48d | 2004-02-03 | 2004-04-09 |  |  | 45d |  |
| 455 |  | Test Analog/Post-reg Flight Board 1 (initial) | 3d | 2004-02-03 | 2004-02-05 | 446 |  | 81d | start no earlier than 2004-02-03 |
| 456 |  | Stake/conformal coat Analog/Post-reg Flight Board 1 | 2d | 2004-04-01 | 2004-04-02 | 448 |  | 45d | start no earlier than 2004-04-01 |
| 457 |  | Bakeout Analog/Post-reg Flight Board 1 | 1d | 2004-04-05 | 2004-04-05 | 456 |  | 45d |  |
| 458 |  | Post-conf coat QA inspection Flight Board 1 | 1d | 2004-04-06 | 2004-04-06 | 457 |  | 45d |  |
| 459 |  | Test Analog/Post-reg Flight Board 1 (final) | 2d | 2004-04-07 | 2004-04-08 | 458 |  | 45d |  |
| 460 |  | Analog/Post-reg Flight Board 1 Mass properties/photo | 1d | 2004-04-09 | 2004-04-09 | 459 |  | 45d |  |
| 461 | 1.6.2.3.2.2 | **FM 2** | 48d | 2004-02-03 | 2004-04-09 |  |  | 71d |  |
| 462 |  | Test Analog/Post-reg Flight Board 2 (initial) | 3d | 2004-02-03 | 2004-02-05 | 450 |  | 107d | start no earlier than 2004-02-03 |
| 463 |  | Stake/conformal coat Analog/Post-reg Flight Board 2 | 2d | 2004-04-01 | 2004-04-02 | 452 |  | 71d | start no earlier than 2004-04-01 |
| 464 |  | Bakeout Analog/Post-reg Flight Board 2 | 1d | 2004-04-05 | 2004-04-05 | 463 |  | 71d |  |
| 465 |  | Post-conf coat QA inspection Flight Board 2 | 1d | 2004-04-06 | 2004-04-06 | 464 |  | 71d |  |
| 466 |  | Test Analog/Post-reg Flight Board 2 (final) | 2d | 2004-04-07 | 2004-04-08 | 465 |  | 71d |  |
| 467 |  | Analog/Post-reg Flight Board 2 Mass properties/photo | 1d | 2004-04-09 | 2004-04-09 | 466 |  | 71d |  |
| 468 | 1.6.2.4 | **SEP Solid State Detector Bias Supply Board** | 63d | 2004-01-12 | 2004-04-09 |  |  | 71d |  |
| 469 | 1.6.2.4.1 | **Assembly** | 53d | 2004-01-12 | 2004-03-26 |  |  | 74d |  |
| 470 | 1.6.2.4.1.1 | **FM 1** | 50d | 2004-01-12 | 2004-03-23 |  |  | 51d |  |
| 471 |  | Assemble flight Solid State Detector Bias Supply Printed Circuit Board 1 | 10d | 2004-01-12 | 2004-01-26 |  |  | 86d | start no earlier than 2004-01-12 |
| 472 |  | Rework/haywire/trim Solid State Detector Bias Supply flight board 1 | 1d | 2004-03-22 | 2004-03-22 | 480 |  | 51d |  |
| 473 |  | Post rework QA inspection of Solid State Detector Bias Supply board 1 | 1d | 2004-03-23 | 2004-03-23 | 472 |  | 51d |  |
| 474 | 1.6.2.4.1.2 | **FM 2** | 43d | 2004-01-27 | 2004-03-26 |  |  | 74d |  |
| 475 |  | Assemble flight Solid State Detector Bias Supply Printed Circuit Board 2 | 10d | 2004-01-27 | 2004-02-09 | 471 |  | 102d |  |
| 476 |  | Rework/haywire/trim Solid State Detector Bias Supply flight board 2 | 1d | 2004-03-25 | 2004-03-25 | 487 |  | 74d |  |
| 477 |  | Post rework QA inspection of Solid State Detector Bias Supply board 2 | 1d | 2004-03-26 | 2004-03-26 | 476 |  | 74d |  |
| 478 | 1.6.2.4.2 | **Test** | 18d | 2004-03-17 | 2004-04-09 |  |  | 51d |  |
| 479 | 1.6.2.4.2.1 | **FM 1** | 18d | 2004-03-17 | 2004-04-09 |  |  | 45d |  |
| 480 |  | Test Solid State Detector Bias Supply flight board 1 (initial) | 3d | 2004-03-17 | 2004-03-19 | 471, 386 |  | 51d |  |
| 481 |  | Stake/conformal coat Solid State Detector Bias Supply flight board 1 | 2d | 2004-04-01 | 2004-04-02 | 473 |  | 45d | start no earlier than 2004-04-01 |
| 482 |  | Bakeout Solid State Detector Bias Supply flight board 1 | 1d | 2004-04-05 | 2004-04-05 | 481 |  | 45d |  |
| 483 |  | Post-conf coat QA inspection of Solid State Detector Bias Supply board 1 | 1d | 2004-04-06 | 2004-04-06 | 482 |  | 45d |  |
| 484 |  | Test Solid State Detector Bias Supply flight board 1 (final) | 2d | 2004-04-07 | 2004-04-08 | 483 |  | 45d |  |
| 485 |  | Solid State Detector Bias Supply FM 1 Mass properties/photo | 1d | 2004-04-09 | 2004-04-09 | 484 |  | 45d |  |
| 486 | 1.6.2.4.2.2 | **FM 2** | 15d | 2004-03-22 | 2004-04-09 |  |  | 71d |  |
| 487 |  | Test Solid State Detector Bias Supply flight board 2 (initial) | 3d | 2004-03-22 | 2004-03-24 | 475, 386, 480 |  | 74d |  |
| 488 |  | Stake/conformal coat Solid State Detector Bias Supply flight board 2 | 2d | 2004-04-01 | 2004-04-02 | 477 |  | 71d | start no earlier than 2004-04-01 |
| 489 |  | Bakeout Solid State Detector Bias Supply flight board 2 | 1d | 2004-04-05 | 2004-04-05 | 488 |  | 71d |  |
| 490 |  | Post-conf coat QA inspection of Solid State Detector Bias Supply board 2 | 1d | 2004-04-06 | 2004-04-06 | 489 |  | 71d |  |

| ID | WBS | Task | Duration | Start | Finish | Predecessors | Complete | Total float | Constraint |
| --- | --- | --- | --- | --- | --- | --- | --- | --- | --- |
| 491 |  | Test Solid State Detector Bias Supply flight board 2 (final) | 2d | 2004-04-07 | 2004-04-08 | 490 |  | 71d |  |
| 492 |  | Solid State Detector Bias Supply FM 2 Mass properties/photo | 1d | 2004-04-09 | 2004-04-09 | 491 |  | 71d |  |
| 493 | 1.6.2.5 | **Flight Software** | 145d | 2003-08-01 A | 2004-03-02 |  | 65% | 73d |  |
| 494 |  | SEP Central Build 3 | 105d | 2003-08-01 A | 2004-01-02 |  | 90% | 73d | start no earlier than 2003-08-01 |
| 495 |  | Final Flight S/W Build | 40d | 2004-01-05 | 2004-03-02 | 494 |  | 73d |  |
| 496 | 1.6.3 | **HET - GSFC** | 199d | 2003-10-01 | 2004-07-15 |  |  | 82d |  |
| 497 | 1.6.3.1 | **Deliveries** | 199d | 2003-10-01 | 2004-07-15 |  |  | 92d |  |
| 498 |  | Deliver HET FM 1 (to CIT for SEP Suite I&T) | 2d | 2004-06-16 | 2004-06-17 | 539 |  | 19d |  |
| 499 |  | Deliver HET FM 2 (to CIT for SEP Suite I&T) | 2d | 2004-07-14 | 2004-07-15 | 542 |  | 5d |  |
| 500 |  | Deliver Final HET Flight Software to SEP I&T | 2d | 2003-10-01 | 2003-10-02 |  |  | 289d |  |
| 501 | 1.6.3.2 | **Detectors** | 60d | 2004-01-06 | 2004-03-31 |  |  | 38d |  |
| 502 |  | Receive & Inspect HET Flight Detectors | 40d | 2004-01-06 | 2004-03-03 |  |  | 38d | start no earlier than 2004-01-06 |
| 503 | 1.6.3.2.2 | **Detector Testing** | 60d | 2004-01-06 | 2004-03-31 |  |  | 38d |  |
| 504 |  | Capacitance, Current, Depletion, Alpha Resin Testing | 60d | 2004-01-06 | 2004-03-31 | 502SS |  | 38d |  |
| 505 |  | Life Test HET Detectors | 60d | 2004-01-06 | 2004-03-31 | 504SS |  | 38d |  |
| 506 | 1.6.3.3 | **Electronics Board** | 82d | 2004-01-22 | 2004-05-17 |  |  | 7d |  |
| 507 | 1.6.3.3.1 | **Assembly** | 44d | 2004-01-22 | 2004-03-24 |  |  | 7d |  |
| 508 |  | Install Socket on HET Electronics FM 1 Board for ETU ACTEL | 1d | 2004-01-22 | 2004-01-22 |  |  | 7d | start no earlier than 2004-01-22 |
| 509 |  | Complete Population of HET Electronics FM 1 Board | 1d | 2004-01-23 | 2004-01-23 | 508 |  | 7d |  |
| 510 |  | Populate HET Electronics FM 2 Board | 10d | 2004-03-11 | 2004-03-24 | 509, 516, 561 |  | 7d |  |
| 511 | 1.6.3.3.2 | **Test** | 80d | 2004-01-26 | 2004-05-17 |  |  | 7d |  |
| 512 | 1.6.3.3.2.1 | **FM 1** | 78d | 2004-01-26 | 2004-05-13 |  |  | 7d |  |
| 513 |  | Test HET FM 1 Electronics Board w/ETU ACTEL | 20d | 2004-01-26 | 2004-02-23 | 509 |  | 7d |  |
| 514 |  | Remove ETU ACTEL and socket from HET FM 1 Electronics Board | 1d | 2004-02-24 | 2004-02-24 | 513 |  | 7d |  |
| 515 |  | Install Flight ACTEL on HET FM 1 Electronics Board | 1d | 2004-02-25 | 2004-02-25 | 514 |  | 7d |  |
| 516 |  | Retest HET FM 1 Electronics Board w/Flight ACTEL | 10d | 2004-02-26 | 2004-03-10 | 515, 561 |  | 7d |  |
| 517 |  | Conformal Coat HET FM 1 Electronics Board | 2d | 2004-03-11 | 2004-03-12 | 516 |  | 45d |  |
| 518 |  | Retest Conformal Coated HET FM 1 Electronics Board | 2d | 2004-05-06 | 2004-05-07 | 517, 522 |  | 7d |  |
| 519 |  | Bakeout HET FM 1 Electronics Board | 2d | 2004-05-10 | 2004-05-11 | 518 |  | 7d |  |
| 520 |  | Retest Bakedout HET FM 1 Electronics Board | 2d | 2004-05-12 | 2004-05-13 | 519, 524 |  | 7d |  |
| 521 | 1.6.3.3.2.2 | **FM 2** | 38d | 2004-03-25 | 2004-05-17 |  |  | 7d |  |
| 522 |  | Test HET FM 2 Electronics Board | 30d | 2004-03-25 | 2004-05-05 | 510, 513 |  | 7d |  |
| 523 |  | Conformal Coat HET FM 2 Electronics Board | 2d | 2004-05-06 | 2004-05-07 | 522 |  | 7d |  |
| 524 |  | Retest Conformal Coated HET FM 2 Electronics Board | 2d | 2004-05-10 | 2004-05-11 | 523, 518 |  | 7d |  |
| 525 |  | Bakeout HET FM 2 Electronics Board | 2d | 2004-05-12 | 2004-05-13 | 524 |  | 20d |  |
| 526 |  | Retest Bakedout HET FM 2 Electronics Board | 2d | 2004-05-14 | 2004-05-17 | 525, 520 |  | 20d |  |
| 527 | 1.6.3.4 | **Flight Software** | 70d | 2004-01-22 | 2004-04-29 |  |  | 17d |  |
| 528 | 1.6.3.4.1 | **Design** | 10d | 2004-01-22 | 2004-02-04 |  |  | 17d |  |
| 529 |  | Complete Definition of HET PH Event Processing | 10d | 2004-01-22 | 2004-02-04 |  |  | 17d | start no earlier than 2004-01-22 |
| 530 | 1.6.3.4.2 | **Coding** | 20d | 2004-02-05 | 2004-03-04 |  |  | 17d |  |
| 531 |  | Code HET PH Event Processing Update for Flight | 10d | 2004-02-05 | 2004-02-19 | 529 |  | 17d |  |
| 532 |  | Code HET Telemetry Formatting Update for Flight | 10d | 2004-02-20 | 2004-03-04 | 531 |  | 17d |  |
| 533 | 1.6.3.4.3 | **Test** | 40d | 2004-03-05 | 2004-04-29 |  |  | 17d |  |
| 534 |  | Test Integrated HET S/W with Simulated Data | 15d | 2004-03-05 | 2004-03-25 | 532 |  | 17d |  |
| 535 |  | Verify HET On-Board Software | 25d | 2004-03-26 | 2004-04-29 | 534 |  | 17d |  |
| 536 | 1.6.3.5 | **Integration & Test** | 40d | 2004-05-18 | 2004-07-13 |  |  | 5d |  |
| 537 | 1.6.3.5.1 | **FM 1** | 20d | 2004-05-18 | 2004-06-15 |  |  | 5d |  |
| 538 |  | Integrate HET FM 1 Electronics Telescope (Ahead) | 5d | 2004-05-18 | 2004-05-24 | 520, 406, 505, 535 |  | 5d |  |
| 539 |  | Test HET FM 1 Telescope (Ahead) | 15d | 2004-05-25 | 2004-06-15 | 538 |  | 5d |  |
| 540 | 1.6.3.5.2 | **FM 2** | 35d | 2004-05-25 | 2004-07-13 |  |  | 5d |  |
| 541 |  | Integrate HET FM 2 Electronics Telescope (Behind) | 5d | 2004-05-25 | 2004-06-01 | 526, 538, 406, 505, 535 |  | 15d |  |
| 542 |  | Test HET FM 2 Telescope (Behind) | 20d | 2004-06-16 | 2004-07-13 | 539, 541 |  | 5d |  |
| 543 | 1.6.4 | **LET - CIT** | 207d | 2003-07-14 A | 2004-05-07 |  | 51% | 53d |  |
| 544 | 1.6.4.1 | **Deliveries** | 79d | 2004-01-15 | 2004-05-07 |  |  | 53d |  |
| 545 |  | Deliver LET FM 1 (stays at CIT for SEP I&T) | 0d | 2004-05-07 | 2004-05-07 | 588, 600 |  | 47d |  |
| 546 |  | Deliver LET FM 2 (stays at CIT for SEP I&T) | 0d | 2004-05-07 | 2004-05-07 | 595, 602 |  | 53d |  |
| 547 |  | Deliver LET Flight Software Build 3 | 0d | 2004-01-15 | 2004-01-15 | 597 |  | 126d |  |
| 548 | 1.6.4.2 | **Detectors** | 142d | 2003-07-14 A | 2004-02-05 |  | 48% | 72d |  |
| 549 | 1.6.4.2.1 | **Detector Testing** | 136d | 2003-07-14 A | 2004-01-28 |  | 42% | 78d |  |
| 550 |  | Perform Detector Noise & breakdown Testing | 76d | 2003-09-02 A | 2003-12-19 |  | 35% | 103d | start no earlier than 2003-09-02 |
| 551 |  | Perform Detector Thermal Vac Testing | 75d | 2003-09-15 A | 2004-01-02 | 550SS+9d | 40% | 95d |  |
| 552 |  | Perform Detector Alphas Testing | 76d | 2003-09-02 A | 2003-12-19 | 550SS | 35% | 103d |  |
| 553 |  | Analyze Detector Testing Data | 75d | 2003-09-15 A | 2004-01-02 | 551SS, 552SS | 35% | 95d |  |
| 554 |  | Capacitance, Current, Depletion, Alpha Resolution | 136d | 2003-07-14 A | 2004-01-28 |  | 50% | 78d | start no earlier than 2003-07-14 |
| 555 |  | Life Test LET Flight Detectors | 76d | 2003-07-28 A | 2003-11-13 | 554SS+10d | 50% | 128d |  |
| 556 | 1.6.4.2.2 | **Hybrids** | 128d | 2003-08-01 A | 2004-02-05 |  | 72% | 20d |  |
| 557 |  | Package and Test Flight Hybrids Lot 1 (7-10 Parts) | 21d | 2003-08-01 A | 2003-08-29 A |  | 100% |  | start no earlier than 2003-08-01 |
| 558 |  | Package and Test Flight Hybrids Lot 2 (10 Parts) | 24d | 2003-09-02 A | 2003-10-03 A | 557 | 100% |  |  |
| 559 |  | Package and Test Flight Hybrids Lot 3 (20 Parts) | 83d | 2003-09-16 A | 2004-01-15 | 558SS+10d | 60% | 30d |  |
| 560 |  | Select parts for flight | 2d | 2004-02-02 | 2004-02-03 | 559, 557, 558 |  | 20d | start no earlier than 2004-02-02 |

| ID | WBS | Task | Duration | Start | Finish | Predecessors | Complete | Total float | Constraint |
| --- | --- | --- | --- | --- | --- | --- | --- | --- | --- |
| 561 |  | Deliver HET Hybrids to GSFC | 2d | 2004-02-04 | 2004-02-05 | 560 |  | 20d |  |
| 562 | 1.6.4.3 | **Detector/Misc Board** | 146d | 2003-09-15 A | 2004-04-14 |  | 62% | 70d |  |
| 563 | 1.6.4.3.1 | **Remaining Procurements** | 95d | 2003-09-15 A | 2004-02-02 |  | 99% | 80d |  |
| 564 |  | Procure LET Detector Board Flight Parts | 95d | 2003-09-15 A | 2004-02-02 |  | 99% | 80d | start no earlier than 2003-09-15 |
| 565 |  | Procure flight LET Detector Printed Circuit Board | 2d | 2003-10-14 A | 2003-10-15 A |  | 100% |  | start no earlier than 2003-10-14 |
| 566 | 1.6.4.3.2 | **Fabrication** | 58d | 2003-11-12 A | 2004-02-05 |  | 40% | 80d |  |
| 567 |  | Receive/inspect/database flight parts for LET Detector Board | 2d | 2004-02-03 | 2004-02-04 | 564 |  | 80d |  |
| 568 |  | Inspect flight LET Detector Printed Circuit Boards (coupons & elec continuity) | 2d | 2003-11-12 A | 2003-11-13 A | 565FS+18d | 100% |  |  |
| 569 |  | Burn-in flight FPGA/EEPROM for LET Detector Board | 1d | 2004-02-05 | 2004-02-05 | 567 |  | 80d |  |
| 570 | 1.6.4.3.3 | **Assembly** | 48d | 2004-02-06 | 2004-04-14 |  |  | 70d |  |
| 571 | 1.6.4.3.3.1 | **FM 1** | 18d | 2004-02-06 | 2004-03-03 |  |  | 80d |  |
| 572 |  | Assemble LET FM 1 Detector Board | 10d | 2004-02-06 | 2004-02-20 | 567, 568, 569 |  | 80d |  |
| 573 |  | Post-assembly QA inspection for flight LET Detector Boards | 1d | 2004-02-23 | 2004-02-23 | 572 |  | 84d |  |
| 574 |  | Rework/haywire/trim flight LET Detector Boards | 1d | 2004-03-02 | 2004-03-02 | 583 |  | 84d |  |
| 575 |  | Post-rework QA inspection for LET Detector Boards | 1d | 2004-03-03 | 2004-03-03 | 574 |  | 84d |  |
| 576 | 1.6.4.3.3.2 | **FM 2** | 18d | 2004-02-23 | 2004-03-17 |  |  | 80d |  |
| 577 |  | Assemble LET FM 2 Detector Board | 10d | 2004-02-23 | 2004-03-05 | 572 |  | 80d |  |
| 578 |  | Post-assembly QA inspection for flight LET Detector Boards | 1d | 2004-03-08 | 2004-03-08 | 577 |  | 80d |  |
| 579 |  | Rework/haywire/trim flight LET Detector Boards | 1d | 2004-03-16 | 2004-03-16 | 590 |  | 80d |  |
| 580 |  | Post-rework QA inspection for LET Detector Boards | 1d | 2004-03-17 | 2004-03-17 | 579 |  | 80d |  |
| 581 | 1.6.4.3.3.3 | **Test** | 37d | 2004-02-24 | 2004-04-14 |  |  | 70d |  |
| 582 | 1.6.4.3.3.3.1 | **FM 1** | 37d | 2004-02-24 | 2004-04-14 |  |  | 64d |  |
| 583 |  | Test LET FM 1 Detector Boards (initial) | 5d | 2004-02-24 | 2004-03-01 | 573 |  | 84d |  |
| 584 |  | Stake/conformal coat LET FM 1 Detector Boards | 2d | 2004-04-01 | 2004-04-02 | 575 |  | 64d | start no earlier than 2004-04-01 |
| 585 |  | Bakeout LET FM 1 Detector Boards | 1d | 2004-04-05 | 2004-04-05 | 584 |  | 64d |  |
| 586 |  | Post-conf. Coat QA inspection of LET FM 1 Detector Boards | 1d | 2004-04-06 | 2004-04-06 | 585 |  | 64d |  |
| 587 |  | Test LET FM 1 Detector Boards (final) | 5d | 2004-04-07 | 2004-04-13 | 586 |  | 64d |  |
| 588 |  | LET FM 1 Detector Board Mass properties/photo | 1d | 2004-04-14 | 2004-04-14 | 587 |  | 64d |  |
| 589 | 1.6.4.3.3.3.2 | **FM 2** | 27d | 2004-03-09 | 2004-04-14 |  |  | 70d |  |
| 590 |  | Test LET FM 2 Detector Boards (initial) | 5d | 2004-03-09 | 2004-03-15 | 578 |  | 80d |  |
| 591 |  | Stake/conformal coat LET FM 2 Detector Boards | 2d | 2004-04-01 | 2004-04-02 | 580 |  | 70d | start no earlier than 2004-04-01 |
| 592 |  | Bakeout LET FM 2 Detector Boards | 1d | 2004-04-05 | 2004-04-05 | 591 |  | 70d |  |
| 593 |  | Post-conf. Coat QA inspection of LET FM 2 Detector Boards | 1d | 2004-04-06 | 2004-04-06 | 592 |  | 70d |  |
| 594 |  | Test LET FM 2 Detector Boards (final) | 5d | 2004-04-07 | 2004-04-13 | 593 |  | 70d |  |
| 595 |  | LET FM 2 Detector Board Mass properties/photo | 1d | 2004-04-14 | 2004-04-14 | 594 |  | 70d |  |
| 596 | 1.6.4.4 | **Flight Software** | 114d | 2003-08-01 A | 2004-01-15 |  | 90% | 126d |  |
| 597 |  | Let Flight Software Build 3 | 114d | 2003-08-01 A | 2004-01-15 |  | 90% | 126d | start no earlier than 2003-08-01 |
| 598 | 1.6.4.5 | **Integration & Test** | 40d | 2004-03-15 | 2004-05-07 |  |  | 47d |  |
| 599 | 1.6.4.5.1 | **FM 1** | 40d | 2004-03-15 | 2004-05-07 |  |  | 47d |  |
| 600 |  | Integrate LET FM 1 Housing With Detectors | 40d | 2004-03-15 | 2004-05-07 | 550, 551, 552, 553, 554, 555, 382 |  | 47d |  |
| 601 | 1.6.4.5.2 | **FM 2** | 40d | 2004-03-15 | 2004-05-07 |  |  | 53d |  |
| 602 |  | Integrate LET FM 2 Housing With Detectors | 40d | 2004-03-15 | 2004-05-07 | 550, 551, 552, 553, 554, 555, 382 |  | 53d |  |
| 603 | 1.6.5 | **SEPT - Kiel/ESTEC** | 260d | 2003-08-08 A | 2004-08-18 |  | 35% | 68d |  |
| 604 | 1.6.5.1 | **Deliveries** | 122d | 2004-03-01 | 2004-08-18 |  |  | 49d |  |
| 605 |  | Deliver SEPT-NS FM 1 to CIT for SEP I&T and Suite EMC | 5d | 2004-03-12 | 2004-03-18 | 649, 650 |  | 81d |  |
| 606 |  | Deliver SEPT-E FM 1 to CIT for SEP I&T and Suite EMC | 5d | 2004-03-01 | 2004-03-05 | 656, 657 |  | 90d |  |
| 607 |  | Final Delivery of SEPT FM 1 to APL | 2d | 2004-08-17 | 2004-08-18 | 651, 658 |  | 35d |  |
| 608 |  | Deliver SEPT-NS FM 2 to CIT for SEP I&T and Suite EMC | 5d | 2004-03-08 | 2004-03-12 | 664, 665 |  | 91d |  |
| 609 |  | Deliver SEPT-E FM 2 to CIT for SEP I&T and Suite EMC | 5d | 2004-03-08 | 2004-03-12 | 671, 672 |  | 91d |  |
| 610 |  | Final Delivery of SEPT FM 2 to APL | 2d | 2004-08-17 | 2004-08-18 | 666, 673 |  | 49d |  |
| 611 | 1.6.5.2 | **Mechanical Assembly** | 46d | 2003-12-22 A | 2004-02-27 |  | 66% | 190d |  |
| 612 | 1.6.5.2.1 | **FM 1** | 13d | 2003-12-22 A | 2004-01-09 A |  | 100% |  |  |
| 613 |  | Assemble SEPT-NS FM 1 Sensor and E-Box Housing | 13d | 2003-12-22 A | 2004-01-09 A |  | 100% |  | start no earlier than 2003-12-22 |
| 614 |  | Assemble SEPT-E FM 1 Sensor and E-Box Housing | 13d | 2003-12-22 A | 2004-01-09 A |  | 100% |  | start no earlier than 2003-12-22 |
| 615 | 1.6.5.2.2 | **FM 2** | 14d | 2003-12-29 A | 2004-01-16 A |  | 100% |  |  |
| 616 |  | Assemble SEPT-NS FM 2 Sensor and E-Box Housing | 14d | 2003-12-29 A | 2004-01-16 A | 613SS+4d | 100% |  |  |
| 617 |  | Assemble SEPT-E FM 2 Sensor and E-Box Housing | 14d | 2003-12-29 A | 2004-01-16 A | 614SS+4d | 100% |  |  |
| 618 | 1.6.5.2.3 | **Spare** | 28d | 2004-01-20 | 2004-02-27 |  |  | 190d |  |
| 619 |  | Assemble SEPT Spare Sensor and E-Box Housing | 28d | 2004-01-20 | 2004-02-27 | 616, 617 |  | 190d |  |
| 620 | 1.6.5.3 | **Electronics** | 144d | 2003-08-08 A | 2004-03-08 |  | 43% | 184d |  |
| 621 | 1.6.5.3.1 | **Assembly** | 124d | 2003-08-08 A | 2004-02-06 |  | 44% | 184d |  |
| 622 | 1.6.5.3.1.1 | **FM 2** | 106d | 2003-08-08 A | 2004-01-12 A |  | 100% |  |  |
| 623 |  | Assemble SEPT-NS FM 2 Electronics | 106d | 2003-08-08 A | 2004-01-12 A |  | 100% |  | start no earlier than 2003-08-08 |
| 624 |  | Assemble SEPT-E FM 2 Electronics | 92d | 2003-08-08 A | 2003-12-19 A |  | 100% |  | start no earlier than 2003-08-08 |
| 625 | 1.6.5.3.1.2 | **Spare** | 124d | 2003-08-08 | 2004-02-06 |  |  | 184d |  |
| 626 |  | Assemble SEPT-NS FS Electronics | 124d | 2003-08-08 | 2004-02-06 | 623SS |  | 184d |  |
| 627 |  | Assemble SEPT-E FS Electronics | 124d | 2003-08-08 | 2004-02-06 | 624SS |  | 184d |  |
| 628 | 1.6.5.3.2 | **Test** | 59d | 2003-12-11 A | 2004-03-08 |  | 35% | 184d |  |
| 629 | 1.6.5.3.2.1 | **FM 2** | 34d | 2003-12-11 A | 2004-01-30 |  | 74% | 209d |  |
| 630 |  | SEPT-NS FM 2 Electronics Test | 4d | 2004-01-13 A | 2004-01-16 A | 623 | 100% |  |  |

| ID | WBS | Task | Duration | Start | Finish | Predecessors | Complete | Total float | Constraint |
| --- | --- | --- | --- | --- | --- | --- | --- | --- | --- |
| 631 |  | SEPT-E FM 2 Electronics Test | 4d | 2003-12-11 A | 2003-12-16 A | 624FS-7d | 100% |  |  |
| 632 |  | Coat SEPT-NS FM 2 Electronics Board | 4d | 2004-01-20 | 2004-01-23 | 630 |  | 209d |  |
| 633 |  | Coat SEPT-E FM 2 Electronics Board | 5d | 2003-12-17 A | 2003-12-23 A | 631 | 100% |  |  |
| 634 |  | SEPT-NS FM 2 Mechanical Integration | 5d | 2004-01-26 | 2004-01-30 | 632 |  | 209d |  |
| 635 |  | SEPT-E FM 2 Mechanical Integration | 13d | 2003-12-24 A | 2004-01-13 A | 633 | 100% |  |  |
| 636 | 1.6.5.3.2.2 | **Spare** | 20d | 2004-02-09 | 2004-03-08 |  |  | 184d |  |
| 637 |  | SEPT-NS Flight Spare Electronics Test | 5d | 2004-02-09 | 2004-02-13 | 626 |  | 184d |  |
| 638 |  | SEPT-E Flight Spare Electronics Test | 5d | 2004-02-09 | 2004-02-13 | 627 |  | 184d |  |
| 639 |  | Coat SEPT-NS FS Electronics Board | 5d | 2004-02-17 | 2004-02-23 | 637 |  | 184d |  |
| 640 |  | Coat SEPT-E FS Electronics Board | 5d | 2004-02-17 | 2004-02-23 | 638 |  | 184d |  |
| 641 |  | SEPT-NS FS Mechanical Integration | 10d | 2004-02-24 | 2004-03-08 | 639 |  | 184d |  |
| 642 |  | SEPT-E FS Mechanical Integration | 10d | 2004-02-24 | 2004-03-08 | 640 |  | 184d |  |
| 643 | 1.6.5.4 | **Integration & Test** | 153d | 2004-01-12 A | 2004-08-16 |  | 3% | 49d |  |
| 644 | 1.6.5.4.1 | **FM 1** | 153d | 2004-01-12 A | 2004-08-16 |  | 6% | 35d |  |
| 645 | 1.6.5.4.1.1 | **SEPT-NS** | 144d | 2004-01-26 | 2004-08-16 |  |  | 35d |  |
| 646 |  | SEPT-NS FM 1 Integration & Test | 5d | 2004-01-26 | 2004-01-30 | 613 |  | 81d | start no earlier than 2004-01-26 |
| 647 |  | Muon and Radioactive Source Test | 5d | 2004-02-02 | 2004-02-06 | 646 |  | 81d |  |
| 648 |  | SEPT-NS FM 1 Vibration and Acoustics | 10d | 2004-02-09 | 2004-02-23 | 647 |  | 81d |  |
| 649 |  | SEPT-NS FM 1 Thermal Vac | 10d | 2004-02-24 | 2004-03-08 | 648 |  | 81d |  |
| 650 |  | SEPT-NS FM 1 Bake Out | 3d | 2004-03-09 | 2004-03-11 | 649 |  | 81d |  |
| 651 |  | SEPT-NS FM 1 Thermal Balance | 10d | 2004-08-03 | 2004-08-16 | 16 |  | 35d |  |
| 652 | 1.6.5.4.1.2 | **SEPT-E** | 153d | 2004-01-12 A | 2004-08-16 |  | 12% | 35d |  |
| 653 |  | SEPT-E FM 1 Integration & Test | 5d | 2004-01-12 A | 2004-01-16 A | 614 | 100% |  |  |
| 654 |  | Muon and Radioactive Source Test | 5d | 2004-01-20 | 2004-01-26 | 653 |  | 90d |  |
| 655 |  | SEPT-E FM 1 Vibration and Acoustics | 10d | 2004-01-27 | 2004-02-09 | 654 |  | 90d |  |
| 656 |  | SEPT-E FM 1 Thermal Vac | 10d | 2004-02-10 | 2004-02-24 | 655 |  | 90d |  |
| 657 |  | SEPT-E FM 1 Bake Out | 3d | 2004-02-25 | 2004-02-27 | 656 |  | 90d |  |
| 658 |  | SEPT-E FM 1 Thermal Balance | 10d | 2004-08-03 | 2004-08-16 | 16 |  | 35d |  |
| 659 | 1.6.5.4.2 | **FM 2** | 148d | 2004-01-20 | 2004-08-16 |  |  | 49d |  |
| 660 | 1.6.5.4.2.1 | **SEPT-NS** | 148d | 2004-01-20 | 2004-08-16 |  |  | 49d |  |
| 661 |  | SEPT-NS FM 2 Integration & Test | 5d | 2004-01-20 | 2004-01-26 | 616 |  | 91d |  |
| 662 |  | Muon and Radioactive Source Test | 5d | 2004-01-27 | 2004-02-02 | 661 |  | 91d |  |
| 663 |  | SEPT-NS FM 2 Vibration and Acoustics | 10d | 2004-02-03 | 2004-02-17 | 662 |  | 91d |  |
| 664 |  | SEPT-NS FM 2 Thermal Vac | 10d | 2004-02-18 | 2004-03-02 | 663 |  | 91d |  |
| 665 |  | SEPT-NS FM 2 Bake Out | 3d | 2004-03-03 | 2004-03-05 | 664 |  | 91d |  |
| 666 |  | SEPT-NS FM 2 Thermal Balance | 10d | 2004-08-03 | 2004-08-16 | 16 |  | 49d |  |
| 667 | 1.6.5.4.2.2 | **SEPT-E** | 148d | 2004-01-20 | 2004-08-16 |  |  | 49d |  |
| 668 |  | SEPT-E FM 2 Integration & Test | 5d | 2004-01-20 | 2004-01-26 | 617 |  | 91d |  |
| 669 |  | Muon and Radioactive Source Test | 5d | 2004-01-27 | 2004-02-02 | 668 |  | 91d |  |
| 670 |  | SEPT-E FM 2 Vibration and Acoustics | 10d | 2004-02-03 | 2004-02-17 | 669 |  | 91d |  |
| 671 |  | SEPT-E FM 2 Thermal Vac | 10d | 2004-02-18 | 2004-03-02 | 670 |  | 91d |  |
| 672 |  | SEPT-E FM 2 Bake Out | 3d | 2004-03-03 | 2004-03-05 | 671 |  | 91d |  |
| 673 |  | SEPT-E FM 2 Thermal Balance | 10d | 2004-08-03 | 2004-08-16 | 16 |  | 49d |  |
| 674 | 1.6.6 | **SIT - UMD** | 348d | 2003-06-02 A | 2004-10-15 |  | 27% | 28d |  |
| 675 | 1.6.6.1 | **Deliveries** | 57d | 2004-07-13 | 2004-09-30 |  |  | 10d |  |
| 676 |  | Deliver SIT FM 1 to CIT for SEP I&T and Suite EMC | 2d | 2004-07-13 | 2004-07-14 | 774 |  | 10d |  |
| 677 |  | Deliver SIT FM 1 back to GSFC for Environmental Testing | 2d | 2004-08-03 | 2004-08-04 | 16 |  | 10d |  |
| 678 |  | Final Delivery of SIT FM 1 to APL | 1d | 2004-09-30 | 2004-09-30 | 806 |  | 5d |  |
| 679 |  | Deliver SIT FM 2 to CIT for SEP I&T | 2d | 2004-07-20 | 2004-07-21 | 779 |  | 9d |  |
| 680 |  | Deliver SIT FM 2 back to GSFC for Environmental Testing | 2d | 2004-08-10 | 2004-08-11 | 865 |  | 5d |  |
| 681 |  | Final Delivery of SIT FM 2 to APL | 1d | 2004-09-30 | 2004-09-30 | 806 |  | 19d |  |
| 682 | 1.6.6.2 | **Detectors** | 43d | 2004-01-05 | 2004-03-05 |  |  | 58d |  |
| 683 | 1.6.6.2.1 | **Detector Testing** | 43d | 2004-01-05 | 2004-03-05 |  |  | 58d |  |
| 684 | 1.6.6.2.1.1 | **FM 1** | 43d | 2004-01-05 | 2004-03-05 |  |  | 53d |  |
| 685 |  | Test FM 1 Solid States Detectors | 24d | 2004-01-05 | 2004-02-06 |  |  | 62d | start no earlier than 2004-01-05 |
| 686 |  | Test FM 1 Foils | 24d | 2004-01-05 | 2004-02-06 | 685SS |  | 62d |  |
| 687 |  | Alpha Tests FM 1 w/Proto Elect | 10d | 2004-02-23 | 2004-03-05 | 685, 686, 372 |  | 53d |  |
| 688 | 1.6.6.2.1.2 | **FM 2** | 43d | 2004-01-05 | 2004-03-05 |  |  | 58d |  |
| 689 |  | Test FM 2 Solid States Detectors | 24d | 2004-01-05 | 2004-02-06 | 685SS |  | 67d |  |
| 690 |  | Test FM 2 Foils | 24d | 2004-01-05 | 2004-02-06 | 686SS |  | 67d |  |
| 691 |  | Alpha Tests FM 2 w/Proto Elect | 10d | 2004-02-23 | 2004-03-05 | 689, 690, 372 |  | 58d |  |
| 692 | 1.6.6.3 | **ACTEL - for SIT Logic Board** | 11d | 2004-02-27 | 2004-03-12 |  |  | 81d |  |
| 693 |  | Burn Final SIT ACTEL Chip (at GSFC) | 1d | 2004-02-27 | 2004-02-27 |  |  | 81d | start no earlier than 2004-02-27 |
| 694 |  | Evaluate (Test) SIT Final ACTEL Chip | 10d | 2004-03-01 | 2004-03-12 | 693 |  | 81d |  |
| 695 | 1.6.6.4 | **TOF Boards** | 20d | 2004-01-30 | 2004-02-27 |  |  | 66d |  |
| 696 |  | Receive Analog and Digital TOF Boards (FM 1 & FM 2) | 0d | 2004-01-30 | 2004-01-30 |  |  | 66d | start no earlier than 2004-01-30 |
| 697 | 1.6.6.4.2 | **Test** | 20d | 2004-01-30 | 2004-02-27 |  |  | 66d |  |
| 698 | 1.6.6.4.2.1 | **FM 1** | 10d | 2004-01-30 | 2004-02-12 |  |  | 66d |  |
| 699 |  | FM 1 TOF Boards Functional Test | 10d | 2004-01-30 | 2004-02-12 | 696 |  | 66d |  |
| 700 | 1.6.6.4.2.2 | **FM 2** | 10d | 2004-02-13 | 2004-02-27 |  |  | 66d |  |

| ID | WBS | Task | Duration | Start | Finish | Predecessors | Complete | Total float | Constraint |
| --- | --- | --- | --- | --- | --- | --- | --- | --- | --- |
| 701 |  | FM 2 TOF Boards Functional Test | 10d | 2004-02-13 | 2004-02-27 | 696, 699 |  | 66d |  |
| 702 | 1.6.6.5 | **Energy Board** | 76d | 2003-11-10 A | 2004-03-02 |  | 57% | 64d |  |
| 703 | 1.6.6.5.1 | **Assembly** | 46d | 2003-11-10 A | 2004-01-16 |  | 76% | 79d |  |
| 704 | 1.6.6.5.1.1 | **FM 1** | 46d | 2003-11-10 A | 2004-01-16 |  | 76% | 64d |  |
| 705 |  | Assemble FM 1 Energy Board | 46d | 2003-11-10 A | 2004-01-16 |  | 76% | 64d | start no earlier than 2003-11-10 |
| 706 | 1.6.6.5.1.2 | **FM 2** | 46d | 2003-11-10 A | 2004-01-16 |  | 76% | 79d |  |
| 707 |  | Assemble FM 2 Energy Board | 46d | 2003-11-10 A | 2004-01-16 | 705SS | 76% | 79d |  |
| 708 | 1.6.6.5.2 | **Test** | 30d | 2004-01-20 | 2004-03-02 |  |  | 64d |  |
| 709 | 1.6.6.5.2.1 | **FM 1** | 15d | 2004-01-20 | 2004-02-09 |  |  | 64d |  |
| 710 |  | Bench Test/Calibration | 10d | 2004-01-20 | 2004-02-02 | 705 |  | 64d |  |
| 711 |  | Thermal | 3d | 2004-02-03 | 2004-02-05 | 710 |  | 64d |  |
| 712 |  | Voltage Margin | 2d | 2004-02-06 | 2004-02-09 | 711 |  | 64d |  |
| 713 | 1.6.6.5.2.2 | **FM 2** | 15d | 2004-02-10 | 2004-03-02 |  |  | 64d |  |
| 714 |  | FM 2 Energy Board Functional Test | 15d | 2004-02-10 | 2004-03-02 | 707, 712 |  | 64d |  |
| 715 | 1.6.6.6 | **Logic Board** | 165d | 2003-11-10 A | 2004-07-06 |  | 31% | 9d |  |
| 716 | 1.6.6.6.1 | **Design** | 3d | 2003-11-17 A | 2003-11-19 A |  | 100% |  |  |
| 717 |  | Layout new Logic Board Design | 3d | 2003-11-17 A | 2003-11-19 A |  | 100% |  | start no earlier than 2003-11-17 |
| 718 | 1.6.6.6.2 | **Fabrication** | 10d | 2004-02-02 | 2004-02-13 |  |  | 24d |  |
| 719 |  | FM 1 & FM 2 Logic Board Fabrication | 10d | 2004-02-02 | 2004-02-13 | 717, 733 |  | 24d | start no earlier than 2004-02-02 |
| 720 | 1.6.6.6.3 | **Assembly** | 88d | 2004-03-02 | 2004-07-02 |  |  | 9d |  |
| 721 | 1.6.6.6.3.1 | **FM 1** | 83d | 2004-03-02 | 2004-06-25 |  |  | 10d |  |
| 722 |  | Assemble FM 1 Logic Board with ETU ACTELs | 11d | 2004-03-02 | 2004-03-16 | 735 |  | 24d |  |
| 723 |  | Disassembel FM 1 Logic Board with ETU ACTELs | 1d | 2004-06-22 | 2004-06-22 | 788 |  | 10d |  |
| 724 |  | Retrofit/Inspect FM 1 Flight ACTELs | 2d | 2004-06-23 | 2004-06-24 | 723, 694 |  | 10d |  |
| 725 |  | Reassemble FM 1 Logic Board with Flight ACTELs | 1d | 2004-06-25 | 2004-06-25 | 724 |  | 10d |  |
| 726 | 1.6.6.6.3.2 | **FM 2** | 88d | 2004-03-02 | 2004-07-02 |  |  | 9d |  |
| 727 |  | Assemble FM 2 Logic Board with ETU ACTELS | 11d | 2004-03-02 | 2004-03-16 | 735 |  | 39d |  |
| 728 |  | Disassemble FM 2 Logic Boards | 1d | 2004-06-29 | 2004-06-29 | 797, 723SS |  | 9d |  |
| 729 |  | Retrofit/Inspect Flight ACTELS | 2d | 2004-06-30 | 2004-07-01 | 728, 694 |  | 9d |  |
| 730 |  | Reassemble FM 2 Logic Boards | 1d | 2004-07-02 | 2004-07-02 | 729 |  | 9d |  |
| 731 | 1.6.6.6.4 | **Test** | 165d | 2003-11-10 A | 2004-07-06 |  | 42% | 9d |  |
| 732 | 1.6.6.6.4.1 | **ETU** | 55d | 2003-11-10 A | 2004-01-30 |  | 75% | 24d |  |
| 733 |  | Test New ETU Logic Board | 55d | 2003-11-10 A | 2004-01-30 |  | 75% | 24d | start no earlier than 2003-11-10 |
| 734 | 1.6.6.6.4.2 | **FM1 & FM 2** | 10d | 2004-02-17 | 2004-03-01 |  |  | 24d |  |
| 735 |  | Coupon Testing | 10d | 2004-02-17 | 2004-03-01 | 719 |  | 24d |  |
| 736 | 1.6.6.6.4.3 | **FM 1** | 74d | 2004-03-17 | 2004-06-29 |  |  | 10d |  |
| 737 |  | Functional Test of FM 1 Logic Board w/ETU ACTELS | 15d | 2004-03-17 | 2004-04-06 | 722 |  | 24d |  |
| 738 |  | Funtional Test of FM 1 Logic Board w/Flight ACTELS | 2d | 2004-06-28 | 2004-06-29 | 725 |  | 10d |  |
| 739 | 1.6.6.6.4.4 | **FM 2** | 64d | 2004-04-07 | 2004-07-06 |  |  | 9d |  |
| 740 |  | Functional Test of FM 2 Logic Board w/ETU ACTELS | 15d | 2004-04-07 | 2004-04-27 | 727, 737 |  | 24d |  |
| 741 |  | Functional Test of FM 2 Logic Board w/Flight ACTELS | 2d | 2004-07-05 | 2004-07-06 | 730 |  | 9d |  |
| 742 | 1.6.6.7 | **Mother Board** | 50d | 2003-12-22 | 2004-03-04 |  |  | 49d |  |
| 743 | 1.6.6.7.1 | **Design** | 15d | 2003-12-22 | 2004-01-13 |  |  | 49d |  |
| 744 | 1.6.6.7.1.1 | **FM 1 & FM 2** | 15d | 2003-12-22 | 2004-01-13 |  |  | 49d |  |
| 745 |  | Finalize Mother Board Layout | 15d | 2003-12-22 | 2004-01-13 |  |  | 49d | start no earlier than 2003-12-22 |
| 746 | 1.6.6.7.2 | **Fabrication** | 15d | 2004-01-14 | 2004-02-04 |  |  | 49d |  |
| 747 | 1.6.6.7.2.1 | **FM 1 & FM 2** | 15d | 2004-01-14 | 2004-02-04 |  |  | 49d |  |
| 748 |  | Fabricate FM 1 & FM 2 Mother Boards | 15d | 2004-01-14 | 2004-02-04 | 745 |  | 49d |  |
| 749 | 1.6.6.7.3 | **Assembly** | 10d | 2004-02-05 | 2004-02-19 |  |  | 49d |  |
| 750 |  | Assemble FM 1 Mother Board | 10d | 2004-02-05 | 2004-02-19 | 748 |  | 49d |  |
| 751 |  | Assemble FM 2 Mother Board | 10d | 2004-02-05 | 2004-02-19 | 750SS |  | 54d |  |
| 752 | 1.6.6.7.4 | **Test** | 20d | 2004-02-05 | 2004-03-04 |  |  | 59d |  |
| 753 | 1.6.6.7.4.1 | **FM 1 & FM 2** | 15d | 2004-02-05 | 2004-02-26 |  |  | 191d |  |
| 754 |  | Coupon Testing of Mother Boards | 15d | 2004-02-05 | 2004-02-26 | 748 |  | 191d |  |
| 755 | 1.6.6.7.4.2 | **FM 1** | 5d | 2004-02-20 | 2004-02-26 |  |  | 49d |  |
| 756 |  | Functional Test FM 1 Mother Board | 5d | 2004-02-20 | 2004-02-26 | 750 |  | 49d |  |
| 757 | 1.6.6.7.4.3 | **FM 2** | 5d | 2004-02-27 | 2004-03-04 |  |  | 49d |  |
| 758 |  | Functional Test FM 2 Mother Board | 5d | 2004-02-27 | 2004-03-04 | 751, 756 |  | 49d |  |
| 759 | 1.6.6.8 | **HVPS** | 62d | 2004-01-12 | 2004-04-08 |  |  | 34d |  |
| 760 | 1.6.6.8.1 | **Test** | 62d | 2004-01-12 | 2004-04-08 |  |  | 34d |  |
| 761 | 1.6.6.8.1.1 | **FM 1** | 10d | 2004-01-12 | 2004-01-26 |  |  | 81d |  |
| 762 |  | Functional Test SIT FM 1 HVPS | 10d | 2004-01-12 | 2004-01-26 | 72 |  | 81d | start no earlier than 2004-01-12 |
| 763 | 1.6.6.8.1.2 | **FM 2** | 10d | 2004-03-26 | 2004-04-08 |  |  | 34d |  |
| 764 |  | Functional Test SIT FM 2 HVPS | 10d | 2004-03-26 | 2004-04-08 | 78, 758 |  | 34d |  |
| 765 | 1.6.6.9 | **Flight Software** | 210d | 2003-06-02 A | 2004-04-01 |  | 70% | 65d |  |
| 766 | 1.6.6.9.1 | **Test** | 210d | 2003-06-02 A | 2004-04-01 |  | 70% | 65d |  |
| 767 | 1.6.6.9.1.1 | **FM 1 & FM 2** | 210d | 2003-06-02 A | 2004-04-01 |  | 70% | 65d |  |
| 768 |  | Validate SIT On-Board Code | 210d | 2003-06-02 A | 2004-04-01 |  | 70% | 65d | start no earlier than 2003-06-02 |
| 769 | 1.6.6.10 | **Integration & Test** | 95d | 2004-03-08 | 2004-07-19 |  |  | 9d |  |
| 770 | 1.6.6.10.1 | **FM 1** | 9d | 2004-06-30 | 2004-07-12 |  |  | 10d |  |

| ID | WBS | Task | Duration | Start | Finish | Predecessors | Complete | Total float | Constraint |
| --- | --- | --- | --- | --- | --- | --- | --- | --- | --- |
| 771 |  | Disassemble SIT FM 1 | 1d | 2004-06-30 | 2004-06-30 | 738 |  | 10d |  |
| 772 |  | Conformal Coat SIT FM 1 Boards | 2d | 2004-07-01 | 2004-07-02 | 771 |  | 10d |  |
| 773 |  | Reassemble SIT FM 1 | 1d | 2004-07-05 | 2004-07-05 | 772 |  | 10d |  |
| 774 |  | Post-Coat Retest SIT FM 1 | 5d | 2004-07-06 | 2004-07-12 | 773 |  | 10d |  |
| 775 | 1.6.6.10.2 | **FM 2** | 9d | 2004-07-07 | 2004-07-19 |  |  | 9d |  |
| 776 |  | Disassemble SIT FM 2 | 1d | 2004-07-07 | 2004-07-07 | 741 |  | 9d |  |
| 777 |  | Conformal Coat SIT FM 2 Boards | 2d | 2004-07-08 | 2004-07-09 | 776 |  | 9d |  |
| 778 |  | Reassemble SIT FM 2 | 1d | 2004-07-12 | 2004-07-12 | 777 |  | 9d |  |
| 779 |  | Post-Coat Retest SIT FM 2 | 5d | 2004-07-13 | 2004-07-19 | 778 |  | 9d |  |
| 780 | 1.6.6.10.3 | **FM 1** | 75d | 2004-03-08 | 2004-06-21 |  |  | 10d |  |
| 781 |  | Integrate SIT FM 1 HVPS and SIT FM 1 Telescope Without Electronics | 3d | 2004-03-08 | 2004-03-10 | 762, 687 |  | 53d |  |
| 782 |  | Integrate SIT FM 1Telescope | 2d | 2004-05-12 | 2004-05-13 | 737, 699, 756, 712, 781, 401 |  | 9d |  |
| 783 |  | SIT FM 1 Debug | 5d | 2004-05-14 | 2004-05-20 | 782 |  | 9d |  |
| 784 |  | SIT FM 1 Bench Test | 5d | 2004-05-21 | 2004-05-27 | 783 |  | 9d |  |
| 785 |  | SIT FM 1 Alpha TEST | 5d | 2004-05-28 | 2004-06-04 | 784 |  | 9d |  |
| 786 |  | SIT FM 1 Noise Removal | 5d | 2004-06-07 | 2004-06-11 | 785 |  | 9d |  |
| 787 |  | SIT FM 1 Thermal Test | 5d | 2004-06-14 | 2004-06-18 | 786 |  | 10d |  |
| 788 |  | SIT FM 1 Functional Test | 1d | 2004-06-21 | 2004-06-21 | 787, 768 |  | 10d |  |
| 789 | 1.6.6.10.4 | **FM 2** | 56d | 2004-04-09 | 2004-06-28 |  |  | 9d |  |
| 790 |  | Integrate SIT FM 2 HVPS and SIT FM 2 Telescope Without Electronics | 3d | 2004-04-09 | 2004-04-13 | 764, 691 |  | 34d |  |
| 791 |  | Integrate SIT FM 2 Telescope | 2d | 2004-05-12 | 2004-05-13 | 740, 701, 758, 714, 790, 401 |  | 14d |  |
| 792 |  | SIT FM 2 Debug | 5d | 2004-05-14 | 2004-05-20 | 791 |  | 14d |  |
| 793 |  | SIT FM 2 Bench Test | 5d | 2004-05-21 | 2004-05-27 | 792 |  | 14d |  |
| 794 |  | SIT FM 2 Alpha Test | 5d | 2004-05-28 | 2004-06-04 | 793 |  | 14d |  |
| 795 |  | SIT FM 2 Noise Removal | 5d | 2004-06-14 | 2004-06-18 | 794, 786 |  | 9d |  |
| 796 |  | SIT FM 2 Thermal Test | 5d | 2004-06-21 | 2004-06-25 | 795 |  | 9d |  |
| 797 |  | SIT FM 2 Functional Test | 1d | 2004-06-28 | 2004-06-28 | 796 |  | 9d |  |
| 798 | 1.6.6.11 | **Environmental Testing at GSFC (FM 1 & FM 2)** | 34d | 2004-08-12 | 2004-09-29 |  |  | 5d |  |
| 799 |  | SIT FM 1 & FM 2 Vibration and Acoustics | 10d | 2004-08-12 | 2004-08-25 | 677, 680 |  | 5d |  |
| 800 |  | Functional Test | 1d | 2004-08-26 | 2004-08-26 | 799 |  | 5d |  |
| 801 |  | SIT FM 1 & FM 2 Thermal Balance | 5d | 2004-08-27 | 2004-09-02 | 800 |  | 5d |  |
| 802 |  | SIT FM 1 & FM 2 Thermal Vac | 10d | 2004-09-03 | 2004-09-17 | 801 |  | 5d |  |
| 803 |  | Disassemble SIT Instruments | 2d | 2004-09-20 | 2004-09-21 | 802 |  | 5d |  |
| 804 |  | Bake Out | 3d | 2004-09-22 | 2004-09-24 | 803 |  | 5d |  |
| 805 |  | Reassemble Instruments | 2d | 2004-09-27 | 2004-09-28 | 804 |  | 5d |  |
| 806 |  | Functional Test | 1d | 2004-09-29 | 2004-09-29 | 805 |  | 5d |  |
| 807 | 1.6.6.12 | **Emulators/Simulators/GSE** | 211d | 2003-12-17 A | 2004-10-15 |  | 9% | 28d |  |
| 808 | 1.6.6.12.1 | **Simulators** | 80d | 2003-12-17 A | 2004-04-12 |  | 13% | 159d |  |
| 809 |  | Labview CPU Ready | 80d | 2003-12-17 A | 2004-04-12 |  | 13% | 159d | start no earlier than 2003-12-17 |
| 810 |  | Test Simulator | 80d | 2003-12-17 A | 2004-04-12 | 809SS | 13% | 159d |  |
| 811 | 1.6.6.12.2 | **GSE** | 60d | 2004-07-22 | 2004-10-15 |  |  | 28d |  |
| 812 |  | Pulse Generator | 60d | 2004-07-22 | 2004-10-15 | 676, 679 |  | 28d |  |
| 813 | 1.6.7 | **SEP Suite I&T - CIT** | 333d | 2003-08-01 A | 2004-11-26 |  | 28% | 0d |  |
| 814 | 1.6.7.1 | **ETU** | 5d | 2004-02-23 | 2004-02-27 |  |  | 190d |  |
| 815 |  | Complete Integration/Test of SEP Central EM with Sensors | 5d | 2004-02-23 | 2004-02-27 |  |  | 190d | start no earlier than 2004-02-23 |
| 816 | 1.6.7.2 | **FM 1 & FM 2** | 143d | 2004-03-08 | 2004-09-24 |  |  | 42d |  |
| 817 |  | Software Support For SEP Integration | 115d | 2004-04-15 | 2004-09-24 | 828SS |  | 42d |  |
| 818 |  | Generate SEPT integration & test procedure | 5d | 2004-03-08 | 2004-03-12 | 829FS-10d |  | 86d |  |
| 819 |  | Generate LET integration & test procedure | 5d | 2004-04-05 | 2004-04-09 | 830FS-10d |  | 67d |  |
| 820 |  | Generate HET integration & test procedure | 5d | 2004-06-07 | 2004-06-11 | 832FS-10d |  | 24d |  |
| 821 |  | Generate SIT integration & test procedure | 5d | 2004-07-02 | 2004-07-08 | 837FS-10d |  | 15d |  |
| 822 |  | Generate SEP system test procedure | 5d | 2004-07-05 | 2004-07-09 | 838FS-10d |  | 15d |  |
| 823 |  | Software Support For Acceptance Testing of SEP Instruments | 27d | 2004-07-19 | 2004-08-24 | 839SS |  | 64d |  |
| 824 |  | Generate SEP-IDPU integration procedure | 5d | 2004-06-08 | 2004-06-14 | 833FS-10d |  | 20d |  |
| 825 |  | Generate SEP-IDPU test procedure | 5d | 2004-06-15 | 2004-06-21 | 824 |  | 20d |  |
| 826 |  | Software Support of SEP Accelerator Tests | 20d | 2004-07-01 | 2004-07-28 | 873SS-10d |  | 83d |  |
| 827 | 1.6.7.3 | **FM 1** | 86d | 2004-03-19 | 2004-07-19 |  |  | 10d |  |
| 828 |  | Integrate/test SEP Central FM 1 | 1d | 2004-04-15 | 2004-04-15 | 409, 411, 413, 69, 391, 415 |  | 42d |  |
| 829 |  | Receive & inspect SEPT FM 1 | 1d | 2004-03-19 | 2004-03-19 | 605, 606 |  | 81d |  |
| 830 |  | Integrate & test SEPT FM 1 | 1d | 2004-04-16 | 2004-04-16 | 818, 828, 829 |  | 62d |  |
| 831 |  | Integrate & test LET FM 1 | 1d | 2004-05-10 | 2004-05-10 | 819, 830, 545, 547 |  | 47d |  |
| 832 |  | Receive & inspect HET FM 1 | 1d | 2004-06-18 | 2004-06-18 | 498 |  | 19d |  |
| 833 |  | Integrate & test HET FM 1 | 1d | 2004-06-21 | 2004-06-21 | 820, 831, 832 |  | 19d |  |
| 834 |  | Integrate SEP FM 1 - IDPU FM 1 | 1d | 2004-06-22 | 2004-06-22 | 824, 833, 162 |  | 19d |  |
| 835 |  | Test SEP FM 1 - IDPU FM 1 | 1d | 2004-06-23 | 2004-06-23 | 825, 834 |  | 19d |  |
| 836 |  | Rework SEP FM 1 - IDPU FM 1 issues and retest | 5d | 2004-06-24 | 2004-06-30 | 835 |  | 19d |  |
| 837 |  | Receive & inspect SIT FM 1 | 1d | 2004-07-15 | 2004-07-15 | 676 |  | 10d |  |
| 838 |  | Integrate & test SIT FM 1 | 1d | 2004-07-16 | 2004-07-16 | 821, 833, 837, 836 |  | 10d |  |
| 839 |  | SEP system test FM 1 | 1d | 2004-07-19 | 2004-07-19 | 822, 838 |  | 10d |  |
| 840 | 1.6.7.4 | **FM 2** | 100d | 2004-03-15 | 2004-08-02 |  |  | 5d |  |

| ID | WBS | Task | Duration | Start | Finish | Predecessors | Complete | Total float | Constraint |
| --- | --- | --- | --- | --- | --- | --- | --- | --- | --- |
| 841 |  | Integrate/testSEP Central FM 2 | 1d | 2004-04-15 | 2004-04-15 | 410, 412, 414, 391, 415 |  | 68d |  |
| 842 |  | Receive & inspect SEPT FM 2 | 1d | 2004-03-15 | 2004-03-15 | 608, 609 |  | 91d |  |
| 843 |  | Integrate & test SEPT FM 2 | 1d | 2004-04-16 | 2004-04-16 | 818, 841, 842 |  | 68d |  |
| 844 |  | Integrate & test LET FM 2 | 1d | 2004-05-10 | 2004-05-10 | 819, 843, 546, 547 |  | 53d |  |
| 845 |  | Receive & inspect HET FM 2 | 1d | 2004-07-16 | 2004-07-16 | 499 |  | 5d |  |
| 846 |  | Integrate & test HET FM 2 | 1d | 2004-07-19 | 2004-07-19 | 820, 844, 845 |  | 5d |  |
| 847 |  | Integrate SEP FM 2 - IDPU FM 2 | 1d | 2004-07-20 | 2004-07-20 | 824, 846, 163 |  | 5d |  |
| 848 |  | Test SEP FM 2 - IDPU FM 2 | 1d | 2004-07-21 | 2004-07-21 | 825, 847 |  | 5d |  |
| 849 |  | Rework SEP FM 2 - IDPU FM 2 issues and retest | 5d | 2004-07-22 | 2004-07-28 | 848 |  | 5d |  |
| 850 |  | Receive & inspect SIT FM 2 | 1d | 2004-07-22 | 2004-07-22 | 679 |  | 9d |  |
| 851 |  | Integrate & test SIT FM 2 | 1d | 2004-07-29 | 2004-07-29 | 821, 849, 850 |  | 5d |  |
| 852 |  | Integrate FM 2 LVPS into SEP Central (if necessary) | 1d | 2004-07-30 | 2004-07-30 | 841, 75, 851 |  | 5d |  |
| 853 |  | SEP FM 2 system test | 1d | 2004-08-02 | 2004-08-02 | 822, 851, 852 |  | 5d |  |
| 854 | 1.6.7.5 | **Environmental Test (at JPL)** | 119d | 2004-05-03 | 2004-10-19 |  |  | 26d |  |
| 855 |  | Generate Environmental Test Procedures | 15d | 2004-05-03 | 2004-05-21 |  |  | 54d | start no earlier than 2004-05-03 |
| 856 |  | Manufacture test cables (JPL) | 10d | 2004-05-24 | 2004-06-07 | 855 |  | 54d |  |
| 857 | 1.6.7.5.3 | **FM 1** | 41d | 2004-08-06 | 2004-10-04 |  |  | 11d |  |
| 858 |  | FM 1 LET/HET/SEP Central Vibration/Acoustics Test | 10d | 2004-08-06 | 2004-08-19 | 16FS+3d, 855, 856 |  | 11d |  |
| 859 |  | FM 1 LET/HET/SEP Central Thermal Balance Test | 5d | 2004-08-20 | 2004-08-26 | 858 |  | 11d |  |
| 860 |  | FM 1 LET/HET/SEP Central T/V Test | 15d | 2004-08-27 | 2004-09-17 | 859 |  | 11d |  |
| 861 |  | Evaluate SEP performance | 10d | 2004-09-20 | 2004-10-01 | 860 |  | 36d |  |
| 862 |  | Generate test reports | 11d | 2004-09-20 | 2004-10-04 | 861SS |  | 36d |  |
| 863 |  | Bakeout Clean SEP exterior & prepare for delivery | 3d | 2004-09-20 | 2004-09-22 | 860 |  | 11d |  |
| 864 | 1.6.7.5.4 | **FM 2** | 54d | 2004-08-03 | 2004-10-19 |  |  | 5d |  |
| 865 |  | FM 2 EMI/EMC Test at CalTech | 5d | 2004-08-03 | 2004-08-09 | 853 |  | 5d |  |
| 866 |  | FM 2 LET/HET/SEP Central Vibration/Acoustics Test | 10d | 2004-08-20 | 2004-09-02 | 865, 858 |  | 15d |  |
| 867 |  | FM 2 LET/HET/SEP Central Thermal Balance Test | 5d | 2004-09-03 | 2004-09-10 | 866 |  | 15d |  |
| 868 |  | FM 2 LET/HET/SEP Central T/V Test | 15d | 2004-09-13 | 2004-10-01 | 867 |  | 15d |  |
| 869 |  | Evaluate SEP performance | 10d | 2004-10-04 | 2004-10-18 | 868 |  | 26d |  |
| 870 |  | Generate test reports | 11d | 2004-10-04 | 2004-10-19 | 869SS |  | 26d |  |
| 871 |  | Bakeout Clean SEP exterior & prepare for delivery | 3d | 2004-10-04 | 2004-10-06 | 868 |  | 15d |  |
| 872 | 1.6.7.6 | **Accelerator Test (at MSU)** | 10d | 2004-07-15 | 2004-07-28 |  |  | 83d |  |
| 873 |  | LET/SEP Cen end-to-end test at Accelerator | 10d | 2004-07-15 | 2004-07-28 | 880 |  | 83d |  |
| 874 | 1.6.7.7 | **GSE** | 333d | 2003-08-01 A | 2004-11-26 |  | 48% | 0d |  |
| 875 | 1.6.7.7.1 | **Design hardware** | 71d | 2004-01-05 | 2004-04-14 |  |  | 157d |  |
| 876 |  | GSE H/W Calibration equipment | 71d | 2004-01-05 | 2004-04-14 |  |  | 157d | start no earlier than 2004-01-05 |
| 877 | 1.6.7.7.2 | **End-to-End Test Equipment** | 234d | 2003-08-11 A | 2004-07-14 |  | 86% | 83d |  |
| 878 |  | Design | 203d | 2003-08-11 A | 2004-06-01 |  | 90% | 83d | start no earlier than 2003-08-11 |
| 879 |  | Assemble | 5d | 2004-07-01 | 2004-07-07 | 878FS+21d |  | 83d |  |
| 880 |  | Test | 5d | 2004-07-08 | 2004-07-14 | 879 |  | 83d |  |
| 881 | 1.6.7.7.3 | **GSE software** | 333d | 2003-08-01 A | 2004-11-26 |  | 31% | 0d |  |
| 882 |  | Write user's guide | 4d | 2004-02-02 | 2004-02-05 |  |  | 0d | start no earlier than 2004-02-02 |
| 883 |  | Build GSE software release 2 | 114d | 2003-08-01 A | 2004-01-15 |  | 70% | 14d | start no earlier than 2003-08-01 |
| 884 |  | Write user's guide supplement | 10d | 2004-02-06 | 2004-02-20 | 882, 883 |  | 0d |  |
| 885 |  | Build GSE software release 3 | 130d | 2004-05-24 | 2004-11-26 | 884FS+65d |  | 0d |  |

## Version 2 (data date 2004-01-31, saved 2004-02-19, file IMPACT Master Schedule_Baseline January 31 2004.mpp)

Last finish 2004-11-26 → 2005-11-18 (+357d). Complete tasks 65 → 92.

Added:

| ID | Task | Duration | Start | Finish | Predecessors | Constraint |
| --- | --- | --- | --- | --- | --- | --- |
| 3 | FM 1 Target Delivery Date | 0d | 2004-10-07 | 2004-10-07 | 5, 7 | must start on 2004-10-07 |
| 4 | FM 1 Target Delivery Date | 0d | 2004-10-28 | 2004-10-28 | 8, 6 | must start on 2004-10-28 |
| 15 | TRR 4 - Prior to FM 1 IDPU Vibration | 1d | 2004-04-26 | 2004-04-26 | 23SS-5d |  |
| 18 | TRR 7 - Prior to FM 1 SIT Vibration | 1d | 2004-07-08 | 2004-07-08 | 43SS-5d |  |
| 25 | IDPU Thermal Vac & Bake Out | 10d | 2004-05-10 | 2004-05-21 | 177SS |  |
| 29 | STE-U Thermal Vac/Bake Out | 10d | 2004-04-27 | 2004-05-10 | 281SS |  |
| 41 | SEPT (NS & E) Thermal Balance (at GSFC) | 10d | 2004-07-13 | 2004-07-26 | 557SS, 564SS |  |
| 55 | LET/HET/SEP Cen Accelerator Test (at MSU) | 11d | 2004-07-13 | 2004-07-27 | 784SS |  |
| 373 | **SEP Electronics Enclosure (Priority 3)** | 31d | 2004-02-17 | 2004-03-30 |  |  |
| 382 | **LET Telescope (Priority 5)** | 26d | 2004-03-12 | 2004-04-16 |  |  |
| 392 | **HET Telescope (Priority 7)** | 68d | 2004-01-27 A | 2004-04-30 |  |  |
| 393 | On Going work for HET Telescope (Complete Design/Drawings & Prep for Fab) | 46d | 2004-01-27 A | 2004-03-31 |  | start no earlier than 2004-01-27 |
| 402 | **Shipping Containers for HET, SIT & SEP Central (Priority 9)** | 23d | 2004-04-27 | 2004-05-27 |  |  |
| 403 | Design | 5d | 2004-04-27 | 2004-05-03 | 398 |  |
| 404 | Fabrication/Machining | 10d | 2004-05-04 | 2004-05-17 | 403 |  |
| 405 | Inspection and Assembly | 5d | 2004-05-18 | 2004-05-24 | 404 |  |
| 406 | HET Container stays at GSFC | 0d | 2004-05-24 | 2004-05-24 | 405 |  |
| 407 | SIT Container to UMD | 1d | 2004-05-25 | 2004-05-25 | 405 |  |
| 408 | SEP Central Container to CIT | 3d | 2004-05-25 | 2004-05-27 | 405 |  |
| 409 | **LET Radiation Test Fixture (Priority 10)** | 21d | 2004-05-04 | 2004-06-02 |  |  |
| 410 | Design | 5d | 2004-05-04 | 2004-05-10 | 403 |  |
| 411 | Fabrication | 10d | 2004-05-11 | 2004-05-24 | 410 |  |
| 412 | Inspection and Assembly | 5d | 2004-05-25 | 2004-06-01 | 411 |  |
| 413 | Deliver to CIT for SEP I&T | 1d | 2004-06-02 | 2004-06-02 | 412 |  |
| 418 | SEP Central Build 3 Software Complete | 0d | 2004-04-14 | 2004-04-14 | 442 |  |
| 428 | FM 1 Analog/Post-Reg Board Complete Test and awaiting Conformal Coat with other SEP Central Boards | 0d | 2004-01-27 A | 2004-01-27 A |  | start no earlier than 2004-01-27 |
| 429 | FM 2 Analog/Post-Reg Board Complete Test and awaiting Conformal Coat with other SEP Central Boards | 0d | 2004-01-27 A | 2004-01-27 A |  | start no earlier than 2004-01-27 |
| 437 | **Conformal Coat, Mass Properties and Bake Out (SEP Central, LET, SEP LVPS)** | 17d | 2004-04-16 | 2004-05-10 |  |  |
| 438 | Stake/Conformal Coat All SEP Central and LET Boards | 10d | 2004-04-16 | 2004-04-29 | 425, 426, 428, 429, 435, 436, 505, 506 |  |
| 439 | Mass Properties/Photo All SEP Central and LET Boards | 4d | 2004-04-30 | 2004-05-05 | 438 |  |
| 440 | Bake Out All SEP Central/LET Boards and SEP LVPS (FM 1 & 2) | 3d | 2004-05-06 | 2004-05-10 | 439, 74, 68 |  |
| 561 | SEPT-E FM 1 Vibration | 4d | 2004-02-21 | 2004-02-24 | 554, 560 |  |
| 679 | Vacuum Test SIT FM 1 w/Flight Telescope | 5d | 2004-06-11 | 2004-06-17 | 678 |  |
| 703 | **Environmental Testing at GSFC (FM 1)** | 34d | 2004-07-15 | 2004-08-31 |  |  |
| 704 | SIT FM 1 Vibration and Acoustics | 10d | 2004-07-15 | 2004-07-28 | 581 |  |
| 705 | Functional Test | 1d | 2004-07-29 | 2004-07-29 | 704 |  |
| 706 | SIT FM 1 Thermal Balance | 5d | 2004-07-30 | 2004-08-05 | 705 |  |
| 707 | SIT FM 1 Thermal Vac | 10d | 2004-08-06 | 2004-08-19 | 706 |  |
| 708 | Disassemble SIT Instruments | 2d | 2004-08-20 | 2004-08-23 | 707 |  |
| 709 | Bake Out | 3d | 2004-08-24 | 2004-08-26 | 708 |  |
| 710 | Reassemble Instruments | 2d | 2004-08-27 | 2004-08-30 | 709 |  |
| 711 | Functional Test | 1d | 2004-08-31 | 2004-08-31 | 710 |  |
| 784 | FM 2 LET/SEP Cen end-to-end test at Accelerator | 5d | 2004-07-13 | 2004-07-19 | 783SS, 761 |  |
| 795 | **SWEA and SIT Refurbishment (after S/C Environmental Testing)** | 39d | 2005-09-27 | 2005-11-18 |  |  |
| 796 | Ship SWEA FM 1 to UCB | 3d | 2005-09-27 | 2005-09-29 |  | start no earlier than 2005-09-27 |
| 797 | Ship (Hand Carry) SIT FM 1 to UMD | 1d | 2005-09-27 | 2005-09-27 |  | start no earlier than 2005-09-27 |
| 798 | Ship SWEA FM 2 to UCB | 3d | 2005-10-04 | 2005-10-06 |  | start no earlier than 2005-10-04 |
| 799 | Ship (Hand Carry) SIT FM 2 to UMD | 1d | 2005-10-04 | 2005-10-04 |  | start no earlier than 2005-10-04 |
| 800 | Vacuum Testing of SWEA FM 1 @ UCB | 5d | 2005-09-30 | 2005-10-06 | 796 |  |
| 801 | Vacuum Testing of SIT FM 1 @ UMD | 5d | 2005-09-28 | 2005-10-04 | 797 |  |
| 802 | Vacuum Testing of SWEA FM 2 @ UCB | 5d | 2005-10-07 | 2005-10-13 | 798 |  |
| 803 | Vacuum Testing of SIT FM 2 @ UMD | 5d | 2005-10-05 | 2005-10-11 | 799 |  |
| 804 | Ship SWEA FM 1 & 2 to Launch Site for Re-integration to S/C | 3d | 2005-10-07 | 2005-10-11 | 800 |  |
| 805 | Ship SIT FM 1 & 2 to Launch Site for Re-integration to S/C | 3d | 2005-10-05 | 2005-10-07 | 801 |  |
| 806 | Reintegration of SWEA and SIT to S/C (at Launch Site) | 3d | 2005-10-12 | 2005-10-14 | 804, 805 |  |
| 807 | Target Date for Reintegration to S/C | 1d | 2005-11-18 | 2005-11-18 | 806 | must start on 2005-11-18 |

Removed: 11 TRR 2 - Prior to FM 1 IDPU Vibration; 19 IDPU Thermal Vac; 25 IDPU Bake Out; 26 Boom Suite Bake Out; 35 IDPU Bake Out; 36 Boom Suite Bake Out; 41 SEPT Thermal Balance (at GSFC); 56 SEPT Thermal Balance (at GSFC); 58 LET/HET/SEP Cen Thermal Balance (at JPL); 179 IDPU FM 1 Bakeout; 184 IDPU FM 2 Bakeout; 357 BOOM Suite FM 1 Bakeout; 364 BOOM Suite FM 2 Bakeout; 378 LET Telescope (Priority 3); 387 SEP Electronics Enclosure (Priority 5); 402 HET Telescope (Priority 8); 403 Complete Design/Drawings for HET Telescope; 411 Deliver SEP Cen FM 1 Analog/Post-Reg Board (stays at CIT for SEP Suite I&T); 412 Deliver SEP Cen FM 2 Analog/Post-Reg Board (stays at CIT for SEP Suite I&T); 413 Deliver SEP Cen FM 1 SSD Bias Supply Board (stays at CIT for SEP Suite I&T); 414 Deliver SEP Cen FM 2 SSD Bias Supply Board (stays at CIT for SEP Suite I&T); 418 FM 1; 420 Post-assembly QA inspection of FM 1 SEP Central Logic Board; 421 Rework/haywire/trim FM 1 SEP Central Logic board; 422 Post-rework QA inspection of FM 1 SEP Central Logic Board; 423 FM 2; 425 Post-assembly QA inspection of FM 2 SEP Central Logic Board; 426 Rework/haywire/trim FM 2 SEP Central Logic board; 427 Post-rework QA inspection of FM 2 SEP Central Logic Boards; 429 FM 1; 431 Stake/conformal coat FM 1 SEP Central Logic board; 432 Bakeout FM 1 SEP Central Logic board; 433 Post-conf. coat QA inspection of FM 1 SEP Central Logic Board; 434 Test FM 1 SEP Central Logic board (final); 435 FM 1 SEP Central Logic Board Mass properties/photo; 436 FM 2; 438 Stake/conformal coat FM 2 SEP Central Logic board; 439 Bakeout FM 2 SEP Central Logic board; 440 Post-conf. coat QA inspection of FM 2 SEP Central Logic Board; 441 Test FM 2 SEP Central Logic board (final); 442 FM 2 SEP Central Logic Board Mass properties/photo; 444 Assembly; 445 FM 1; 446 Assemble Analog/Post-reg Flight Printed Circuit Board 1; 447 Rework/haywire/trim Analog/Post-reg Flight Board 1; 448 Post rework QA inspection Flight Board 1; 449 FM 2; 450 Assemble Analog/Post-reg Flight Printed Circuit Board 2; 451 Rework/haywire/trim Analog/Post-reg Flight Board 2; 452 Post rework QA inspection Flight Board 2; 453 Test; 454 FM 1; 455 Test Analog/Post-reg Flight Board 1 (initial); 456 Stake/conformal coat Analog/Post-reg Flight Board 1; 457 Bakeout Analog/Post-reg Flight Board 1; 458 Post-conf coat QA inspection Flight Board 1; 459 Test Analog/Post-reg Flight Board 1 (final); 460 Analog/Post-reg Flight Board 1 Mass properties/photo; 461 FM 2; 462 Test Analog/Post-reg Flight Board 2 (initial); 463 Stake/conformal coat Analog/Post-reg Flight Board 2; 464 Bakeout Analog/Post-reg Flight Board 2; 465 Post-conf coat QA inspection Flight Board 2; 466 Test Analog/Post-reg Flight Board 2 (final); 467 Analog/Post-reg Flight Board 2 Mass properties/photo; 470 FM 1; 472 Rework/haywire/trim Solid State Detector Bias Supply flight board 1; 473 Post rework QA inspection of Solid State Detector Bias Supply board 1; 474 FM 2; 476 Rework/haywire/trim Solid State Detector Bias Supply flight board 2; 477 Post rework QA inspection of Solid State Detector Bias Supply board 2; 479 FM 1; 481 Stake/conformal coat Solid State Detector Bias Supply flight board 1; 482 Bakeout Solid State Detector Bias Supply flight board 1; 483 Post-conf coat QA inspection of Solid State Detector Bias Supply board 1; 484 Test Solid State Detector Bias Supply flight board 1 (final); 485 Solid State Detector Bias Supply FM 1 Mass properties/photo; 486 FM 2; 488 Stake/conformal coat Solid State Detector Bias Supply flight board 2; 489 Bakeout Solid State Detector Bias Supply flight board 2; 490 Post-conf coat QA inspection of Solid State Detector Bias Supply board 2; 491 Test Solid State Detector Bias Supply flight board 2 (final); 492 Solid State Detector Bias Supply FM 2 Mass properties/photo; 550 Perform Detector Noise & breakdown Testing; 551 Perform Detector Thermal Vac Testing; 552 Perform Detector Alphas Testing; 553 Analyze Detector Testing Data; 554 Capacitance, Current, Depletion, Alpha Resolution; 555 Life Test LET Flight Detectors; 557 Package and Test Flight Hybrids Lot 1 (7-10 Parts); 558 Package and Test Flight Hybrids Lot 2 (10 Parts); 559 Package and Test Flight Hybrids Lot 3 (20 Parts); 560 Select parts for flight; 563 Remaining Procurements; 564 Procure LET Detector Board Flight Parts; 565 Procure flight LET Detector Printed Circuit Board; 566 Fabrication; 567 Receive/inspect/database flight parts for LET Detector Board; 568 Inspect flight LET Detector Printed Circuit Boards (coupons & elec continuity); 569 Burn-in flight FPGA/EEPROM for LET Detector Board; 571 FM 1; 573 Post-assembly QA inspection for flight LET Detector Boards; 574 Rework/haywire/trim flight LET Detector Boards; 575 Post-rework QA inspection for LET Detector Boards; 576 FM 2; 578 Post-assembly QA inspection for flight LET Detector Boards; 579 Rework/haywire/trim flight LET Detector Boards; 580 Post-rework QA inspection for LET Detector Boards; 582 FM 1; 584 Stake/conformal coat LET FM 1 Detector Boards; 585 Bakeout LET FM 1 Detector Boards; 586 Post-conf. Coat QA inspection of LET FM 1 Detector Boards; 587 Test LET FM 1 Detector Boards (final); 588 LET FM 1 Detector Board Mass properties/photo; 589 FM 2; 591 Stake/conformal coat LET FM 2 Detector Boards; 592 Bakeout LET FM 2 Detector Boards; 593 Post-conf. Coat QA inspection of LET FM 2 Detector Boards; 594 Test LET FM 2 Detector Boards (final); 595 LET FM 2 Detector Board Mass properties/photo; 610 Final Delivery of SEPT FM 2 to APL; 627 Assemble SEPT-E FS Electronics; 638 SEPT-E Flight Spare Electronics Test; 640 Coat SEPT-E FS Electronics Board; 642 SEPT-E FS Mechanical Integration; 655 SEPT-E FM 1 Vibration and Acoustics; 666 SEPT-NS FM 2 Thermal Balance; 673 SEPT-E FM 2 Thermal Balance; 836 Rework SEP FM 1 - IDPU FM 1 issues and retest; 849 Rework SEP FM 2 - IDPU FM 2 issues and retest; 852 Integrate FM 2 LVPS into SEP Central (if necessary); 867 FM 2 LET/HET/SEP Central Thermal Balance Test; 875 Design hardware; 876 GSE H/W Calibration equipment

Changed:

| ID | Task | Start | Finish | Duration | Complete | Total float | Predecessors | Other |
| --- | --- | --- | --- | --- | --- | --- | --- | --- |
| 1 | **IMPACT - Dave Curtis (UCB) & Lil Reichenthal (GSFC)** |  | 2004-11-26 → 2005-11-18 (+357d) | 443d → 698d | 39% → 50% |  |  | baseline start none → 2003-02-26; baseline finish none → 2005-11-18 |
| 2 | **Suite Deliveries to APL** | 2004-08-31 → 2004-08-13 (-18d) | 2004-10-06 → 2004-10-28 (+22d) | 25d → 51d |  | 15d → 0d |  | baseline start none → 2004-08-13; baseline finish none → 2004-10-28 |
| 5 | Boom Suite FM 1 Ready for Delivery to APL | 2004-09-13 → 2004-08-13 (-31d) | 2004-09-13 → 2004-08-13 (-31d) |  |  | 18d → 37d |  | constraint finish no later than 2004-10-07 → none; baseline start none → 2004-08-13; baseline finish none → 2004-08-13 |
| 6 | Boom Suite FM 2 Ready for Delivery to APL | 2004-08-31 → 2004-09-28 (+28d) | 2004-08-31 → 2004-09-28 (+28d) |  |  | 40d → 20d |  | constraint finish no later than 2004-10-28 → none; baseline start none → 2004-09-28; baseline finish none → 2004-09-28 |
| 7 | SEP Suite FM 1 Ready for Delivery to APL | 2004-09-30 → 2004-09-14 (-16d) | 2004-09-30 → 2004-09-14 (-16d) |  |  | 5d → 16d |  | constraint finish no later than 2004-10-07 → none; baseline start none → 2004-09-14; baseline finish none → 2004-09-14 |
| 8 | SEP Suite FM 2 Ready for Delivery to APL | 2004-10-06 → 2004-10-12 (+6d) | 2004-10-06 → 2004-10-12 (+6d) |  |  | 15d → 11d | 781, 585, Final Delivery of SEPT FM 2 to APL → 781, 585 | constraint finish no later than 2004-10-28 → none; baseline start none → 2004-10-12; baseline finish none → 2004-10-12 |
| 9 | **Environmental Testing - PER, Impact Suite EMC, Snapshots of Boom & SEP Suite Test Flows** |  | 2004-10-06 → 2004-10-05 (-1d) | 187d → 186d | 0% → 1% | 34d → 290d |  | baseline start none → 2004-01-14; baseline finish none → 2004-10-05 |
| 10 | **Reviews (PER and TRR's) - TRR Dates are Tentative** |  | 2004-07-27 → 2004-07-08 (-19d) | 137d → 124d | 14% → 25% | 84d → 352d |  | baseline start none → 2004-01-14; baseline finish none → 2004-07-08 |
| 11 | Instrument PER at UCB |  |  |  |  |  |  | baseline start none → 2004-01-14; baseline finish none → 2004-01-14 |
| 12 | TRR 1 - Prior to FM 1 SEPT Thermal Vac | 2004-02-02 → 2004-02-13 A (+11d) | 2004-02-02 → 2004-02-13 A (+11d) |  | 0% → 100% | 208d → none | 38SS-5d → 39SS-6d | was named TRR 1 - Prior to FM 1 SEPT Vibration/Acoustics; baseline start none → 2004-02-13; baseline finish none → 2004-02-13 |
| 13 | TRR 2 - Prior to FM 1 STE-U Thermal Vac/Thermal Balance | 2004-03-10 → 2004-03-25 (+15d) | 2004-03-10 → 2004-03-25 (+15d) |  |  | 182d → 426d |  | was named TRR 3 - Prior to FM 1 STE-U Thermal Vac/Thermal Balance; baseline start none → 2004-03-25; baseline finish none → 2004-03-25 |
| 14 | TRR 3 - Prior to FM 1 Boom Structure Vibration | 2004-04-08 → 2004-04-20 (+12d) | 2004-04-08 → 2004-04-20 (+12d) |  |  | 161d → 408d |  | was named TRR 4 - Prior to FM 1 Boom Structure Vibration; baseline start none → 2004-04-20; baseline finish none → 2004-04-20 |
| 16 | TRR 5 - Prior to FM 1 SWEA Vibration | 2004-05-03 → 2004-05-28 (+25d) | 2004-05-03 → 2004-05-28 (+25d) |  |  | 144d → 380d |  | baseline start none → 2004-05-28; baseline finish none → 2004-05-28 |
| 17 | TRR 6 - Prior to FM 1 Impact Suite EMC (for Boom and SEP) | 2004-07-27 → 2004-06-22 (-35d) | 2004-07-27 → 2004-06-22 (-35d) |  |  | 84d → 364d | 57SS-5d → 19SS-5d | was named TRR 6 - Prior to FM 2 SEP Suite EMC; baseline start none → 2004-06-22; baseline finish none → 2004-06-22 |
| 19 | IMPACT Suite FM 1 EMC Testing at UCB | 2004-07-20 → 2004-06-29 (-21d) | 2004-08-02 → 2004-07-12 (-21d) |  |  | 10d → 9d | 752, 353 → 353, 752, 419 | baseline start none → 2004-06-29; baseline finish none → 2004-07-12 |
| 20 | **Boom Suite FM 1 Environmental Test Flow Snapshot - UCB** | 2004-03-15 → 2004-04-01 (+17d) | 2004-08-27 → 2004-07-30 (-28d) | 119d → 86d |  | 61d → 336d |  | baseline start none → 2004-04-01; baseline finish none → 2004-07-30 |
| 21 | STE-U Thermal Vac/Thermal Balance/Bake Out | 2004-03-17 → 2004-04-01 (+15d) | 2004-04-05 → 2004-04-20 (+15d) |  |  | 164d → 408d |  | was named STE-U Thermal Vac and Thermal Balance; baseline start none → 2004-04-01; baseline finish none → 2004-04-20 |
| 22 | Boom Structure Vibration | 2004-04-15 → 2004-04-27 (+12d) | 2004-04-20 → 2004-04-30 (+10d) |  |  | 153d → 400d |  | baseline start none → 2004-04-27; baseline finish none → 2004-04-30 |
| 23 | IDPU Vibration | 2004-03-15 → 2004-05-03 (+49d) | 2004-03-19 → 2004-05-07 (+49d) |  |  | 175d → 395d |  | baseline start none → 2004-05-03; baseline finish none → 2004-05-07 |
| 24 | Boom Structure Thermal Vac & Bake Out | 2004-04-21 → 2004-05-03 (+12d) | 2004-06-02 → 2004-05-21 (-12d) | 30d → 15d |  | 123d → 385d |  | was named Boom Structure Thermal Vac; baseline start none → 2004-05-03; baseline finish none → 2004-05-21 |
| 26 | SWEA/STE Vibration | 2004-05-10 → 2004-06-07 (+28d) | 2004-05-14 → 2004-06-11 (+28d) |  |  | 135d → 371d |  | baseline start none → 2004-06-07; baseline finish none → 2004-06-11 |
| 27 | SWEA/STE Thermal Vac/Thermal Balance/Bake Out | 2004-08-03 → 2004-07-13 (-21d) | 2004-08-20 → 2004-07-30 (-21d) |  |  | 66d → 336d |  | was named SWEA/STE Thermal Vac and Thermal Balance; baseline start none → 2004-07-13; baseline finish none → 2004-07-30 |
| 28 | **Boom Suite FM 2 Environmental Test Flow Snapshot - UCB** | 2004-04-16 → 2004-04-27 (+11d) | 2004-08-17 → 2004-09-14 (+28d) | 87d → 99d |  | 69d → 305d |  | baseline start none → 2004-04-27; baseline finish none → 2004-09-14 |
| 30 | IDPU Vibration |  |  |  |  | 135d → 390d |  | baseline start none → 2004-05-10; baseline finish none → 2004-05-14 |
| 31 | Boom Structure Vibration | 2004-04-16 → 2004-05-17 (+31d) | 2004-04-21 → 2004-05-20 (+29d) |  |  | 152d → 386d |  | baseline start none → 2004-05-17; baseline finish none → 2004-05-20 |
| 32 | IDPU Thermal Vac & Bake Out |  |  |  |  | 125d → 380d |  | was named IDPU Thermal Vac; baseline start none → 2004-05-17; baseline finish none → 2004-05-28 |
| 33 | Boom Structure Thermal Vac & Bake Out | 2004-05-12 → 2004-05-24 (+12d) | 2004-06-23 → 2004-06-14 (-9d) | 30d → 15d |  | 108d → 370d |  | was named Boom Structure Thermal Vac; baseline start none → 2004-05-24; baseline finish none → 2004-06-14 |
| 34 | SWEA/STE Vibration | 2004-06-23 → 2004-08-09 (+47d) | 2004-06-29 → 2004-08-13 (+45d) |  |  | 104d → 326d |  | baseline start none → 2004-08-09; baseline finish none → 2004-08-13 |
| 35 | SWEA/STE Thermal Vac & Bake Out | 2004-06-30 → 2004-08-16 (+47d) | 2004-07-13 → 2004-08-27 (+45d) |  |  | 94d → 316d |  | was named SWEA/STE Thermal Vac; baseline start none → 2004-08-16; baseline finish none → 2004-08-27 |
| 36 | Boom Suite FM 2 EMC | 2004-08-04 → 2004-09-08 (+35d) | 2004-08-10 → 2004-09-14 (+35d) |  |  | 74d → 305d |  | baseline start none → 2004-09-08; baseline finish none → 2004-09-14 |
| 37 | **SEP Suite FM 1 Environmental Test Flow Snapshot** | 2004-02-09 → 2004-02-17 (+8d) | 2004-09-24 → 2004-09-14 (-10d) | 162d → 149d |  | 42d → 305d |  | baseline start none → 2004-02-17; baseline finish none → 2004-09-14 |
| 38 | SEPT (NS & E) Vibration (in Europe) | 2004-02-09 → 2004-02-17 (+8d) | 2004-02-23 → 2004-02-24 (+1d) | 10d → 8d |  | 194d → 450d | 554SS, SEPT-E FM 1 Vibration and AcousticsSS → 554SS, 561FF | was named SEPT Vibe and Acoustics (in Europe); baseline start none → 2004-02-17; baseline finish none → 2004-02-24 |
| 39 | SEPT (NS & E) Thermal Vac (in Europe) | 2004-02-24 → 2004-02-25 (+1d) |  | 10d → 9d |  | 184d → 439d |  | was named SEPT Thermal Vac (in Europe); baseline start none → 2004-02-25; baseline finish none → 2004-03-08 |
| 40 | SEPT (NS & E) Bake Out (in Europe) |  | 2004-03-11 → 2004-03-10 (-1d) | 3d → 2d |  | 181d → 437d |  | was named SEPT Bake Out (in Europe); baseline start none → 2004-03-09; baseline finish none → 2004-03-10 |
| 42 | LET/HET/SEP Cen Accelerator Test (at MSU) | 2004-07-15 → 2004-07-13 (-2d) | 2004-07-28 → 2004-07-27 (-1d) | 10d → 11d |  | 83d → 339d |  | baseline start none → 2004-07-13; baseline finish none → 2004-07-27 |
| 43 | SIT Vibe and Acoustics (at GSFC) | 2004-08-12 → 2004-07-15 (-28d) | 2004-08-25 → 2004-07-28 (-28d) |  |  | 63d → 338d | 713SS → 704SS | baseline start none → 2004-07-15; baseline finish none → 2004-07-28 |
| 44 | LET/HET/SEP Cen Vibe and Acoustics (at JPL) | 2004-08-06 → 2004-07-23 (-14d) | 2004-08-19 → 2004-08-05 (-14d) |  |  | 67d → 332d |  | baseline start none → 2004-07-23; baseline finish none → 2004-08-05 |
| 45 | SIT Thermal Balance (at GSFC) | 2004-08-27 → 2004-07-30 (-28d) | 2004-09-02 → 2004-08-05 (-28d) |  |  | 57d → 332d | 715SS → 706SS | baseline start none → 2004-07-30; baseline finish none → 2004-08-05 |
| 46 | LET/HET/SEP Cen Thermal Balance (at JPL) | 2004-08-20 → 2004-08-06 (-14d) | 2004-08-26 → 2004-08-12 (-14d) |  |  | 62d → 327d |  | baseline start none → 2004-08-06; baseline finish none → 2004-08-12 |
| 47 | SIT Thermal Vac (at GSFC) | 2004-09-03 → 2004-08-06 (-28d) | 2004-09-17 → 2004-08-19 (-29d) |  |  | 47d → 322d | 716SS → 707SS | baseline start none → 2004-08-06; baseline finish none → 2004-08-19 |
| 48 | LET/HET/SEP Cen Thermal Vac (at JPL) | 2004-08-27 → 2004-08-19 (-8d) | 2004-09-17 → 2004-09-09 (-8d) |  |  | 47d → 308d |  | baseline start none → 2004-08-19; baseline finish none → 2004-09-09 |
| 49 | SIT Bake Out (at GSFC) | 2004-09-22 → 2004-08-24 (-29d) | 2004-09-24 → 2004-08-26 (-29d) |  |  | 42d → 317d | 718SS → 709SS | baseline start none → 2004-08-24; baseline finish none → 2004-08-26 |
| 50 | LET/HET/SEP Cen Bake Out (at JPL) | 2004-09-20 → 2004-09-10 (-10d) | 2004-09-22 → 2004-09-14 (-8d) |  |  | 44d → 305d |  | baseline start none → 2004-09-10; baseline finish none → 2004-09-14 |
| 51 | **SEP Suite FM 2 Environmental Test Flow Snapshot** | 2004-02-03 → 2004-02-17 (+14d) | 2004-10-06 → 2004-10-05 (-1d) | 174d → 164d |  | 34d → 290d |  | baseline start none → 2004-02-17; baseline finish none → 2004-10-05 |
| 52 | SEPT (NS & E) Vibe and Acoustics (in Europe) | 2004-02-03 → 2004-02-17 (+14d) | 2004-02-17 → 2004-02-24 (+7d) | 10d → 8d |  | 198d → 450d | 569SS, 575SS → 569SS, 575FF | was named SEPT Vibe and Acoustics (in Europe); baseline start none → 2004-02-17; baseline finish none → 2004-02-24 |
| 53 | SEPT (NS & E) Thermal Vac (in Europe) | 2004-02-18 → 2004-03-09 (+20d) | 2004-03-02 → 2004-03-17 (+15d) | 10d → 9d |  | 188d → 432d |  | was named SEPT Thermal Vac (in Europe); baseline start none → 2004-03-09; baseline finish none → 2004-03-17 |
| 54 | SEPT (NS & E) Bake Out (in Europe) | 2004-03-03 → 2004-03-18 (+15d) | 2004-03-05 → 2004-03-19 (+14d) | 3d → 2d |  | 185d → 430d |  | was named SEPT Bake Out (in Europe); baseline start none → 2004-03-18; baseline finish none → 2004-03-19 |
| 56 | LET/HET/SEP Cen Vibe and Acoustics (at JPL) | 2004-08-20 → 2004-07-23 (-28d) | 2004-09-02 → 2004-08-05 (-28d) |  |  | 57d → 332d |  | baseline start none → 2004-07-23; baseline finish none → 2004-08-05 |
| 57 | SEP Suite FM 2 EMC (at Caltech) | 2004-08-03 → 2004-08-12 (+9d) | 2004-08-09 → 2004-08-18 (+9d) |  |  | 75d → 323d |  | baseline start none → 2004-08-12; baseline finish none → 2004-08-18 |
| 58 | LET/HET/SEP Cen Thermal Vac (at JPL) | 2004-09-13 → 2004-08-19 (-25d) | 2004-10-01 → 2004-09-09 (-22d) |  |  | 37d → 308d |  | baseline start none → 2004-08-19; baseline finish none → 2004-09-09 |
| 59 | SIT Vibe and Acoustics (at GSFC) | 2004-08-12 → 2004-08-23 (+11d) | 2004-08-25 → 2004-09-03 (+9d) |  |  | 63d → 311d |  | baseline start none → 2004-08-23; baseline finish none → 2004-09-03 |
| 60 | SIT Thermal Balance (at GSFC) | 2004-08-27 → 2004-09-08 (+12d) | 2004-09-02 → 2004-09-14 (+12d) |  |  | 57d → 305d |  | baseline start none → 2004-09-08; baseline finish none → 2004-09-14 |
| 61 | LET/HET/SEP Cen Bake Out (at JPL) | 2004-10-04 → 2004-09-10 (-24d) | 2004-10-06 → 2004-09-14 (-22d) |  |  | 34d → 305d |  | baseline start none → 2004-09-10; baseline finish none → 2004-09-14 |
| 62 | SIT Thermal Vac (at GSFC) | 2004-09-03 → 2004-09-15 (+12d) | 2004-09-17 → 2004-09-28 (+11d) |  |  | 47d → 295d |  | baseline start none → 2004-09-15; baseline finish none → 2004-09-28 |
| 63 | SIT Bake Out (at GSFC) | 2004-09-22 → 2004-10-01 (+9d) | 2004-09-24 → 2004-10-05 (+11d) |  |  | 42d → 290d |  | baseline start none → 2004-10-01; baseline finish none → 2004-10-05 |
| 64 | **Power Converters - UCB** |  | 2004-07-21 → 2004-06-23 (-28d) | 355d → 335d | 44% → 57% | 88d → 363d |  | baseline start none → 2003-02-26; baseline finish none → 2004-06-23 |
| 65 | **Deliveries** |  |  |  |  | 145d → 49d |  | baseline start none → 2003-12-09; baseline finish none → 2004-04-30 |
| 66 | **FM 1** |  | 2004-03-19 → 2004-04-23 (+35d) | 70d → 95d |  | 175d → 25d |  | baseline start none → 2003-12-09; baseline finish none → 2004-04-23 |
| 67 | Deliver IDPU FM 1 LVPS (stays at UCB) | 2004-03-05 → 2004-04-23 (+49d) | 2004-03-05 → 2004-04-23 (+49d) |  |  | 74d → 25d |  | baseline start none → 2004-04-23; baseline finish none → 2004-04-23 |
| 68 | Deliver SEP FM 1 LVPS (to Caltech) | 2004-03-17 → 2004-04-06 (+20d) | 2004-03-17 → 2004-04-06 (+20d) |  |  | 62d → 36d |  | was named Deliver SEP FM 1 LVPS (to Cal Tech); baseline start none → 2004-04-06; baseline finish none → 2004-04-06 |
| 69 | Deliver SWEA/STE FM 1 LVPS (stays at UCB) | 2004-03-19 → 2004-04-15 (+27d) | 2004-03-19 → 2004-04-15 (+27d) |  |  | 49d → 9d |  | baseline start none → 2004-04-15; baseline finish none → 2004-04-15 |
| 70 | Deliver PLASTIC FM 1 LVPS (to UNH) | 2004-03-04 → 2004-03-24 (+20d) | 2004-03-05 → 2004-03-25 (+20d) |  |  | 185d → 28d |  | constraint none → finish no later than 2004-05-04; baseline start none → 2004-03-24; baseline finish none → 2004-03-25 |
| 71 | Deliver SIT FM 1 HVPS (to UMD) |  |  |  |  |  |  | baseline start none → 2003-12-09; baseline finish none → 2003-12-10 |
| 72 | **FM 2** | 2004-03-24 → 2004-04-12 (+19d) |  | 28d → 15d |  | 34d → 31d |  | baseline start none → 2004-04-12; baseline finish none → 2004-04-30 |
| 73 | Deliver IDPU FM 2 LVPS (stays at UCB) |  |  |  |  | 40d → 37d |  | baseline start none → 2004-04-30; baseline finish none → 2004-04-30 |
| 74 | Deliver SEP FM 2 LVPS (to Caltech) |  |  |  |  | 77d → 27d |  | was named Deliver SEP FM 2 LVPS (to Cal Tech); baseline start none → 2004-04-19; baseline finish none → 2004-04-19 |
| 75 | Deliver SWEA/STE FM 2 LVPS (stays at UCB) |  |  |  |  | 49d → 53d |  | baseline start none → 2004-04-26; baseline finish none → 2004-04-26 |
| 76 | Deliver PLASTIC FM 2 LVPS (to UNH) |  |  |  |  | 158d → 41d |  | constraint none → finish no later than 2004-06-10; baseline start none → 2004-04-12; baseline finish none → 2004-04-13 |
| 77 | Deliver SIT FM 2 HVPS (to UMD) | 2004-03-24 → 2004-04-12 (+19d) | 2004-03-25 → 2004-04-13 (+19d) |  |  | 34d → 31d |  | baseline start none → 2004-04-12; baseline finish none → 2004-04-13 |
| 78 | **Remaining Flight Procurements** |  | 2003-12-29 → 2004-02-19 (+52d) | 44d → 79d |  | 74d → 25d |  | baseline start none → 2003-10-24; baseline finish none → 2004-02-19 |

| ID | Task | Start | Finish | Duration | Complete | Total float | Other |
| --- | --- | --- | --- | --- | --- | --- | --- |
| 79 | Procure IDPU Flight Printed Wiring Board | 2003-12-15 → 2004-02-05 (+52d) | 2003-12-29 → 2004-02-19 (+52d) |  |  | 74d → 25d | constraint start no earlier than 2003-12-15 → start no earlier than 2004-02-05; baseline start none → 2004-02-05; baseline finish none → 2004-02-19 |
| 80 | Procure SEP Flight Printed Wiring Board |  |  |  |  |  | baseline start none → 2003-11-24; baseline finish none → 2003-12-08 |
| 81 | Procure SWEA Flight Printed Wiring Board |  |  |  |  |  | baseline start none → 2003-12-04; baseline finish none → 2003-12-17 |
| 82 | Procure PLASTIC Flight Printed Wiring Board |  |  |  |  |  | baseline start none → 2003-10-24; baseline finish none → 2003-11-06 |
| 83 | **Fabrication** |  | 2004-01-20 → 2004-02-06 A (+17d) | 226d → 239d | 86% → 100% | 171d → none | baseline start none → 2003-02-26; baseline finish none → 2004-02-06 |
| 84 | **FM 1 & FM 2** |  |  |  |  |  | baseline start none → 2003-02-26; baseline finish none → 2003-12-03 |
| 85 | Re-layout IDPU LVPS Flight Printed Wiring Board |  |  |  |  |  | baseline start none → 2003-02-26; baseline finish none → 2003-11-19 |
| 86 | Re-layout SEP LVPS Flight Printed Wiring Board |  |  |  |  |  | baseline start none → 2003-09-24; baseline finish none → 2003-11-07 |
| 87 | Re-layout SWEA LVPS Flight Printed Wiring Board |  |  |  |  |  | baseline start none → 2003-11-26; baseline finish none → 2003-12-03 |
| 88 | **FM 1** |  |  |  |  |  | baseline start none → 2003-09-29; baseline finish none → 2003-12-03 |
| 89 | Wind IDPU LVPS FM 1 Magnets |  |  |  |  |  | baseline start none → 2003-10-17; baseline finish none → 2003-10-30 |
| 90 | Wind SEP LVPS FM 1 Magnets |  |  |  |  |  | baseline start none → 2003-09-29; baseline finish none → 2003-10-20 |
| 91 | Wind SWEA LVPS FM 1 Magnets |  |  |  |  |  | baseline start none → 2003-11-26; baseline finish none → 2003-12-03 |
| 92 | Wind PLASTIC LVPS FM 1 Magnets |  |  |  |  |  | baseline start none → 2003-09-29; baseline finish none → 2003-12-03 |
| 93 | **FM 2** |  | 2004-01-20 → 2004-02-06 A (+17d) | 15d → 28d | 30% → 100% | 171d → none | baseline start none → 2003-12-29; baseline finish none → 2004-02-06 |
| 94 | Wind HVPS FM 2 Magnets |  | 2004-01-20 → 2004-02-06 A (+17d) | 15d → 28d | 30% → 100% | 34d → none | baseline start none → 2003-12-29; baseline finish none → 2004-02-06 |
| 95 | Wind IDPU LVPS FM 2 Magnets |  | 2004-01-20 → 2004-02-06 A (+17d) | 15d → 28d | 30% → 100% | 67d → none | baseline start none → 2003-12-29; baseline finish none → 2004-02-06 |
| 96 | Wind SEP LVPS FM 2 Magnets |  | 2004-01-20 → 2004-02-06 A (+17d) | 15d → 28d | 30% → 100% | 94d → none | baseline start none → 2003-12-29; baseline finish none → 2004-02-06 |
| 97 | Wind SWEA LVPS FM 2 Magnets |  | 2004-01-20 → 2004-02-06 A (+17d) | 15d → 28d | 30% → 100% | 72d → none | baseline start none → 2003-12-29; baseline finish none → 2004-02-06 |
| 98 | Wind PLASTIC LVPS FM 2 Magnets |  | 2004-01-20 → 2004-02-06 A (+17d) | 15d → 28d | 30% → 100% | 171d → none | baseline start none → 2003-12-29; baseline finish none → 2004-02-06 |
| 99 | **Assembly** |  |  |  | 2% → 27% | 143d → 49d | baseline start none → 2003-12-29; baseline finish none → 2004-03-19 |
| 100 | **FM 1** |  | 2004-02-05 → 2004-03-12 (+36d) | 27d → 52d | 5% → 51% | 173d → 25d | baseline start none → 2003-12-29; baseline finish none → 2004-03-12 |
| 101 | Assemble IDPU FM 1 LVPS | 2004-01-06 → 2004-02-26 (+51d) | 2004-01-22 → 2004-03-12 (+50d) |  |  | 74d → 25d | baseline start none → 2004-02-26; baseline finish none → 2004-03-12 |
| 102 | Assemble SEP FM 1 LVPS | 2004-01-12 A | 2004-02-02 → 2004-02-23 (+21d) | 15d → 29d | 0% → 48% | 62d → 36d | baseline start none → 2004-01-12; baseline finish none → 2004-02-23 |
| 103 | Assemble SWEA FM 1 LVPS | 2004-01-16 → 2004-02-13 (+28d) | 2004-02-05 → 2004-03-04 (+28d) |  |  | 49d → 9d | constraint start no earlier than 2004-01-12 → start no earlier than 2004-02-13; baseline start none → 2004-02-13; baseline finish none → 2004-03-04 |
| 104 | Assemble PLASTIC FM 1 LVPS |  | 2004-01-20 → 2004-02-09 A (+20d) | 15d → 29d | 20% → 100% | 185d → none | baseline start none → 2003-12-29; baseline finish none → 2004-02-09 |
| 105 | **FM 2** | 2004-01-21 → 2004-02-09 (+19d) |  | 42d → 29d |  | 34d → 31d | baseline start none → 2004-02-09; baseline finish none → 2004-03-19 |
| 106 | Assemble IDPU FM 2 LVPS |  |  |  |  | 40d → 37d | baseline start none → 2004-03-01; baseline finish none → 2004-03-19 |
| 107 | Assemble SEP FM 2 LVPS |  |  |  |  | 77d → 27d | baseline start none → 2004-02-13; baseline finish none → 2004-03-05 |
| 108 | Assemble SWEA FM 2 LVPS |  |  |  |  | 49d → 53d | baseline start none → 2004-02-24; baseline finish none → 2004-03-15 |
| 109 | Assemble PLASTIC FM 2 LVPS |  |  |  |  | 158d → 41d | baseline start none → 2004-02-09; baseline finish none → 2004-02-27 |
| 110 | Assemble SIT FM 2 HVPS | 2004-01-21 → 2004-02-09 (+19d) | 2004-02-09 → 2004-02-27 (+18d) |  |  | 34d → 31d | baseline start none → 2004-02-09; baseline finish none → 2004-02-27 |
| 111 | **Testing** |  | 2004-07-21 → 2004-06-23 (-28d) | 182d → 162d | 11% → 12% | 88d → 363d | baseline start none → 2003-10-31; baseline finish none → 2004-06-23 |
| 112 | **FM 1 & FM 2** |  | 2004-01-15 → 2004-02-25 (+41d) | 36d → 63d | 53% → 80% | 66d → 25d | baseline start none → 2003-11-24; baseline finish none → 2004-02-25 |
| 113 | Coupon Test IDPU Flight Printed Wiring Board | 2003-12-30 → 2004-02-20 (+52d) | 2004-01-05 → 2004-02-25 (+51d) |  |  | 74d → 25d | baseline start none → 2004-02-20; baseline finish none → 2004-02-25 |
| 114 | Coupon Test SEP Flight Printed Wiring Board |  |  |  |  |  | baseline start none → 2003-12-09; baseline finish none → 2003-12-15 |
| 115 | Coupon Test SWEA Flight Printed Wiring Board | 2004-01-09 A | 2004-01-15 → 2004-01-16 A (+1d) | 5d → 6d | 0% → 100% | 49d → none | baseline start none → 2004-01-09; baseline finish none → 2004-01-16 |
| 116 | Coupon Test PLASTIC Flight Printed Wiring Board |  |  |  |  |  | baseline start none → 2003-11-24; baseline finish none → 2003-12-01 |
| 117 | **FM 1** |  | 2004-07-21 → 2004-06-23 (-28d) | 182d → 162d |  | 88d → 363d | baseline start none → 2003-10-31; baseline finish none → 2004-06-23 |
| 118 | **IDPU** | 2004-01-23 → 2004-03-15 (+52d) | 2004-03-05 → 2004-04-23 (+49d) |  |  | 74d → 25d | baseline start none → 2004-03-15; baseline finish none → 2004-04-23 |
| 119 | Test IDPU FM 1 LVPS | 2004-01-23 → 2004-03-15 (+52d) | 2004-02-12 → 2004-04-02 (+50d) |  |  | 74d → 25d | baseline start none → 2004-03-15; baseline finish none → 2004-04-02 |
| 120 | Coat & Stake IDPU LVPS FM 1 Boards | 2004-02-13 → 2004-04-05 (+52d) | 2004-02-20 → 2004-04-09 (+49d) |  |  | 74d → 25d | baseline start none → 2004-04-05; baseline finish none → 2004-04-09 |
| 121 | Retest IDPU LVPS FM 1 Boards | 2004-02-23 → 2004-04-12 (+49d) | 2004-03-05 → 2004-04-23 (+49d) |  |  | 74d → 25d | baseline start none → 2004-04-12; baseline finish none → 2004-04-23 |
| 122 | **SEP** | 2004-02-03 → 2004-02-24 (+21d) | 2004-03-16 → 2004-04-05 (+20d) |  |  | 62d → 36d | baseline start none → 2004-02-24; baseline finish none → 2004-04-05 |
| 123 | Test SEP FM 1 LVPS | 2004-02-03 → 2004-02-24 (+21d) | 2004-02-24 → 2004-03-15 (+20d) |  |  | 62d → 36d | baseline start none → 2004-02-24; baseline finish none → 2004-03-15 |
| 124 | Coat & Stake SEP LVPS FM 1 Boards | 2004-02-25 → 2004-03-16 (+20d) | 2004-03-02 → 2004-03-22 (+20d) |  |  | 62d → 36d | baseline start none → 2004-03-16; baseline finish none → 2004-03-22 |
| 125 | Retest SEP LVPS FM 1 Boards | 2004-03-03 → 2004-03-23 (+20d) | 2004-03-16 → 2004-04-05 (+20d) |  |  | 62d → 36d | baseline start none → 2004-03-23; baseline finish none → 2004-04-05 |
| 126 | **SWEA** | 2004-02-06 → 2004-03-05 (+28d) | 2004-03-19 → 2004-04-15 (+27d) |  |  | 49d → 9d | baseline start none → 2004-03-05; baseline finish none → 2004-04-15 |
| 127 | Test SWEA FM 1 LVPS | 2004-02-06 → 2004-03-05 (+28d) | 2004-02-27 → 2004-03-25 (+27d) |  |  | 49d → 9d | baseline start none → 2004-03-05; baseline finish none → 2004-03-25 |
| 128 | Coat & Stake SWEA LVPS FM 1 Boards | 2004-03-01 → 2004-03-26 (+25d) | 2004-03-05 → 2004-04-01 (+27d) |  |  | 49d → 9d | baseline start none → 2004-03-26; baseline finish none → 2004-04-01 |
| 129 | Retest SWEA LVPS FM 1 Boards | 2004-03-08 → 2004-04-02 (+25d) | 2004-03-19 → 2004-04-15 (+27d) |  |  | 49d → 9d | baseline start none → 2004-04-02; baseline finish none → 2004-04-15 |
| 130 | **PLASTIC** | 2004-01-21 → 2004-02-10 (+20d) | 2004-03-03 → 2004-03-23 (+20d) |  |  | 185d → 28d | baseline start none → 2004-02-10; baseline finish none → 2004-03-23 |
| 131 | Test PLASTIC FM 1 LVPS | 2004-01-21 → 2004-02-10 (+20d) | 2004-02-10 → 2004-03-02 (+21d) |  |  | 185d → 28d | baseline start none → 2004-02-10; baseline finish none → 2004-03-02 |
| 132 | Coat & Stake PLASTIC LVPS FM 1 Boards | 2004-02-11 → 2004-03-03 (+21d) | 2004-02-18 → 2004-03-09 (+20d) |  |  | 185d → 28d | baseline start none → 2004-03-03; baseline finish none → 2004-03-09 |
| 133 | Retest PLASTIC LVPS FM 1 Boards | 2004-02-19 → 2004-03-10 (+20d) | 2004-03-03 → 2004-03-23 (+20d) |  |  | 185d → 28d | baseline start none → 2004-03-10; baseline finish none → 2004-03-23 |
| 134 | **SIT** |  | 2004-07-21 → 2004-06-23 (-28d) | 182d → 162d |  | 88d → 363d | baseline start none → 2003-10-31; baseline finish none → 2004-06-23 |
| 135 | Test SIT FM 1 HVPS |  |  |  |  |  | baseline start none → 2003-10-31; baseline finish none → 2003-12-08 |
| 136 | Coat & Stake SIT FM 1 HVPS Boards (at UMD) | 2004-07-01 → 2004-06-03 (-28d) | 2004-07-07 → 2004-06-09 (-28d) |  |  | 88d → 363d | baseline start none → 2004-06-03; baseline finish none → 2004-06-09 |
| 137 | Retest SIT FM 1 HVPS Boards (at UMD) | 2004-07-08 → 2004-06-10 (-28d) | 2004-07-21 → 2004-06-23 (-28d) |  |  | 88d → 363d | baseline start none → 2004-06-10; baseline finish none → 2004-06-23 |
| 138 | **FM 2** | 2004-02-10 → 2004-03-01 (+20d) |  | 58d → 45d |  | 34d → 31d | baseline start none → 2004-03-01; baseline finish none → 2004-04-30 |
| 139 | **IDPU** |  |  |  |  | 40d → 37d | baseline start none → 2004-03-22; baseline finish none → 2004-04-30 |
| 140 | Test IDPU FM 2 LVPS |  |  |  |  | 40d → 37d | baseline start none → 2004-03-22; baseline finish none → 2004-04-09 |
| 141 | Coat & Stake IDPU LVPS FM 2 Boards |  |  |  |  | 40d → 37d | baseline start none → 2004-04-12; baseline finish none → 2004-04-16 |
| 142 | Retest IDPU LVPS FM 2 Boards |  |  |  |  | 40d → 37d | baseline start none → 2004-04-19; baseline finish none → 2004-04-30 |
| 143 | **SEP** |  |  |  |  | 77d → 27d | baseline start none → 2004-03-08; baseline finish none → 2004-04-16 |
| 144 | Test SEP FM 2 LVPS |  |  |  |  | 77d → 27d | baseline start none → 2004-03-08; baseline finish none → 2004-03-26 |
| 145 | Coat & Stake SEP LVPS FM 2 Boards |  |  |  |  | 77d → 27d | baseline start none → 2004-03-29; baseline finish none → 2004-04-02 |
| 146 | Retest SEP LVPS FM 2 Boards |  |  |  |  | 77d → 27d | baseline start none → 2004-04-05; baseline finish none → 2004-04-16 |
| 147 | **SWEA** |  |  |  |  | 49d → 53d | baseline start none → 2004-03-16; baseline finish none → 2004-04-26 |
| 148 | Test SWEA FM 2 LVPS |  |  |  |  | 49d → 53d | baseline start none → 2004-03-16; baseline finish none → 2004-04-05 |

| ID | Task | Start | Finish | Duration | Complete | Total float | Other |
| --- | --- | --- | --- | --- | --- | --- | --- |
| 149 | Coat & Stake SWEA LVPS FM 2 Boards |  |  |  |  | 49d → 53d | baseline start none → 2004-04-06; baseline finish none → 2004-04-12 |
| 150 | Retest SWEA LVPS FM 2 Boards |  |  |  |  | 49d → 53d | baseline start none → 2004-04-13; baseline finish none → 2004-04-26 |
| 151 | **PLASTIC** |  |  |  |  | 158d → 41d | baseline start none → 2004-03-01; baseline finish none → 2004-04-09 |
| 152 | Test PLASTIC FM 2 LVPS |  |  |  |  | 158d → 41d | baseline start none → 2004-03-01; baseline finish none → 2004-03-19 |
| 153 | Coat & Stake PLASTIC LVPS FM 2 Boards |  |  |  |  | 158d → 41d | baseline start none → 2004-03-22; baseline finish none → 2004-03-26 |
| 154 | Retest PLASTIC LVPS FM 2 Boards |  |  |  |  | 158d → 41d | baseline start none → 2004-03-29; baseline finish none → 2004-04-09 |
| 155 | **SIT** | 2004-02-10 → 2004-03-01 (+20d) | 2004-03-23 → 2004-04-09 (+17d) |  |  | 34d → 31d | baseline start none → 2004-03-01; baseline finish none → 2004-04-09 |
| 156 | Test SIT FM 2 HVPS | 2004-02-10 → 2004-03-01 (+20d) | 2004-03-02 → 2004-03-19 (+17d) |  |  | 34d → 31d | baseline start none → 2004-03-01; baseline finish none → 2004-03-19 |
| 157 | Coat & Stake SIT FM 2 HVPS Boards | 2004-03-03 → 2004-03-22 (+19d) | 2004-03-09 → 2004-03-26 (+17d) |  |  | 34d → 31d | baseline start none → 2004-03-22; baseline finish none → 2004-03-26 |
| 158 | Retest SIT FM 2 HVPS Boards | 2004-03-10 → 2004-03-29 (+19d) | 2004-03-23 → 2004-04-09 (+17d) |  |  | 34d → 31d | baseline start none → 2004-03-29; baseline finish none → 2004-04-09 |
| 159 | **IDPU - UCB** |  |  |  | 59% → 69% | 55d → 310d | baseline start none → 2003-05-05; baseline finish none → 2004-09-07 |
| 160 | **Deliveries** | 2004-02-09 → 2004-04-13 (+64d) |  | 78d → 33d |  | 112d → 53d | baseline start none → 2004-04-13; baseline finish none → 2004-05-28 |
| 161 | IDPU FM 1 Complete (to UCB for Boom I&T, then to CIT for SEP I&T, Suite EMC, BO & Final Boom I&T) | 2004-04-02 → 2004-05-21 (+49d) | 2004-04-02 → 2004-05-21 (+49d) |  |  | 74d → 25d | was named IDPU FM 1 Complete (to CIT for SEP I&T, then to UCB for Boom I&T, Suite EMC, BO & Final Boom I&T); baseline start none → 2004-05-21; baseline finish none → 2004-05-21 |
| 162 | IDPU FM 2 Complete (to CIT for SEP I&T, then to UCB for Boom I&T, Boom EMC, BO & Final Boom I&T) |  |  |  |  | 40d → 37d | baseline start none → 2004-05-28; baseline finish none → 2004-05-28 |
| 163 | Deliver IDPU S/W Build 3 (to UNH) | 2004-02-09 → 2004-04-13 (+64d) | 2004-02-09 → 2004-04-13 (+64d) |  |  | 203d → 413d | baseline start none → 2004-04-13; baseline finish none → 2004-04-13 |
| 164 | **Flight Software** |  | 2004-02-09 → 2004-04-13 (+64d) | 192d → 237d | 81% → 83% | 108d → 60d | baseline start none → 2003-05-05; baseline finish none → 2004-04-13 |
| 165 | IDPU S/W Build #2.5 |  |  |  |  |  | baseline start none → 2003-05-05; baseline finish none → 2003-11-07 |
| 166 | IDPU S/W Build #3 |  | 2004-02-09 → 2004-04-13 (+64d) | 120d → 165d | 60% → 69% | 108d → 60d | baseline start none → 2003-08-15; baseline finish none → 2004-04-13 |
| 167 | **GSE** |  |  |  | 50% → 65% | 55d → 310d | baseline start none → 2003-06-30; baseline finish none → 2004-09-07 |
| 168 | STE Science Display |  |  |  |  |  | baseline start none → 2003-10-23; baseline finish none → 2003-12-02 |
| 169 | SWEA Science Display |  | 2004-01-21 → 2004-02-23 (+33d) | 140d → 162d | 62% → 91% | 216d → 449d | baseline start none → 2003-06-30; baseline finish none → 2004-02-23 |
| 170 | GSE Continued Development |  |  |  | 40% → 47% | 55d → 310d | baseline start none → 2003-07-15; baseline finish none → 2004-09-07 |
| 171 | **Integration & Test** |  | 2004-08-17 → 2004-05-28 (-81d) | 218d → 162d | 33% → 38% | 40d → 37d | baseline start none → 2003-10-07; baseline finish none → 2004-05-28 |
| 172 | IDPU DCB FM 2 Board Level Testing |  |  |  |  |  | baseline start none → 2003-10-07; baseline finish none → 2003-10-28 |
| 173 | IDPU DCB Clean/Stake/Coat (FM 1 & FM 2) |  |  |  |  |  | baseline start none → 2003-12-26; baseline finish none → 2004-01-09 |
| 174 | **FM 1** | 2004-03-08 → 2004-04-26 (+49d) | 2004-08-09 → 2004-05-21 (-80d) | 110d → 20d |  | 32d → 25d | baseline start none → 2004-04-26; baseline finish none → 2004-05-21 |
| 175 | IDPU FM 1 I & T | 2004-03-08 → 2004-04-26 (+49d) | 2004-03-12 → 2004-04-30 (+49d) |  |  | 74d → 25d | baseline start none → 2004-04-26; baseline finish none → 2004-04-30 |
| 176 | IDPU FM 1 Vibration | 2004-03-15 → 2004-05-03 (+49d) | 2004-03-19 → 2004-05-07 (+49d) |  |  | 74d → 25d | baseline start none → 2004-05-03; baseline finish none → 2004-05-07 |
| 177 | IDPU FM 1 Thermal Vacuum & Bake Out | 2004-03-22 → 2004-05-10 (+49d) | 2004-04-02 → 2004-05-21 (+49d) |  |  | 74d → 25d | was named IDPU FM 1 Thermal Vacuum; baseline start none → 2004-05-10; baseline finish none → 2004-05-21 |
| 178 | **FM 2** |  | 2004-08-17 → 2004-05-28 (-81d) | 76d → 20d |  | 40d → 37d | baseline start none → 2004-05-03; baseline finish none → 2004-05-28 |
| 179 | IDPU FM 2 I & T |  |  |  |  | 40d → 37d | baseline start none → 2004-05-03; baseline finish none → 2004-05-07 |
| 180 | IDPU FM 2 Vibration |  |  |  |  | 40d → 37d | baseline start none → 2004-05-10; baseline finish none → 2004-05-14 |
| 181 | IDPU FM 2 Thermal Vacuum & Bake Out |  |  |  |  | 40d → 37d | was named IDPU FM 2 Thermal Vacuum; baseline start none → 2004-05-17; baseline finish none → 2004-05-28 |
| 182 | **BOOM Suite - UCB** |  | 2004-09-13 → 2004-09-28 (+15d) | 304d → 315d | 56% → 67% | 32d → 20d | baseline start none → 2003-07-01; baseline finish none → 2004-09-28 |
| 183 | **BOOM Structure - UCB** |  | 2004-06-08 → 2004-06-18 (+10d) | 187d → 195d | 59% → 73% | 74d → 70d | baseline start none → 2003-09-10; baseline finish none → 2004-06-18 |
| 184 | **Deliveries** |  | 2004-06-08 → 2004-06-18 (+10d) | 104d → 112d |  | 74d → 70d | baseline start none → 2004-01-09; baseline finish none → 2004-06-18 |
| 185 | Protoflight Boom available for I&T (if needed) |  |  |  |  |  | baseline start none → 2004-01-09; baseline finish none → 2004-01-09 |
| 186 | Deliver Boom Structure FM 1 (stays at UCB for Boom Suite FM 1 I&T) | 2004-05-17 → 2004-05-27 (+10d) | 2004-05-17 → 2004-05-27 (+10d) |  |  | 48d → 19d | baseline start none → 2004-05-27; baseline finish none → 2004-05-27 |
| 187 | Deliver Boom Structure FM 2 (stays at UCB for Boom Suite FM 2 I&T) | 2004-06-08 → 2004-06-18 (+10d) | 2004-06-08 → 2004-06-18 (+10d) |  |  | 74d → 70d | baseline start none → 2004-06-18; baseline finish none → 2004-06-18 |
| 188 | **Protoflight** |  |  |  |  |  | baseline start none → 2003-09-16; baseline finish none → 2004-01-09 |
| 189 | Protoflight Boom Post Environmental Deployment Test |  |  |  |  |  | baseline start none → 2003-09-16; baseline finish none → 2003-11-04 |
| 190 | Document Protoflight Boom Test Results |  |  |  |  |  | baseline start none → 2003-11-05; baseline finish none → 2004-01-09 |
| 191 | **Flight Procurements** |  |  |  |  |  | baseline start none → 2003-09-10; baseline finish none → 2003-11-05 |
| 192 | Receive and Inspect Flight Boom Structure Tubes (FM 1) |  |  |  |  |  | baseline start none → 2003-09-10; baseline finish none → 2003-10-24 |
| 193 | Receive and Inspect Flight Boom Structure Tubes (FM 2) |  |  |  |  |  | baseline start none → 2003-09-10; baseline finish none → 2003-11-05 |
| 194 | **FM 1** |  | 2004-05-17 → 2004-05-27 (+10d) | 159d → 167d | 46% → 65% | 48d → 19d | baseline start none → 2003-09-29; baseline finish none → 2004-05-27 |
| 195 | **Telescoping** |  | 2004-02-24 → 2004-02-29 (+5d) | 81d → 84d | 59% → 86% | 50d → 26d | baseline start none → 2003-10-27; baseline finish none → 2004-02-29 |
| 196 | **Fabrication, Assembly & Test** |  | 2004-02-24 → 2004-02-29 (+5d) | 81d → 84d | 59% → 86% | 50d → 26d | baseline start none → 2003-10-27; baseline finish none → 2004-02-29 |
| 197 | Machine FM 1 Boom Structure Tubes as necessary |  |  |  |  |  | baseline start none → 2003-10-27; baseline finish none → 2003-10-31 |
| 198 | Machine FM 1 Boom Structure Parts (Rings) |  |  |  |  |  | baseline start none → 2003-11-07; baseline finish none → 2004-01-05 |
| 199 | Assemble FM 1 Boom Structure Telescoping Assembly | 2004-01-12 → 2004-02-23 (+42d) | 2004-02-09 → 2004-02-27 (+18d) | 20d → 5d |  | 50d → 24d | constraint start no earlier than 2004-01-12 → start no earlier than 2004-02-23; baseline start none → 2004-02-23; baseline finish none → 2004-02-27 |
| 200 | Test FM 1 Boom Structure Telescoping Assembly | 2004-02-10 → 2004-02-28 (+18d) | 2004-02-24 → 2004-02-29 (+5d) | 10d → 2d |  | 50d → 28d | baseline start none → 2004-02-28; baseline finish none → 2004-02-29 |
| 201 | **Harness** |  | 2004-02-26 → 2004-03-08 (+11d) | 102d → 109d | 41% → 76% | 48d → 20d | baseline start none → 2003-09-29; baseline finish none → 2004-03-08 |
| 202 | **Fabrication** |  | 2004-01-13 → 2004-02-27 (+45d) | 72d → 103d | 59% → 82% | 48d → 18d | baseline start none → 2003-09-29; baseline finish none → 2004-02-27 |
| 203 | Machine FM 1 Harness Parts |  | 2004-01-13 → 2004-02-27 (+45d) | 72d → 103d | 59% → 82% | 48d → 18d | baseline start none → 2003-09-29; baseline finish none → 2004-02-27 |
| 204 | **Assembly & Test** | 2004-01-14 → 2004-03-01 (+47d) | 2004-02-26 → 2004-03-08 (+11d) | 30d → 6d |  | 48d → 18d | baseline start none → 2004-03-01; baseline finish none → 2004-03-08 |
| 205 | Assemble FM 1 Harness subassembly | 2004-01-14 → 2004-03-01 (+47d) | 2004-02-11 → 2004-03-07 (+25d) | 20d → 7d |  | 48d → 20d | constraint none → start no earlier than 2004-03-01; baseline start none → 2004-03-01; baseline finish none → 2004-03-07 |
| 206 | FM1 Harness Test | 2004-02-12 → 2004-03-08 (+25d) | 2004-02-26 → 2004-03-08 (+11d) | 10d → 1d |  | 48d → 20d | baseline start none → 2004-03-08; baseline finish none → 2004-03-08 |
| 207 | **Mounting** |  |  |  |  |  | baseline start none → 2003-09-29; baseline finish none → 2003-11-21 |
| 208 | FM 1Boom Structure Mounting Fabrication |  |  |  |  |  | baseline start none → 2003-09-29; baseline finish none → 2003-11-06 |
| 209 | FM 1Boom Structure Mounting Assembly |  |  |  |  |  | baseline start none → 2003-11-07; baseline finish none → 2003-11-21 |
| 210 | **Integration & Test** | 2004-02-27 → 2004-03-09 (+11d) | 2004-05-17 → 2004-05-27 (+10d) | 57d → 58d |  | 48d → 19d | baseline start none → 2004-03-09; baseline finish none → 2004-05-27 |
| 211 | Integrate FM 1 Boom Structure subassemblies & Harness Completion | 2004-02-27 → 2004-03-09 (+11d) | 2004-03-25 → 2004-04-05 (+11d) |  |  | 48d → 20d | was named Integrate FM 1 Boom Structure subassemblies; baseline start none → 2004-03-09; baseline finish none → 2004-04-05 |
| 212 | FM 1 Boom Structure Deployment Test | 2004-03-26 → 2004-04-06 (+11d) | 2004-04-08 → 2004-04-19 (+11d) |  |  | 48d → 20d | baseline start none → 2004-04-06; baseline finish none → 2004-04-19 |
| 213 | FM 1 Boom Structure Vibration Test | 2004-04-15 → 2004-04-27 (+12d) | 2004-04-20 → 2004-04-30 (+10d) |  |  | 48d → 19d | was named FM 1 Boom Structure Vibration Testing Completed; baseline start none → 2004-04-27; baseline finish none → 2004-04-30 |
| 214 | FM 1 Boom Structure Themal Vac & Bake Out | 2004-04-21 → 2004-05-03 (+12d) | 2004-05-11 → 2004-05-21 (+10d) |  |  | 48d → 19d | was named FM 1 Boom Structure Themal Vac Testing Completed; baseline start none → 2004-05-03; baseline finish none → 2004-05-21 |
| 215 | FM 1 Boom Structure Post Environmental Deployment Test | 2004-05-12 → 2004-05-24 (+12d) | 2004-05-17 → 2004-05-27 (+10d) |  |  | 48d → 19d | was named FM 1 Boom Structure Post Environmental Deployment Test Completed; baseline start none → 2004-05-24; baseline finish none → 2004-05-27 |
| 216 | **FM 2** |  | 2004-06-08 → 2004-06-18 (+10d) | 174d → 182d | 47% → 65% | 74d → 70d | baseline start none → 2003-09-29; baseline finish none → 2004-06-18 |
| 217 | **Telescoping** |  | 2004-02-24 → 2004-03-16 (+21d) | 73d → 88d | 62% → 88% | 91d → 80d | baseline start none → 2003-11-06; baseline finish none → 2004-03-16 |
| 218 | **Fabrication, Assembly & Test** |  | 2004-02-24 → 2004-03-16 (+21d) | 73d → 88d | 62% → 88% | 91d → 80d | baseline start none → 2003-11-06; baseline finish none → 2004-03-16 |

| ID | Task | Start | Finish | Duration | Complete | Total float | Predecessors | Other |
| --- | --- | --- | --- | --- | --- | --- | --- | --- |
| 219 | Machine FM 2 Boom Structure Tubes as necessary |  |  |  |  |  |  | baseline start none → 2003-11-06; baseline finish none → 2003-11-21 |
| 220 | Machine FM 2 Boom Structure Parts (Rings) |  |  |  |  |  |  | baseline start none → 2003-11-07; baseline finish none → 2004-01-05 |
| 221 | Assemble FM 2 Boom Structure Telescoping Assembly | 2004-01-12 → 2004-02-23 (+42d) | 2004-02-09 → 2004-02-27 (+18d) | 20d → 5d |  | 91d → 80d | 219, 220 → 219, 220, 199SS | constraint start no earlier than 2004-01-12 → none; baseline start none → 2004-02-23; baseline finish none → 2004-02-27 |
| 222 | Test FM 2 Boom Structure Telescoping Assembly | 2004-02-10 → 2004-03-15 (+34d) | 2004-02-24 → 2004-03-16 (+21d) | 10d → 2d |  | 91d → 80d | 221 → 221FS+10d | baseline start none → 2004-03-15; baseline finish none → 2004-03-16 |
| 223 | **Harness** |  | 2004-02-26 → 2004-03-16 (+19d) | 102d → 115d | 41% → 73% | 89d → 80d |  | baseline start none → 2003-09-29; baseline finish none → 2004-03-16 |
| 224 | **Fabrication** |  | 2004-01-13 → 2004-02-27 (+45d) | 72d → 103d | 59% → 82% | 89d → 80d |  | baseline start none → 2003-09-29; baseline finish none → 2004-02-27 |
| 225 | Machine FM 2 Harness Parts |  | 2004-01-13 → 2004-02-27 (+45d) | 72d → 103d | 59% → 82% | 89d → 80d |  | baseline start none → 2003-09-29; baseline finish none → 2004-02-27 |
| 226 | **Assembly & Test** | 2004-01-14 → 2004-03-01 (+47d) | 2004-02-26 → 2004-03-16 (+19d) | 30d → 12d |  | 89d → 80d |  | baseline start none → 2004-03-01; baseline finish none → 2004-03-16 |
| 227 | Assemble FM 2 Harness subassembly | 2004-01-14 → 2004-03-01 (+47d) | 2004-02-11 → 2004-03-15 (+33d) | 20d → 11d |  | 89d → 80d |  | baseline start none → 2004-03-01; baseline finish none → 2004-03-15 |
| 228 | FM 2 Harness Test | 2004-02-12 → 2004-03-16 (+33d) | 2004-02-26 → 2004-03-16 (+19d) | 10d → 1d |  | 89d → 80d |  | baseline start none → 2004-03-16; baseline finish none → 2004-03-16 |
| 229 | **Mounting** |  |  |  |  |  |  | baseline start none → 2003-09-29; baseline finish none → 2003-11-21 |
| 230 | FM 2 Boom Structure Mountings Fabrication |  |  |  |  |  |  | baseline start none → 2003-09-29; baseline finish none → 2003-11-06 |
| 231 | FM 2 Boom Structure Mountings Assembly |  |  |  |  |  |  | baseline start none → 2003-11-07; baseline finish none → 2003-11-21 |
| 232 | **Integration & Test** | 2004-02-27 → 2004-03-17 (+19d) | 2004-06-08 → 2004-06-18 (+10d) | 72d → 67d |  | 74d → 70d |  | baseline start none → 2004-03-17; baseline finish none → 2004-06-18 |
| 233 | Integrate FM 2 Boom Structure subassemblies & Harness Completion | 2004-02-27 → 2004-03-17 (+19d) | 2004-03-25 → 2004-04-13 (+19d) |  |  | 89d → 80d |  | was named Integrate FM 2 Boom Structure subassemblies; baseline start none → 2004-03-17; baseline finish none → 2004-04-13 |
| 234 | FM 2 Boom Structure Deployment Test | 2004-03-26 → 2004-04-14 (+19d) | 2004-04-08 → 2004-04-27 (+19d) |  |  | 89d → 80d |  | baseline start none → 2004-04-14; baseline finish none → 2004-04-27 |
| 235 | FM 2 Boom Structure Vibration Test | 2004-04-16 → 2004-05-17 (+31d) | 2004-04-21 → 2004-05-20 (+29d) |  |  | 88d → 71d |  | baseline start none → 2004-05-17; baseline finish none → 2004-05-20 |
| 236 | FM 2 Boom Structure Themal Vac & Bake Out | 2004-05-12 → 2004-05-24 (+12d) | 2004-06-02 → 2004-06-14 (+12d) |  |  | 74d → 70d |  | was named FM 2 Boom Structure Themal Vac Testing; baseline start none → 2004-05-24; baseline finish none → 2004-06-14 |
| 237 | FM 2 Boom Structure Post Environmental Deployment Test | 2004-06-03 → 2004-06-15 (+12d) | 2004-06-08 → 2004-06-18 (+10d) |  |  | 74d → 70d |  | baseline start none → 2004-06-15; baseline finish none → 2004-06-18 |
| 238 | **MAG - GSFC** | 2004-01-09 → 2004-02-20 (+42d) | 2004-03-17 → 2004-03-29 (+12d) | 47d → 27d |  | 72d → 35d |  | baseline start none → 2004-02-20; baseline finish none → 2004-03-29 |
| 239 | **Deliveries** | 2004-02-17 → 2004-03-26 (+38d) | 2004-03-17 → 2004-03-29 (+12d) | 22d → 2d |  | 72d → 35d |  | baseline start none → 2004-03-26; baseline finish none → 2004-03-29 |
| 240 | Deliver MAG FM 1 (to UCB for IDPU/BOOM Suite FM 1 I&T) | 2004-02-17 → 2004-03-26 (+38d) | 2004-02-18 → 2004-03-29 (+40d) |  |  | 84d → 35d |  | baseline start none → 2004-03-26; baseline finish none → 2004-03-29 |
| 241 | Deliver MAG FM 2 (to UCB for IDPU/BOOM Suite FM 2 I&T) | 2004-03-16 → 2004-03-26 (+10d) | 2004-03-17 → 2004-03-29 (+12d) |  |  | 72d → 61d |  | baseline start none → 2004-03-26; baseline finish none → 2004-03-29 |
| 242 | **FM 1** | 2004-01-09 → 2004-02-20 (+42d) | 2004-02-13 → 2004-03-25 (+41d) |  |  | 84d → 35d |  | baseline start none → 2004-02-20; baseline finish none → 2004-03-25 |
| 243 | FM 1 MAG Testing | 2004-01-09 → 2004-02-20 (+42d) | 2004-01-23 → 2004-03-04 (+41d) |  |  | 84d → 35d |  | constraint start no earlier than 2004-01-09 → start no earlier than 2004-02-20; baseline start none → 2004-02-20; baseline finish none → 2004-03-04 |
| 244 | MAG FM 1 Calibration | 2004-01-26 → 2004-03-05 (+39d) | 2004-02-13 → 2004-03-25 (+41d) |  |  | 84d → 35d |  | baseline start none → 2004-03-05; baseline finish none → 2004-03-25 |
| 245 | **FM 2** | 2004-02-09 → 2004-02-20 (+11d) | 2004-03-15 → 2004-03-25 (+10d) |  |  | 72d → 61d |  | baseline start none → 2004-02-20; baseline finish none → 2004-03-25 |
| 246 | FM 2 MAG Testing | 2004-02-09 → 2004-02-20 (+11d) | 2004-02-23 → 2004-03-04 (+10d) |  |  | 72d → 61d |  | constraint start no earlier than 2004-02-09 → start no earlier than 2004-02-20; baseline start none → 2004-02-20; baseline finish none → 2004-03-04 |
| 247 | MAG FM 2 Calibration | 2004-02-24 → 2004-03-05 (+10d) | 2004-03-15 → 2004-03-25 (+10d) |  |  | 72d → 61d |  | baseline start none → 2004-03-05; baseline finish none → 2004-03-25 |
| 248 | **SWEA - CESR** |  | 2004-03-31 → 2004-04-20 (+20d) | 79d → 93d |  | 77d → 67d |  | baseline start none → 2003-12-08; baseline finish none → 2004-04-20 |
| 249 | **Deliveries** |  | 2004-03-31 → 2004-04-20 (+20d) | 79d → 93d |  | 77d → 67d |  | baseline start none → 2003-12-08; baseline finish none → 2004-04-20 |
| 250 | SWEA FM 1 Delivery to UCB |  |  |  |  |  |  | baseline start none → 2003-12-08; baseline finish none → 2003-12-10 |
| 251 | SWEA FM 2 Delivery to UCB | 2004-03-29 → 2004-04-16 (+18d) | 2004-03-31 → 2004-04-20 (+20d) |  |  | 77d → 67d |  | baseline start none → 2004-04-16; baseline finish none → 2004-04-20 |
| 252 | **FM 2** | 2004-01-21 → 2004-02-10 (+20d) | 2004-03-26 → 2004-04-15 (+20d) |  |  | 77d → 67d |  | baseline start none → 2004-02-10; baseline finish none → 2004-04-15 |
| 253 | SWEA FM 2 Final Assembly (Block 2) | 2004-01-21 → 2004-02-10 (+20d) | 2004-01-23 → 2004-02-12 (+20d) |  |  | 77d → 67d |  | constraint start no earlier than 2004-01-21 → start no earlier than 2004-02-10; baseline start none → 2004-02-10; baseline finish none → 2004-02-12 |
| 254 | SWEA FM 2 Calibration | 2004-01-26 → 2004-02-13 (+18d) | 2004-03-26 → 2004-04-15 (+20d) |  |  | 77d → 67d |  | baseline start none → 2004-02-13; baseline finish none → 2004-04-15 |
| 255 | **STE - UCB** |  | 2004-04-09 → 2004-05-10 (+31d) | 153d → 174d | 55% → 67% | 88d → 71d |  | baseline start none → 2003-08-29; baseline finish none → 2004-05-10 |
| 256 | **Deliveries** | 2004-03-30 → 2004-04-14 (+15d) | 2004-04-09 → 2004-05-10 (+31d) | 8d → 18d |  | 52d → 20d |  | baseline start none → 2004-04-14; baseline finish none → 2004-05-10 |
| 257 | Deliver STE-D FM 1 (stays at UCB for SWEA/STE-D FM 1 I&T) | 2004-03-30 → 2004-04-14 (+15d) | 2004-03-30 → 2004-04-14 (+15d) |  |  | 52d → 20d |  | baseline start none → 2004-04-14; baseline finish none → 2004-04-14 |
| 258 | Deliver STE-D FM 2 (stays at UCB for SWEA/STE-D FM 2 I&T) | 2004-04-09 → 2004-05-10 (+31d) | 2004-04-09 → 2004-05-10 (+31d) |  |  | 70d → 53d |  | baseline start none → 2004-05-10; baseline finish none → 2004-05-10 |
| 259 | Deliver STE-U FM 1 (stays at UCB for BOOM Suite FM 1 I&T) | 2004-04-05 → 2004-04-20 (+15d) | 2004-04-05 → 2004-04-20 (+15d) |  |  | 51d → 19d |  | baseline start none → 2004-04-20; baseline finish none → 2004-04-20 |
| 260 | Deliver STE-U FM 2 (stays at UCB for BOOM Suite FM 2 I&T) | 2004-04-09 → 2004-05-10 (+31d) | 2004-04-09 → 2004-05-10 (+31d) |  |  | 88d → 71d |  | baseline start none → 2004-05-10; baseline finish none → 2004-05-10 |
| 261 | **STE-U/D Housing** |  | 2004-01-16 → 2004-02-09 A (+24d) | 38d → 53d | 71% → 100% | 100d → none |  | baseline start none → 2003-11-21; baseline finish none → 2004-02-09 |
| 262 | Fabricate STE FM 1 Box |  | 2004-01-16 → 2004-02-09 A (+24d) | 38d → 53d | 71% → 100% | 61d → none |  | baseline start none → 2003-11-21; baseline finish none → 2004-02-09 |
| 263 | Fabricate STE FM 2 Box |  | 2004-01-16 → 2004-02-09 A (+24d) | 38d → 53d | 71% → 100% | 100d → none |  | baseline start none → 2003-11-21; baseline finish none → 2004-02-09 |
| 264 | **STE-U/D Detector Boards** |  | 2004-04-09 → 2004-05-10 (+31d) | 153d → 174d | 51% → 56% | 88d → 71d |  | baseline start none → 2003-08-29; baseline finish none → 2004-05-10 |
| 265 | Coupon Test STE FM 1 & FM 2 Detector Printed Wiring Board |  |  |  |  |  |  | baseline start none → 2003-10-10; baseline finish none → 2003-11-04 |
| 266 | **FM 1** |  | 2004-04-05 → 2004-04-20 (+15d) | 149d → 160d | 47% → 58% | 51d → 19d |  | baseline start none → 2003-08-29; baseline finish none → 2004-04-20 |
| 267 | Fabrication STE FM 1 Detector Printed Wiring Board |  |  |  |  |  |  | baseline start none → 2003-08-29; baseline finish none → 2003-10-09 |
| 268 | Load STE FM 1 Detector Printed Wiring Board |  | 2004-01-16 → 2004-02-03 A (+18d) | 49d → 60d | 78% → 100% | 51d → none |  | baseline start none → 2003-11-05; baseline finish none → 2004-02-03 |
| 269 | Test STE FM 1 Detector Printed Wiring Board | 2004-01-20 → 2004-02-04 (+15d) | 2004-02-02 → 2004-02-18 (+16d) |  |  | 51d → 19d |  | baseline start none → 2004-02-04; baseline finish none → 2004-02-18 |
| 270 | **Integration & Test** | 2004-02-03 → 2004-02-19 (+16d) | 2004-04-05 → 2004-04-20 (+15d) |  |  | 51d → 19d |  | baseline start none → 2004-02-19; baseline finish none → 2004-04-20 |
| 271 | Integrate & Test STE-U/D FM 1 Detectors W/ FM 1 Housings | 2004-02-03 → 2004-02-19 (+16d) | 2004-03-02 → 2004-03-17 (+15d) |  |  | 51d → 19d |  | baseline start none → 2004-02-19; baseline finish none → 2004-03-17 |
| 272 | Calibrate STE-U/D FM 1 | 2004-03-03 → 2004-03-18 (+15d) | 2004-03-30 → 2004-04-14 (+15d) |  |  | 51d → 19d |  | baseline start none → 2004-03-18; baseline finish none → 2004-04-14 |
| 273 | STE-U FM 1 Thermal Vacuum/Balance/Bake Out | 2004-03-17 → 2004-04-01 (+15d) | 2004-04-05 → 2004-04-20 (+15d) |  |  | 51d → 19d |  | was named STE-U FM 1 Thermal Vacuum/Balance; baseline start none → 2004-04-01; baseline finish none → 2004-04-20 |
| 274 | **FM 2** |  | 2004-04-09 → 2004-05-10 (+31d) | 153d → 174d |  | 88d → 71d |  | baseline start none → 2003-08-29; baseline finish none → 2004-05-10 |
| 275 | Fabricate STE FM 2 Detector Printed Wiring Board |  |  |  |  |  |  | baseline start none → 2003-08-29; baseline finish none → 2003-10-09 |
| 276 | Load STE FM 2 Detector Printed Wiring Board |  | 2004-02-06 → 2004-03-17 (+40d) |  |  | 76d → 53d | 265 → 265, 269FF+20d | baseline start none → 2003-11-05; baseline finish none → 2004-03-17 |
| 277 | Test STE FM 2 Detector Printed Wiring Board | 2004-02-09 → 2004-03-18 (+38d) | 2004-02-23 → 2004-03-31 (+37d) |  |  | 76d → 53d |  | baseline start none → 2004-03-18; baseline finish none → 2004-03-31 |
| 278 | **Integration & Test** | 2004-03-03 → 2004-04-01 (+29d) | 2004-04-09 → 2004-05-10 (+31d) |  |  | 70d → 53d |  | baseline start none → 2004-04-01; baseline finish none → 2004-05-10 |
| 279 | Integrate & Test STE-U/D FM 2 Detectors W/ FM 2 Housings | 2004-03-03 → 2004-04-01 (+29d) | 2004-03-16 → 2004-04-14 (+29d) |  |  | 70d → 53d |  | baseline start none → 2004-04-01; baseline finish none → 2004-04-14 |
| 280 | Calibrate STE-U/D FM 2 | 2004-03-17 → 2004-04-15 (+29d) | 2004-04-09 → 2004-05-10 (+31d) |  |  | 70d → 53d |  | baseline start none → 2004-04-15; baseline finish none → 2004-05-10 |
| 281 | STE-U FM 2 Thermal Vacuum/Bake Out | 2004-03-29 → 2004-04-27 (+29d) | 2004-04-09 → 2004-05-10 (+31d) |  |  | 88d → 71d |  | was named STE-U FM 2 Thermal Vacuum; baseline start none → 2004-04-27; baseline finish none → 2004-05-10 |
| 282 | **STE and SWEA - UCB** |  | 2004-08-20 → 2004-08-27 (+7d) | 289d → 294d | 67% → 73% | 21d → 20d |  | baseline start none → 2003-07-01; baseline finish none → 2004-08-27 |
| 283 | **Deliveries** | 2004-01-26 → 2004-02-27 (+32d) | 2004-07-13 → 2004-08-27 (+45d) | 119d → 129d |  | 49d → 20d |  | baseline start none → 2004-02-27; baseline finish none → 2004-08-27 |
| 284 | Deliver STE-U FM 1 Interface (stays at UCB for IDPU FM 1 I&T) | 2004-01-26 → 2004-02-27 (+32d) | 2004-01-26 → 2004-02-27 (+32d) |  |  | 102d → 65d |  | baseline start none → 2004-02-27; baseline finish none → 2004-02-27 |
| 285 | Deliver STE-U FM 2 Interface (stays at UCB for IDPU FM 2 I&T) | 2004-01-26 → 2004-03-01 (+35d) | 2004-01-26 → 2004-03-01 (+35d) |  |  | 108d → 81d |  | baseline start none → 2004-03-01; baseline finish none → 2004-03-01 |
| 286 | Deliver SWEA/STE-D FM 1 (stays at UCB for Boom Suite FM 1 I&T) | 2004-05-14 → 2004-06-11 (+28d) | 2004-05-14 → 2004-06-11 (+28d) |  |  | 49d → 9d |  | baseline start none → 2004-06-11; baseline finish none → 2004-06-11 |
| 287 | Deliver SWEA/STE-D FM 2 (stays at UCB for Boom Suite FM 2 I&T) | 2004-07-13 → 2004-08-27 (+45d) | 2004-07-13 → 2004-08-27 (+45d) |  |  | 49d → 20d |  | baseline start none → 2004-08-27; baseline finish none → 2004-08-27 |
| 288 | **SWEA Pedestal** |  | 2004-01-16 → 2004-02-09 A (+24d) | 137d → 152d | 92% → 100% | 98d → none |  | baseline start none → 2003-07-01; baseline finish none → 2004-02-09 |

| ID | Task | Start | Finish | Duration | Complete | Total float | Predecessors | Other |
| --- | --- | --- | --- | --- | --- | --- | --- | --- |
| 289 | Fabricate SWEA FM 1 Baseplate |  | 2004-01-16 → 2004-02-09 A (+24d) | 137d → 152d | 92% → 100% | 72d → none |  | baseline start none → 2003-07-01; baseline finish none → 2004-02-09 |
| 290 | Fabricate SWEA FM 2 Baseplate |  | 2004-01-16 → 2004-02-09 A (+24d) | 137d → 152d | 92% → 100% | 98d → none |  | baseline start none → 2003-07-01; baseline finish none → 2004-02-09 |
| 291 | **STE-D Pre-Amp Board** |  | 2003-12-09 → 2004-02-23 (+76d) | 54d → 104d |  | 124d → 78d |  | baseline start none → 2003-09-22; baseline finish none → 2004-02-23 |
| 292 | **FM 1** |  | 2003-12-09 → 2004-02-23 (+76d) | 54d → 104d |  | 98d → 27d |  | baseline start none → 2003-09-22; baseline finish none → 2004-02-23 |
| 293 | Fabricate STE-D FM 1 Preamp Printed Wiring Board |  |  |  |  |  |  | baseline start none → 2003-09-22; baseline finish none → 2003-11-07 |
| 294 | Load STE-D FM 1 Preamp Printed Wiring Board | 2003-12-03 → 2004-02-17 (+76d) | 2003-12-09 → 2004-02-23 (+76d) |  |  | 98d → 27d |  | constraint none → start no earlier than 2004-02-17; baseline start none → 2004-02-17; baseline finish none → 2004-02-23 |
| 295 | **FM 2** |  | 2003-12-09 → 2004-02-23 (+76d) | 54d → 104d |  | 124d → 78d |  | baseline start none → 2003-09-22; baseline finish none → 2004-02-23 |
| 296 | Fabricate STE-D FM 2 Preamp Printed Wiring Board |  |  |  |  |  |  | baseline start none → 2003-09-22; baseline finish none → 2003-11-07 |
| 297 | Load STE-D FM 2 Preamp Printed Wiring Board | 2003-12-03 → 2004-02-17 (+76d) | 2003-12-09 → 2004-02-23 (+76d) |  |  | 124d → 78d | 298 → 294SS | baseline start none → 2004-02-17; baseline finish none → 2004-02-23 |
| 298 | Coupon Test STE-D FM 1 & FM 2 Pre-Amp Printed Wiring Boards |  |  |  |  |  |  | baseline start none → 2003-11-10; baseline finish none → 2003-12-02 |
| 299 | **STE-D Shaper Board** |  | 2004-01-16 → 2004-05-13 (+118d) | 30d → 112d | 64% → 78% | 98d → 20d |  | baseline start none → 2003-12-04; baseline finish none → 2004-05-13 |
| 300 | **FM 1** |  | 2004-01-16 → 2004-02-20 (+35d) | 30d → 53d |  | 72d → 28d |  | baseline start none → 2003-12-04; baseline finish none → 2004-02-20 |
| 301 | Fabricate STE-D FM 1 Shaper Printed Wiring Board |  |  |  |  |  |  | baseline start none → 2003-12-04; baseline finish none → 2003-12-17 |
| 302 | Load STE-D FM 1 Shaper Printed Wiring Board | 2004-01-12 → 2004-02-13 (+32d) | 2004-01-16 → 2004-02-20 (+35d) |  |  | 72d → 28d |  | constraint none → start no earlier than 2004-02-13; baseline start none → 2004-02-13; baseline finish none → 2004-02-20 |
| 303 | **FM 2** |  | 2004-01-16 → 2004-05-13 (+118d) | 30d → 112d |  | 98d → 20d |  | baseline start none → 2003-12-04; baseline finish none → 2004-05-13 |
| 304 | Fabricate STE-D FM 2 Shaper Printed Wiring Board |  |  |  |  |  |  | baseline start none → 2003-12-04; baseline finish none → 2003-12-17 |
| 305 | Load STE-D FM 2 Shaper Printed Wiring Board | 2004-01-12 → 2004-05-07 (+116d) | 2004-01-16 → 2004-05-13 (+118d) |  |  | 98d → 20d | 306 → 306, 337 | baseline start none → 2004-05-07; baseline finish none → 2004-05-13 |
| 306 | Coupon Test STE-D FM 1 & FM 2 Shaper Printed Wiring Boards |  | 2004-01-09 A |  | 60% → 100% | 72d → none |  | baseline start none → 2003-12-18; baseline finish none → 2004-01-09 |
| 307 | **STE-D Interface Board** |  | 2004-01-16 → 2004-05-13 (+118d) | 30d → 112d | 64% → 78% | 98d → 20d |  | baseline start none → 2003-12-04; baseline finish none → 2004-05-13 |
| 308 | **FM 1** |  | 2004-01-16 → 2004-02-20 (+35d) | 30d → 53d |  | 72d → 28d |  | baseline start none → 2003-12-04; baseline finish none → 2004-02-20 |
| 309 | Fabricate SWEA / STE-D FM 1 Digital to Analog Converter Printed Wiring Board |  |  |  |  |  |  | baseline start none → 2003-12-04; baseline finish none → 2003-12-17 |
| 310 | Load SWEA / STE-D FM 1 Digital to Analog Converter Printed Wiring Board | 2004-01-12 → 2004-02-13 (+32d) | 2004-01-16 → 2004-02-20 (+35d) |  |  | 72d → 28d | 314 → 302SS | baseline start none → 2004-02-13; baseline finish none → 2004-02-20 |
| 311 | **FM 2** |  | 2004-01-16 → 2004-05-13 (+118d) | 30d → 112d |  | 98d → 20d |  | baseline start none → 2003-12-04; baseline finish none → 2004-05-13 |
| 312 | Fabricate SWEA / STE-D FM 2 Digital to Analog Converter Printed Wiring Board |  |  |  |  |  |  | baseline start none → 2003-12-04; baseline finish none → 2003-12-17 |
| 313 | Load SWEA / STE-D FM 2 Digital to Analog Converter Printed Wiring Board | 2004-01-12 → 2004-05-07 (+116d) | 2004-01-16 → 2004-05-13 (+118d) |  |  | 98d → 20d | 314 → 305SS | baseline start none → 2004-05-07; baseline finish none → 2004-05-13 |
| 314 | Coupon Test STE-D FM 1 & FM 2 D/A Converter Printed Wiring Boards |  | 2004-01-09 A |  | 60% → 100% | 72d → none |  | baseline start none → 2003-12-18; baseline finish none → 2004-01-09 |
| 315 | **STE-U Pre-Amp Board** |  | 2004-01-15 → 2004-02-23 (+39d) | 79d → 104d |  | 109d → 81d |  | baseline start none → 2003-09-22; baseline finish none → 2004-02-23 |
| 316 | **FM 1** |  |  |  |  |  |  | baseline start none → 2003-09-22; baseline finish none → 2004-01-15 |
| 317 | Fabricate STE-U FM 1 Preamp Printed Wiring Board |  |  |  |  |  |  | baseline start none → 2003-09-22; baseline finish none → 2003-11-07 |
| 318 | Load STE-U FM 1 Preamp Printed Wiring Board |  |  |  |  |  |  | baseline start none → 2004-01-12; baseline finish none → 2004-01-15 |
| 319 | **FM 2** |  | 2003-12-09 → 2004-02-23 (+76d) | 54d → 104d |  | 134d → 81d |  | baseline start none → 2003-09-22; baseline finish none → 2004-02-23 |
| 320 | Fabricate STE-U FM 2 Preamp Printed Wiring Board |  |  |  |  |  |  | baseline start none → 2003-09-22; baseline finish none → 2003-11-07 |
| 321 | Load STE-U FM 2 Preamp Printed Wiring Board | 2003-12-03 → 2004-02-17 (+76d) | 2003-12-09 → 2004-02-23 (+76d) |  |  | 134d → 81d |  | constraint none → start no earlier than 2004-02-17; baseline start none → 2004-02-17; baseline finish none → 2004-02-23 |
| 322 | Coupon Test STE-U FM 1 & FM 2 Pre-Amp Printed Wiring Boards |  |  |  |  |  |  | baseline start none → 2003-11-10; baseline finish none → 2003-12-02 |
| 323 | **STE-U Shaper & Interface Board** |  | 2004-01-16 → 2004-02-20 (+35d) | 30d → 53d | 64% → 78% | 108d → 82d |  | baseline start none → 2003-12-04; baseline finish none → 2004-02-20 |
| 324 | **FM 1** |  | 2004-01-16 → 2004-02-20 (+35d) | 30d → 53d |  | 102d → 65d |  | baseline start none → 2003-12-04; baseline finish none → 2004-02-20 |
| 325 | Fabricate STE-U FM 1Shaper & Interface Printed Wiring Board |  |  |  |  |  |  | baseline start none → 2003-12-04; baseline finish none → 2003-12-17 |
| 326 | Load STE-U FM 1 Shaper & Interface Printed Wiring Board | 2004-01-12 → 2004-02-13 (+32d) | 2004-01-16 → 2004-02-20 (+35d) |  |  | 102d → 65d |  | constraint none → start no earlier than 2004-02-13; baseline start none → 2004-02-13; baseline finish none → 2004-02-20 |
| 327 | **FM 2** |  | 2004-01-16 → 2004-02-20 (+35d) | 30d → 53d |  | 108d → 82d |  | baseline start none → 2003-12-04; baseline finish none → 2004-02-20 |
| 328 | Fabricate STE-U FM 2 Shaper & Interface Printed Wiring Board |  |  |  |  |  |  | baseline start none → 2003-12-04; baseline finish none → 2003-12-17 |
| 329 | Load STE-U FM 2 Shaper & Interface Printed Wiring Board | 2004-01-12 → 2004-02-13 (+32d) | 2004-01-16 → 2004-02-20 (+35d) |  |  | 108d → 82d | 330 → 326SS | baseline start none → 2004-02-13; baseline finish none → 2004-02-20 |
| 330 | Coupon Test STE-U FM 1 & FM 2 Shaper & Interface Printed Wiring Boards |  | 2004-01-09 A |  | 60% → 100% | 102d → none |  | baseline start none → 2003-12-18; baseline finish none → 2004-01-09 |
| 331 | **Integration & Test** | 2004-01-20 → 2004-02-23 (+34d) | 2004-08-20 → 2004-08-27 (+7d) | 152d → 134d |  | 21d → 20d |  | baseline start none → 2004-02-23; baseline finish none → 2004-08-27 |
| 332 | **FM 1** | 2004-01-20 → 2004-02-23 (+34d) | 2004-08-20 → 2004-07-30 (-21d) | 152d → 114d |  | 18d → 28d |  | baseline start none → 2004-02-23; baseline finish none → 2004-07-30 |
| 333 | Integrate & Test STE-U FM 1 Interface Boards | 2004-01-20 → 2004-02-23 (+34d) | 2004-01-26 → 2004-02-27 (+32d) |  |  | 102d → 65d |  | baseline start none → 2004-02-23; baseline finish none → 2004-02-27 |
| 334 | Integrate & Test SWEA/STE-D FM 1 Interface Boards | 2004-01-20 → 2004-02-24 (+35d) | 2004-02-17 → 2004-03-22 (+34d) |  |  | 72d → 27d |  | baseline start none → 2004-02-24; baseline finish none → 2004-03-22 |
| 335 | Integrate & Test SWEA/STE-D FM 1 Interface with SWEA/STE-D FM 1 LVPS | 2004-03-22 → 2004-04-16 (+25d) | 2004-04-02 → 2004-04-29 (+27d) |  |  | 49d → 9d |  | baseline start none → 2004-04-16; baseline finish none → 2004-04-29 |
| 336 | Clean/Coat/Stake SWEA/STE-D Interface | 2004-02-18 → 2004-03-23 (+34d) | 2004-03-02 → 2004-04-05 (+34d) |  |  | 72d → 27d |  | baseline start none → 2004-03-23; baseline finish none → 2004-04-05 |
| 337 | Integrate & Test SWEA/STE-D FM 1 Combined | 2004-04-05 → 2004-04-30 (+25d) | 2004-04-09 → 2004-05-06 (+27d) |  |  | 49d → 9d |  | baseline start none → 2004-04-30; baseline finish none → 2004-05-06 |
| 338 | Calibrate SWEA/STE FM 1 | 2004-04-12 → 2004-05-07 (+25d) | 2004-05-07 → 2004-06-04 (+28d) |  |  | 49d → 9d |  | baseline start none → 2004-05-07; baseline finish none → 2004-06-04 |
| 339 | SWEA/STE FM 1 Vibration | 2004-05-10 → 2004-06-07 (+28d) | 2004-05-14 → 2004-06-11 (+28d) |  |  | 49d → 9d |  | baseline start none → 2004-06-07; baseline finish none → 2004-06-11 |
| 340 | SWEA/STE-D FM 1 Thermal Vac/Thermal Balance/Bake Out | 2004-08-03 → 2004-07-13 (-21d) | 2004-08-20 → 2004-07-30 (-21d) |  |  | 18d → 37d |  | was named SWEA/STE-D FM 1 Thermal Vac/Thermal Balance; baseline start none → 2004-07-13; baseline finish none → 2004-07-30 |
| 341 | **FM 2** | 2004-01-20 → 2004-02-24 (+35d) | 2004-07-13 → 2004-08-27 (+45d) | 124d → 133d |  | 49d → 20d |  | baseline start none → 2004-02-24; baseline finish none → 2004-08-27 |
| 342 | Integrate & Test STE-U FM 2 Interface Boards | 2004-01-20 → 2004-02-24 (+35d) | 2004-01-26 → 2004-03-01 (+35d) |  |  | 108d → 81d |  | baseline start none → 2004-02-24; baseline finish none → 2004-03-01 |
| 343 | Integrate & Test SWEA/STE-D FM 2 Interface Boards | 2004-01-20 → 2004-05-14 (+115d) | 2004-02-17 → 2004-06-11 (+115d) |  |  | 98d → 20d |  | baseline start none → 2004-05-14; baseline finish none → 2004-06-11 |
| 344 | Integrate & Test SWEA/STE-D FM 2 Interface with SWEA/STE-D FM 2 LVPS | 2004-04-27 → 2004-06-14 (+48d) | 2004-05-10 → 2004-06-25 (+46d) |  |  | 49d → 20d |  | baseline start none → 2004-06-14; baseline finish none → 2004-06-25 |
| 345 | Integrate & Test SWEA/STE-D FM 2 Combined | 2004-05-11 → 2004-06-28 (+48d) | 2004-05-24 → 2004-07-09 (+46d) |  |  | 49d → 20d |  | baseline start none → 2004-06-28; baseline finish none → 2004-07-09 |
| 346 | Calibrate SWEA/STE FM 2 | 2004-05-25 → 2004-07-12 (+48d) | 2004-06-22 → 2004-08-06 (+45d) |  |  | 49d → 20d |  | baseline start none → 2004-07-12; baseline finish none → 2004-08-06 |
| 347 | SWEA/STE FM 2 Vibration | 2004-06-23 → 2004-08-09 (+47d) | 2004-06-29 → 2004-08-13 (+45d) |  |  | 49d → 20d |  | baseline start none → 2004-08-09; baseline finish none → 2004-08-13 |
| 348 | SWEA/STE-D FM 2 Thermal Vac & bake Out | 2004-06-30 → 2004-08-16 (+47d) | 2004-07-13 → 2004-08-27 (+45d) |  |  | 49d → 20d |  | was named SWEA/STE-D FM 2 Thermal Vac; baseline start none → 2004-08-16; baseline finish none → 2004-08-27 |
| 349 | **Boom Suite I&T - UCB** | 2004-04-09 → 2004-04-21 (+12d) | 2004-09-13 → 2004-09-28 (+15d) | 110d → 113d |  | 32d → 19d |  | baseline start none → 2004-04-21; baseline finish none → 2004-09-28 |
| 350 | **FM 1** | 2004-04-09 → 2004-04-21 (+12d) | 2004-09-13 → 2004-08-13 (-31d) | 110d → 82d |  | 18d → 19d |  | baseline start none → 2004-04-21; baseline finish none → 2004-08-13 |
| 351 | FM 1 Boom/MAG/STE-U I&T | 2004-04-09 → 2004-04-21 (+12d) | 2004-04-14 → 2004-04-26 (+12d) |  |  | 48d → 19d |  | baseline start none → 2004-04-21; baseline finish none → 2004-04-26 |
| 352 | FM 1 Boom/SWEA/STE/MAG I&T | 2004-05-18 → 2004-06-14 (+27d) | 2004-05-19 → 2004-06-15 (+27d) |  |  | 48d → 9d |  | baseline start none → 2004-06-14; baseline finish none → 2004-06-15 |
| 353 | FM 1 Integrated Boom/IDPU I&T | 2004-07-01 → 2004-06-16 (-15d) | 2004-07-06 → 2004-06-21 (-15d) |  |  | 19d → 9d | 352, 186, Rework SEP FM 1 - IDPU FM 1 issues and retest → 352, 186, 161 | baseline start none → 2004-06-16; baseline finish none → 2004-06-21 |
| 354 | Final BOOM Suite FM 1 I & T | 2004-08-30 → 2004-08-02 (-28d) | 2004-09-13 → 2004-08-13 (-31d) |  |  | 18d → 37d | BOOM Suite FM 1 Bakeout, IDPU FM 1 Bakeout → 353, 340 | baseline start none → 2004-08-02; baseline finish none → 2004-08-13 |
| 355 | **FM 2** | 2004-04-12 → 2004-05-11 (+29d) | 2004-08-31 → 2004-09-28 (+28d) | 101d → 99d |  | 40d → 20d |  | baseline start none → 2004-05-11; baseline finish none → 2004-09-28 |
| 356 | FM 2 Boom/MAG/STE-U I&T | 2004-04-12 → 2004-05-11 (+29d) | 2004-04-15 → 2004-05-14 (+29d) |  |  | 88d → 71d |  | baseline start none → 2004-05-11; baseline finish none → 2004-05-14 |
| 357 | FM 2 Boom/SWEA/STE/MAG I&T | 2004-07-14 → 2004-08-30 (+47d) | 2004-07-15 → 2004-08-31 (+47d) |  |  | 49d → 20d |  | baseline start none → 2004-08-30; baseline finish none → 2004-08-31 |
| 358 | FM 2 Integrated Boom/IDPU I&T | 2004-07-29 → 2004-09-01 (+34d) | 2004-08-03 → 2004-09-07 (+35d) |  |  | 40d → 20d | 357, Rework SEP FM 2 - IDPU FM 2 issues and retest, 187 → 357, 187, 761 | baseline start none → 2004-09-01; baseline finish none → 2004-09-07 |

| ID | Task | Start | Finish | Duration | Complete | Total float | Predecessors | Other |
| --- | --- | --- | --- | --- | --- | --- | --- | --- |
| 359 | Boom Suite FM 2 EMC | 2004-08-04 → 2004-09-08 (+35d) | 2004-08-10 → 2004-09-14 (+35d) |  |  | 40d → 20d |  | baseline start none → 2004-09-08; baseline finish none → 2004-09-14 |
| 360 | Final BOOM Suite FM 2 I & T | 2004-08-18 → 2004-09-15 (+28d) | 2004-08-31 → 2004-09-28 (+28d) |  |  | 40d → 20d | BOOM Suite FM 2 Bakeout, IDPU FM 2 Bakeout → 359 | baseline start none → 2004-09-15; baseline finish none → 2004-09-28 |
| 361 | **SEP Suite - CIT** |  | 2004-11-26 → 2004-10-21 (-36d) | 376d → 352d | 31% → 42% | 0d → 279d |  | baseline start none → 2003-06-02; baseline finish none → 2004-10-21 |
| 362 | **SEP Mechanical - Sandy Shuman (GSFC)** | 2004-01-22 → 2004-01-27 A (+5d) | 2004-05-17 → 2004-06-02 (+16d) | 82d → 90d | 0% → 1% | 5d → 37d |  | baseline start none → 2004-01-27; baseline finish none → 2004-06-02 |
| 363 | **SIT Electronics Enclosure (Priority 1)** | 2004-01-22 → 2004-02-09 (+18d) | 2004-02-20 → 2004-03-16 (+25d) | 21d → 26d |  | 5d → 15d |  | baseline start none → 2004-02-09; baseline finish none → 2004-03-16 |
| 364 | Complete Design/Drawings for SIT Enclosure | 2004-01-22 → 2004-02-09 (+18d) | 2004-01-28 → 2004-02-23 (+26d) | 5d → 10d |  | 5d → 15d |  | constraint start no earlier than 2004-01-22 → start no earlier than 2004-02-09; baseline start none → 2004-02-09; baseline finish none → 2004-02-23 |
| 365 | Fabrication of SIT Enclosure | 2004-01-29 → 2004-02-24 (+26d) | 2004-02-11 → 2004-03-08 (+26d) |  |  | 53d → 16d |  | baseline start none → 2004-02-24; baseline finish none → 2004-03-08 |
| 366 | Inspection and Final Assembly of SIT Enclosure | 2004-02-12 → 2004-03-09 (+26d) | 2004-02-19 → 2004-03-15 (+25d) |  |  | 53d → 16d |  | baseline start none → 2004-03-09; baseline finish none → 2004-03-15 |
| 367 | Deliver SIT Enclosure to UMD | 2004-02-20 → 2004-03-16 (+25d) | 2004-02-20 → 2004-03-16 (+25d) |  |  | 53d → 16d |  | baseline start none → 2004-03-16; baseline finish none → 2004-03-16 |
| 368 | **SEP FM 1 & FM 2 LVPS Boxes (Priority 2)** | 2004-01-29 → 2004-02-09 (+11d) | 2004-03-02 → 2004-03-11 (+9d) |  |  | 5d → 15d |  | baseline start none → 2004-02-09; baseline finish none → 2004-03-11 |
| 369 | Complete Design/Drawings for SEP LVPS Boxes | 2004-01-29 → 2004-02-09 (+11d) | 2004-02-04 → 2004-02-13 (+9d) |  |  | 5d → 15d | 364 → 364SS | baseline start none → 2004-02-09; baseline finish none → 2004-02-13 |
| 370 | Fabrication of SEP LVPS Boxes | 2004-02-05 → 2004-02-17 (+12d) | 2004-02-19 → 2004-03-01 (+11d) |  |  | 62d → 43d |  | baseline start none → 2004-02-17; baseline finish none → 2004-03-01 |
| 371 | Inspection and Final Assembly of SEP LVPS Boxes | 2004-02-20 → 2004-03-02 (+11d) | 2004-02-26 → 2004-03-08 (+11d) |  |  | 62d → 43d |  | baseline start none → 2004-03-02; baseline finish none → 2004-03-08 |
| 372 | Deliver SEP LVPS Boxes to UCB | 2004-02-27 → 2004-03-09 (+11d) | 2004-03-02 → 2004-03-11 (+9d) |  |  | 62d → 43d |  | baseline start none → 2004-03-09; baseline finish none → 2004-03-11 |
| 374 | Complete Design/Drawings for SEP Enclosure | 2004-02-25 → 2004-02-17 (-8d) | 2004-03-12 → 2004-03-04 (-8d) |  |  | 5d → 15d | 379 → 369 | baseline start none → 2004-02-17; baseline finish none → 2004-03-04 |
| 375 | Fabrication of SEP Enclosure | 2004-03-15 → 2004-03-05 (-10d) | 2004-03-26 → 2004-03-18 (-8d) |  |  | 47d → 58d |  | baseline start none → 2004-03-05; baseline finish none → 2004-03-18 |
| 376 | Inspection and Final Assembly of SEP Enclosure | 2004-03-29 → 2004-03-19 (-10d) | 2004-04-02 → 2004-03-25 (-8d) |  |  | 47d → 58d |  | baseline start none → 2004-03-19; baseline finish none → 2004-03-25 |
| 377 | Deliver SEP Enclosure to CIT | 2004-04-05 → 2004-03-26 (-10d) | 2004-04-07 → 2004-03-30 (-8d) |  |  | 47d → 58d |  | baseline start none → 2004-03-26; baseline finish none → 2004-03-30 |
| 378 | **SEP Central Bias Supply Shields (Priority 4)** | 2004-02-18 → 2004-03-05 (+16d) | 2004-03-16 → 2004-04-01 (+16d) |  |  | 5d → 15d |  | baseline start none → 2004-03-05; baseline finish none → 2004-04-01 |
| 379 | Complete Design/Drawings for Bias Supply Shields | 2004-02-18 → 2004-03-05 (+16d) | 2004-02-24 → 2004-03-11 (+16d) |  |  | 5d → 15d | 383 → 374 | baseline start none → 2004-03-05; baseline finish none → 2004-03-11 |
| 380 | Fabrication of Bias Supply Shields | 2004-02-25 → 2004-03-12 (+16d) | 2004-03-09 → 2004-03-25 (+16d) |  |  | 51d → 15d |  | baseline start none → 2004-03-12; baseline finish none → 2004-03-25 |
| 381 | Inspection and Delivery (to CIT) of Bias Supply Shields | 2004-03-10 → 2004-03-26 (+16d) | 2004-03-16 → 2004-04-01 (+16d) |  |  | 51d → 15d |  | baseline start none → 2004-03-26; baseline finish none → 2004-04-01 |
| 383 | Complete Design/Drawings for LET Telescope | 2004-02-05 → 2004-03-12 (+36d) | 2004-02-17 → 2004-03-23 (+35d) |  |  | 5d → 18d | 369 → 379 | baseline start none → 2004-03-12; baseline finish none → 2004-03-23 |
| 384 | Fabrication of LET Telescope | 2004-02-18 → 2004-03-24 (+35d) | 2004-03-02 → 2004-04-06 (+35d) |  |  | 47d → 31d |  | baseline start none → 2004-03-24; baseline finish none → 2004-04-06 |
| 385 | Inspection and Final Assembly of LET Telescope | 2004-03-03 → 2004-04-07 (+35d) | 2004-03-09 → 2004-04-13 (+35d) |  |  | 47d → 31d |  | baseline start none → 2004-04-07; baseline finish none → 2004-04-13 |
| 386 | Deliver LET Telescope to CIT | 2004-03-10 → 2004-04-14 (+35d) | 2004-03-12 → 2004-04-16 (+35d) |  |  | 47d → 31d |  | baseline start none → 2004-04-14; baseline finish none → 2004-04-16 |
| 387 | **HET Electronics Enclosure (Priority 6)** | 2004-03-15 → 2004-03-24 (+9d) | 2004-04-14 → 2004-04-23 (+9d) |  |  | 5d → 18d |  | baseline start none → 2004-03-24; baseline finish none → 2004-04-23 |
| 388 | Complete Design/Drawings for HET Enclosure | 2004-03-15 → 2004-03-24 (+9d) | 2004-03-24 → 2004-04-02 (+9d) |  |  | 5d → 18d | 374 → 383 | baseline start none → 2004-03-24; baseline finish none → 2004-04-02 |
| 389 | Fabrication of HET Enclosure | 2004-03-25 → 2004-04-05 (+11d) | 2004-04-07 → 2004-04-16 (+9d) |  |  | 23d → 18d |  | baseline start none → 2004-04-05; baseline finish none → 2004-04-16 |
| 390 | Inspection and Final Assembly of HET Enclosure | 2004-04-08 → 2004-04-19 (+11d) | 2004-04-14 → 2004-04-23 (+9d) |  |  | 23d → 18d |  | baseline start none → 2004-04-19; baseline finish none → 2004-04-23 |
| 391 | Deliver HET Enclosure (stays at GSFC) | 2004-04-14 → 2004-04-23 (+9d) | 2004-04-14 → 2004-04-23 (+9d) |  |  | 23d → 18d |  | baseline start none → 2004-04-23; baseline finish none → 2004-04-23 |
| 394 | Fabrication of HET Telescope | 2004-04-27 → 2004-04-01 (-26d) | 2004-05-10 → 2004-04-14 (-26d) |  |  | 5d → 25d | Complete Design/Drawings for HET Telescope → 393 | baseline start none → 2004-04-01; baseline finish none → 2004-04-14 |
| 395 | Inspection and Final Assembly of HET Telescope | 2004-05-11 → 2004-04-26 (-15d) | 2004-05-17 → 2004-04-30 (-17d) |  |  | 5d → 18d |  | baseline start none → 2004-04-26; baseline finish none → 2004-04-30 |
| 396 | Deliver HET Telescope (stays at GSFC) | 2004-05-17 → 2004-04-30 (-17d) | 2004-05-17 → 2004-04-30 (-17d) |  |  | 5d → 18d |  | baseline start none → 2004-04-30; baseline finish none → 2004-04-30 |
| 397 | **SIT Telescope (Priority 8)** | 2004-03-25 → 2004-04-01 (+7d) | 2004-05-11 → 2004-05-18 (+7d) |  |  | 5d → 16d |  | was named SIT Telescope (Priority 7); baseline start none → 2004-04-01; baseline finish none → 2004-05-18 |
| 398 | Complete Design/Drawings for SIT Telescope | 2004-03-25 → 2004-04-01 (+7d) | 2004-04-19 → 2004-04-26 (+7d) |  |  | 5d → 16d | 388 → 393 | baseline start none → 2004-04-01; baseline finish none → 2004-04-26 |
| 399 | Fabrication of SIT Telescope | 2004-04-20 → 2004-04-27 (+7d) | 2004-05-03 → 2004-05-10 (+7d) |  |  | 9d → 16d |  | baseline start none → 2004-04-27; baseline finish none → 2004-05-10 |
| 400 | Inspection and Final Assembly of SIT Telescope | 2004-05-04 → 2004-05-11 (+7d) | 2004-05-10 → 2004-05-17 (+7d) |  |  | 9d → 16d |  | baseline start none → 2004-05-11; baseline finish none → 2004-05-17 |
| 401 | Deliver SIT Telescope to UMD | 2004-05-11 → 2004-05-18 (+7d) | 2004-05-11 → 2004-05-18 (+7d) |  |  | 9d → 16d |  | baseline start none → 2004-05-18; baseline finish none → 2004-05-18 |
| 414 | **SEP Central - CIT** |  | 2004-04-14 → 2004-06-03 (+50d) | 176d → 211d | 38% → 31% | 68d → 26d |  | baseline start none → 2003-08-01; baseline finish none → 2004-06-03 |
| 415 | **Deliveries** | 2004-03-02 → 2004-04-14 (+43d) | 2004-04-14 → 2004-06-03 (+50d) | 31d → 35d |  | 68d → 26d |  | baseline start none → 2004-04-14; baseline finish none → 2004-06-03 |
| 416 | Deliver all SEP Cen FM 1 Boards to SEP I&T (stays at CIT) | 2004-04-14 → 2004-05-10 (+26d) | 2004-04-14 → 2004-05-10 (+26d) |  |  | 42d → 29d | FM 1 SEP Central Logic Board Mass properties/photo → 440 | was named Deliver SEP Cen FM 1 Logic Board (stays at CIT for SEP Suite I&T); baseline start none → 2004-05-10; baseline finish none → 2004-05-10 |
| 417 | Deliver all SEP Cen FM 2 Boards & FM 2 LVPS to SEP I&T (stays at CIT) | 2004-04-14 → 2004-05-10 (+26d) | 2004-04-14 → 2004-05-10 (+26d) |  |  | 68d → 43d | FM 2 SEP Central Logic Board Mass properties/photo → 440 | was named Deliver SEP Cen FM 2 Logic Board (stays at CIT for SEP Suite I&T); baseline start none → 2004-05-10; baseline finish none → 2004-05-10 |
| 419 | Final SEP Central Flight Software Complete | 2004-03-02 → 2004-06-03 (+93d) | 2004-03-02 → 2004-06-03 (+93d) |  |  | 73d → 26d |  | was named Deliver Final SEP Central Flight Software to SEP I&T; baseline start none → 2004-06-03; baseline finish none → 2004-06-03 |
| 420 | **Logic Board** | 2004-01-09 → 2004-02-13 (+35d) | 2004-04-14 → 2004-03-26 (-19d) | 67d → 30d |  | 68d → 29d |  | baseline start none → 2004-02-13; baseline finish none → 2004-03-26 |
| 421 | **Assembly** | 2004-01-09 → 2004-02-13 (+35d) | 2004-02-17 → 2004-02-27 (+10d) | 26d → 10d |  | 86d → 29d |  | baseline start none → 2004-02-13; baseline finish none → 2004-02-27 |
| 422 | Assemble FM 1 SEP Central Logic board | 2004-01-09 → 2004-02-13 (+35d) | 2004-01-15 → 2004-02-27 (+43d) | 5d → 10d |  | 86d → 29d |  | constraint start no earlier than 2004-01-09 → start no earlier than 2004-02-13; baseline start none → 2004-02-13; baseline finish none → 2004-02-27 |
| 423 | Assemble FM 2 SEP Central Logic board | 2004-01-16 → 2004-02-13 (+28d) | 2004-01-23 → 2004-02-27 (+35d) | 5d → 10d |  | 107d → 29d | 422 → 422SS | baseline start none → 2004-02-13; baseline finish none → 2004-02-27 |
| 424 | **Test** | 2004-01-20 → 2004-03-01 (+41d) | 2004-04-14 → 2004-03-26 (-19d) | 61d → 20d |  | 68d → 29d |  | baseline start none → 2004-03-01; baseline finish none → 2004-03-26 |
| 425 | Test FM 1 SEP Central Logic board (initial) | 2004-01-20 → 2004-03-01 (+41d) | 2004-01-26 → 2004-03-26 (+60d) | 5d → 20d |  | 86d → 29d | Post-assembly QA inspection of FM 1 SEP Central Logic Board → 422 | baseline start none → 2004-03-01; baseline finish none → 2004-03-26 |
| 426 | Test FM 2 SEP Central Logic board (initial) | 2004-01-27 → 2004-03-01 (+34d) | 2004-02-02 → 2004-03-26 (+53d) | 5d → 20d |  | 107d → 29d | Post-assembly QA inspection of FM 2 SEP Central Logic Board → 423 | baseline start none → 2004-03-01; baseline finish none → 2004-03-26 |
| 427 | **Analog/Post-Reg Board** | 2003-12-04 A → 2004-01-27 A (+54d) | 2004-04-09 → 2004-01-27 A (-73d) | 88d → 0d | 24% → 100% | 71d → none |  | baseline start none → 2004-01-27; baseline finish none → 2004-01-27 |
| 430 | **SEP Solid State Detector Bias Supply Board** | 2004-01-12 → 2004-01-20 A (+8d) | 2004-04-09 → 2004-04-15 (+6d) | 63d → 62d | 0% → 18% | 71d → 15d |  | baseline start none → 2004-01-20; baseline finish none → 2004-04-15 |
| 431 | **Assembly & Initial Test** | 2004-01-12 → 2004-01-20 A (+8d) | 2004-03-26 → 2004-03-16 (-10d) | 53d → 40d | 0% → 23% | 74d → 27d |  | was named Assembly; baseline start none → 2004-01-20; baseline finish none → 2004-03-16 |
| 432 | Assemble and Initial Test FM 1 SSD Bias Supply Board | 2004-01-12 → 2004-01-20 A (+8d) | 2004-01-26 → 2004-03-16 (+50d) | 10d → 40d | 0% → 23% | 86d → 27d |  | was named Assemble flight Solid State Detector Bias Supply Printed Circuit Board 1; constraint start no earlier than 2004-01-12 → start no earlier than 2004-01-20; baseline start none → 2004-01-20; baseline finish none → 2004-03-16 |
| 433 | Assemble and Initial Test FM 2 SSD Bias Supply Board | 2004-01-27 → 2004-01-20 A (-7d) | 2004-02-09 → 2004-03-16 (+36d) | 10d → 40d | 0% → 23% | 102d → 27d | 432 → 432SS | was named Assemble flight Solid State Detector Bias Supply Printed Circuit Board 2; baseline start none → 2004-01-20; baseline finish none → 2004-03-16 |
| 434 | **Final Test** | 2004-03-17 → 2004-04-02 (+16d) | 2004-04-09 → 2004-04-15 (+6d) | 18d → 10d |  | 51d → 15d |  | was named Test; baseline start none → 2004-04-02; baseline finish none → 2004-04-15 |
| 435 | Final Test FM 1 SSD Bias Supply Board | 2004-03-17 → 2004-04-02 (+16d) | 2004-03-19 → 2004-04-15 (+27d) | 3d → 10d |  | 51d → 15d |  | was named Test Solid State Detector Bias Supply flight board 1 (initial); baseline start none → 2004-04-02; baseline finish none → 2004-04-15 |
| 436 | Final Test FM 2 SSD Bias Supply Board | 2004-03-22 → 2004-04-02 (+11d) | 2004-03-24 → 2004-04-15 (+22d) | 3d → 10d |  | 74d → 15d | 433, 381, 435 → 433, 381 | was named Test Solid State Detector Bias Supply flight board 2 (initial); baseline start none → 2004-04-02; baseline finish none → 2004-04-15 |
| 441 | **Flight Software** |  | 2004-03-02 → 2004-06-03 (+93d) | 145d → 211d | 65% → 49% | 73d → 26d |  | baseline start none → 2003-08-01; baseline finish none → 2004-06-03 |
| 442 | SEP Central Build 3 |  | 2004-01-02 → 2004-04-14 (+103d) | 105d → 176d | 90% → 59% | 73d → 26d |  | baseline start none → 2003-08-01; baseline finish none → 2004-04-14 |
| 443 | Final Flight S/W Build | 2004-01-05 → 2004-04-15 (+101d) | 2004-03-02 → 2004-06-03 (+93d) | 40d → 35d |  | 73d → 26d |  | baseline start none → 2004-04-15; baseline finish none → 2004-06-03 |
| 444 | **HET - GSFC** | 2003-10-01 → 2004-01-06 A (+97d) | 2004-07-15 → 2004-06-23 (-22d) | 199d → 119d | 0% → 19% | 82d → 363d |  | baseline start none → 2004-01-06; baseline finish none → 2004-06-23 |
| 445 | **Deliveries** | 2003-10-01 → 2004-04-30 (+212d) | 2004-07-15 → 2004-06-23 (-22d) | 199d → 38d |  | 92d → 18d |  | baseline start none → 2004-04-30; baseline finish none → 2004-06-23 |
| 446 | Deliver HET FM 1 (to CIT for SEP Suite I&T) | 2004-06-16 → 2004-06-01 (-15d) | 2004-06-17 → 2004-06-02 (-15d) |  |  |  | 487 → 487, 406 | baseline start none → 2004-06-01; baseline finish none → 2004-06-02 |
| 447 | Deliver HET FM 2 (to CIT for SEP Suite I&T) | 2004-07-14 → 2004-06-22 (-22d) | 2004-07-15 → 2004-06-23 (-22d) |  |  | 5d → 18d | 490 → 490, 406 | baseline start none → 2004-06-22; baseline finish none → 2004-06-23 |
| 448 | Deliver Final HET Flight Software to SEP I&T | 2003-10-01 → 2004-04-30 (+212d) | 2003-10-02 → 2004-05-03 (+214d) |  |  | 289d → 40d | none → 483 | baseline start none → 2004-04-30; baseline finish none → 2004-05-03 |
| 449 | **Detectors** | 2004-01-06 A |  |  | 0% → 34% | 38d → 422d |  | baseline start none → 2004-01-06; baseline finish none → 2004-03-31 |
| 450 | Receive & Inspect HET Flight Detectors | 2004-01-06 A |  |  | 0% → 45% | 38d → 442d |  | baseline start none → 2004-01-06; baseline finish none → 2004-03-03 |
| 451 | **Detector Testing** | 2004-01-06 A |  |  | 0% → 30% | 38d → 422d |  | baseline start none → 2004-01-06; baseline finish none → 2004-03-31 |

| ID | Task | Start | Finish | Duration | Complete | Total float | Predecessors | Other |
| --- | --- | --- | --- | --- | --- | --- | --- | --- |
| 452 | Capacitance, Current, Depletion, Alpha Resolution Testing | 2004-01-06 A |  |  | 0% → 30% | 38d → 422d |  | was named Capacitance, Current, Depletion, Alpha Resin Testing; baseline start none → 2004-01-06; baseline finish none → 2004-03-31 |
| 453 | Life Test HET Detectors | 2004-01-06 A |  |  | 0% → 30% | 38d → 40d |  | baseline start none → 2004-01-06; baseline finish none → 2004-03-31 |
| 454 | **Electronics Board** | 2004-01-22 A | 2004-05-17 → 2004-05-13 (-4d) | 82d → 80d | 0% → 9% | 7d → 24d |  | baseline start none → 2004-01-22; baseline finish none → 2004-05-13 |
| 455 | **Assembly** | 2004-01-22 A | 2004-03-24 → 2004-03-12 (-12d) | 44d → 36d | 0% → 50% | 7d → 30d |  | baseline start none → 2004-01-22; baseline finish none → 2004-03-12 |
| 456 | Install Socket on HET Electronics FM 1 Board for ETU ACTEL | 2004-01-22 A | 2004-01-22 A |  | 0% → 100% | 7d → none |  | baseline start none → 2004-01-22; baseline finish none → 2004-01-22 |
| 457 | Complete Population of HET Electronics FM 1 Board (ETU ACTEL) | 2004-01-23 A | 2004-01-23 A |  | 0% → 100% | 7d → none |  | was named Complete Population of HET Electronics FM 1 Board; baseline start none → 2004-01-23; baseline finish none → 2004-01-23 |
| 458 | Complete Population of HET Electronics FM 2 Board (Flight ACTEL) |  | 2004-03-24 → 2004-03-12 (-12d) | 10d → 2d |  | 7d → 30d |  | was named Populate HET Electronics FM 2 Board; baseline start none → 2004-03-11; baseline finish none → 2004-03-12 |
| 459 | **Test** | 2004-01-26 A | 2004-05-17 → 2004-05-13 (-4d) | 80d → 78d | 0% → 6% | 7d → 24d |  | baseline start none → 2004-01-26; baseline finish none → 2004-05-13 |
| 460 | **FM 1** | 2004-01-26 A | 2004-05-13 → 2004-03-22 (-52d) | 78d → 40d | 0% → 13% | 7d → 24d |  | baseline start none → 2004-01-26; baseline finish none → 2004-03-22 |
| 461 | Test HET FM 1 Electronics Board w/ETU ACTEL | 2004-01-26 A |  |  | 0% → 25% | 7d → 24d |  | baseline start none → 2004-01-26; baseline finish none → 2004-02-23 |
| 462 | Remove ETU ACTEL and socket from HET FM 1 Electronics Board |  |  |  |  | 7d → 24d |  | baseline start none → 2004-02-24; baseline finish none → 2004-02-24 |
| 463 | Install Flight ACTEL on HET FM 1 Electronics Board |  |  |  |  | 7d → 24d |  | baseline start none → 2004-02-25; baseline finish none → 2004-02-25 |
| 464 | Retest HET FM 1 Electronics Board w/Flight ACTEL |  |  |  |  | 7d → 24d | 463, 499 → 463 | baseline start none → 2004-02-26; baseline finish none → 2004-03-10 |
| 465 | Conformal Coat HET FM 1 Electronics Board |  |  |  |  | 45d → 24d |  | baseline start none → 2004-03-11; baseline finish none → 2004-03-12 |
| 466 | Retest Conformal Coated HET FM 1 Electronics Board | 2004-05-06 → 2004-03-15 (-52d) | 2004-05-07 → 2004-03-16 (-52d) |  |  | 7d → 24d | 465, 470 → 465 | baseline start none → 2004-03-15; baseline finish none → 2004-03-16 |
| 467 | Bakeout HET FM 1 Electronics Board | 2004-05-10 → 2004-03-17 (-54d) | 2004-05-11 → 2004-03-18 (-54d) |  |  | 7d → 24d |  | baseline start none → 2004-03-17; baseline finish none → 2004-03-18 |
| 468 | Retest Bakedout HET FM 1 Electronics Board | 2004-05-12 → 2004-03-19 (-54d) | 2004-05-13 → 2004-03-22 (-52d) |  |  | 7d → 24d | 467, 472 → 467 | baseline start none → 2004-03-19; baseline finish none → 2004-03-22 |
| 469 | **FM 2** | 2004-03-25 → 2004-03-23 (-2d) | 2004-05-17 → 2004-05-13 (-4d) |  |  | 7d → 24d |  | baseline start none → 2004-03-23; baseline finish none → 2004-05-13 |
| 470 | Test HET FM 2 Electronics Board | 2004-03-25 → 2004-03-23 (-2d) | 2004-05-05 → 2004-05-03 (-2d) |  |  | 7d → 24d | 458, 461 → 458, 461, 468 | baseline start none → 2004-03-23; baseline finish none → 2004-05-03 |
| 471 | Conformal Coat HET FM 2 Electronics Board | 2004-05-06 → 2004-05-04 (-2d) | 2004-05-07 → 2004-05-05 (-2d) |  |  | 7d → 24d |  | baseline start none → 2004-05-04; baseline finish none → 2004-05-05 |
| 472 | Retest Conformal Coated HET FM 2 Electronics Board | 2004-05-10 → 2004-05-06 (-4d) | 2004-05-11 → 2004-05-07 (-4d) |  |  | 7d → 24d |  | baseline start none → 2004-05-06; baseline finish none → 2004-05-07 |
| 473 | Bakeout HET FM 2 Electronics Board | 2004-05-12 → 2004-05-10 (-2d) | 2004-05-13 → 2004-05-11 (-2d) |  |  | 20d → 24d |  | baseline start none → 2004-05-10; baseline finish none → 2004-05-11 |
| 474 | Retest Bakedout HET FM 2 Electronics Board | 2004-05-14 → 2004-05-12 (-2d) | 2004-05-17 → 2004-05-13 (-4d) |  |  | 20d → 24d |  | baseline start none → 2004-05-12; baseline finish none → 2004-05-13 |
| 475 | **Flight Software** | 2004-01-22 A |  |  | 0% → 10% | 17d → 19d |  | baseline start none → 2004-01-22; baseline finish none → 2004-04-29 |
| 476 | **Design** | 2004-01-22 A |  |  | 0% → 70% | 17d → 19d |  | baseline start none → 2004-01-22; baseline finish none → 2004-02-04 |
| 477 | Complete Definition of HET PH Event Processing | 2004-01-22 A |  |  | 0% → 70% | 17d → 19d |  | baseline start none → 2004-01-22; baseline finish none → 2004-02-04 |
| 478 | **Coding** |  |  |  |  | 17d → 19d |  | baseline start none → 2004-02-05; baseline finish none → 2004-03-04 |
| 479 | Code HET PH Event Processing Update for Flight |  |  |  |  | 17d → 19d |  | baseline start none → 2004-02-05; baseline finish none → 2004-02-19 |
| 480 | Code HET Telemetry Formatting Update for Flight |  |  |  |  | 17d → 19d |  | baseline start none → 2004-02-20; baseline finish none → 2004-03-04 |
| 481 | **Test** |  |  |  |  | 17d → 19d |  | baseline start none → 2004-03-05; baseline finish none → 2004-04-29 |
| 482 | Test Integrated HET S/W with Simulated Data |  |  |  |  | 17d → 19d |  | baseline start none → 2004-03-05; baseline finish none → 2004-03-25 |
| 483 | Verify HET On-Board Software |  |  |  |  | 17d → 19d |  | baseline start none → 2004-03-26; baseline finish none → 2004-04-29 |
| 484 | **Integration & Test** | 2004-05-18 → 2004-05-03 (-15d) | 2004-07-13 → 2004-06-21 (-22d) | 40d → 35d |  | 5d → 18d |  | baseline start none → 2004-05-03; baseline finish none → 2004-06-21 |
| 485 | **FM 1** | 2004-05-18 → 2004-05-03 (-15d) | 2004-06-15 → 2004-05-28 (-18d) |  |  | 5d → 18d |  | baseline start none → 2004-05-03; baseline finish none → 2004-05-28 |
| 486 | Integrate HET FM 1 Electronics Telescope (Ahead) | 2004-05-18 → 2004-05-03 (-15d) | 2004-05-24 → 2004-05-07 (-17d) |  |  | 5d → 18d |  | baseline start none → 2004-05-03; baseline finish none → 2004-05-07 |
| 487 | Test HET FM 1 Telescope (Ahead) | 2004-05-25 → 2004-05-10 (-15d) | 2004-06-15 → 2004-05-28 (-18d) |  |  | 5d → 18d |  | baseline start none → 2004-05-10; baseline finish none → 2004-05-28 |
| 488 | **FM 2** | 2004-05-25 → 2004-05-14 (-11d) | 2004-07-13 → 2004-06-21 (-22d) | 35d → 26d |  | 5d → 18d |  | baseline start none → 2004-05-14; baseline finish none → 2004-06-21 |
| 489 | Integrate HET FM 2 Electronics Telescope (Behind) | 2004-05-25 → 2004-05-14 (-11d) | 2004-06-01 → 2004-05-20 (-12d) |  |  | 15d → 24d |  | baseline start none → 2004-05-14; baseline finish none → 2004-05-20 |
| 490 | Test HET FM 2 Telescope (Behind) | 2004-06-16 → 2004-06-01 (-15d) | 2004-07-13 → 2004-06-21 (-22d) | 20d → 15d |  | 5d → 18d |  | baseline start none → 2004-06-01; baseline finish none → 2004-06-21 |
| 491 | **LET - CIT** |  | 2004-05-07 → 2004-06-08 (+32d) | 207d → 228d | 51% → 66% | 53d → 29d |  | baseline start none → 2003-07-14; baseline finish none → 2004-06-08 |
| 492 | **Deliveries** | 2004-01-15 → 2004-05-04 (+110d) | 2004-05-07 → 2004-06-08 (+32d) | 79d → 24d |  | 53d → 29d |  | baseline start none → 2004-05-04; baseline finish none → 2004-06-08 |
| 493 | Deliver LET FM 1 (stays at CIT for SEP I&T) | 2004-05-07 → 2004-06-08 (+32d) | 2004-05-07 → 2004-06-08 (+32d) |  |  | 47d → 15d | LET FM 1 Detector Board Mass properties/photo, 511 → 511 | baseline start none → 2004-06-08; baseline finish none → 2004-06-08 |
| 494 | Deliver LET FM 2 (stays at CIT for SEP I&T) | 2004-05-07 → 2004-06-08 (+32d) | 2004-05-07 → 2004-06-08 (+32d) |  |  | 53d → 29d | LET FM 2 Detector Board Mass properties/photo, 513 → 513 | baseline start none → 2004-06-08; baseline finish none → 2004-06-08 |
| 495 | Deliver LET Flight Software Build 3 | 2004-01-15 → 2004-05-04 (+110d) | 2004-01-15 → 2004-05-04 (+110d) |  |  | 126d → 39d |  | baseline start none → 2004-05-04; baseline finish none → 2004-05-04 |
| 496 | **Detectors** |  | 2004-02-05 → 2004-03-12 (+36d) | 142d → 167d | 48% → 83% | 72d → 56d |  | baseline start none → 2003-07-14; baseline finish none → 2004-03-12 |
| 497 | Complete LET Flight Detector Testing |  | 2004-01-28 → 2004-03-12 (+44d) | 136d → 167d | 42% → 83% | 78d → 56d |  | was named Detector Testing; constraint none → start no earlier than 2003-07-14; baseline start none → 2003-07-14; baseline finish none → 2004-03-12 |
| 498 | **Hybrids** |  | 2004-02-05 → 2004-03-01 (+25d) | 128d → 144d | 72% → 86% | 20d → 27d |  | baseline start none → 2003-08-01; baseline finish none → 2004-03-01 |
| 499 | Complete Test of Flight Hybrids (LET and to GSFC for HET FM 2) | 2004-02-04 → 2003-08-01 A (-187d) | 2004-02-05 → 2004-03-01 (+25d) | 2d → 144d | 0% → 86% | 20d → 27d | Select parts for flight → none | was named Deliver HET Hybrids to GSFC; constraint none → start no earlier than 2003-08-01; baseline start none → 2003-08-01; baseline finish none → 2004-03-01 |
| 500 | **Detector/Misc Board** | 2003-09-15 A → 2004-03-02 (+169d) | 2004-04-14 → 2004-03-30 (-15d) | 146d → 21d | 62% → 0% | 70d → 27d |  | baseline start none → 2004-03-02; baseline finish none → 2004-03-30 |
| 501 | **Assembly** | 2004-02-06 → 2004-03-02 (+25d) | 2004-04-14 → 2004-03-15 (-30d) | 48d → 10d |  | 70d → 27d |  | baseline start none → 2004-03-02; baseline finish none → 2004-03-15 |
| 502 | Assemble LET FM 1 Detector Board | 2004-02-06 → 2004-03-02 (+25d) | 2004-02-20 → 2004-03-15 (+24d) |  |  | 80d → 27d | Receive/inspect/database flight parts for LET Detector Board, Inspect flight LET Detector Printed Circuit Boards (coupons & elec continuity), Burn-in flight FPGA/EEPROM for LET Detector Board → 499 | baseline start none → 2004-03-02; baseline finish none → 2004-03-15 |
| 503 | Assemble LET FM 2 Detector Board | 2004-02-23 → 2004-03-02 (+8d) | 2004-03-05 → 2004-03-15 (+10d) |  |  | 80d → 27d | 502 → 499 | baseline start none → 2004-03-02; baseline finish none → 2004-03-15 |
| 504 | **Test** | 2004-02-24 → 2004-03-16 (+21d) | 2004-04-14 → 2004-03-30 (-15d) | 37d → 11d |  | 70d → 27d |  | baseline start none → 2004-03-16; baseline finish none → 2004-03-30 |
| 505 | Test LET FM 1 Detector Board | 2004-02-24 → 2004-03-16 (+21d) | 2004-03-01 → 2004-03-30 (+29d) | 5d → 11d |  | 84d → 27d | Post-assembly QA inspection for flight LET Detector Boards → 502 | was named Test LET FM 1 Detector Boards (initial); baseline start none → 2004-03-16; baseline finish none → 2004-03-30 |
| 506 | Test LET FM 2 Detector Board | 2004-03-09 → 2004-03-16 (+7d) | 2004-03-15 → 2004-03-30 (+15d) | 5d → 11d |  | 80d → 27d | Post-assembly QA inspection for flight LET Detector Boards → 503 | was named Test LET FM 2 Detector Boards (initial); baseline start none → 2004-03-16; baseline finish none → 2004-03-30 |
| 507 | **Flight Software** |  | 2004-01-15 → 2004-05-04 (+110d) | 114d → 190d | 90% → 65% | 126d → 39d |  | baseline start none → 2003-08-01; baseline finish none → 2004-05-04 |
| 508 | Let Flight Software Build 3 |  | 2004-01-15 → 2004-05-04 (+110d) | 114d → 190d | 90% → 65% | 126d → 39d |  | baseline start none → 2003-08-01; baseline finish none → 2004-05-04 |
| 509 | **Integration & Test** | 2004-03-15 → 2004-05-11 (+57d) | 2004-05-07 → 2004-06-08 (+32d) | 40d → 20d |  | 47d → 15d |  | baseline start none → 2004-05-11; baseline finish none → 2004-06-08 |
| 510 | **FM 1** | 2004-03-15 → 2004-05-11 (+57d) | 2004-05-07 → 2004-06-08 (+32d) | 40d → 20d |  | 47d → 15d |  | baseline start none → 2004-05-11; baseline finish none → 2004-06-08 |
| 511 | Integrate LET FM 1 Housing With Detectors | 2004-03-15 → 2004-05-11 (+57d) | 2004-05-07 → 2004-06-08 (+32d) | 40d → 20d |  | 47d → 15d | Perform Detector Noise & breakdown Testing, Perform Detector Thermal Vac Testing, Perform Detector Alphas Testing, Analyze Detector Testing Data, Capacitance, Current, Depletion, Alpha Resolution, Life Test LET Flight Detectors, 386 → 497, 440, 386 | baseline start none → 2004-05-11; baseline finish none → 2004-06-08 |
| 512 | **FM 2** | 2004-03-15 → 2004-05-11 (+57d) | 2004-05-07 → 2004-06-08 (+32d) | 40d → 20d |  | 53d → 29d |  | baseline start none → 2004-05-11; baseline finish none → 2004-06-08 |
| 513 | Integrate LET FM 2 Housing With Detectors | 2004-03-15 → 2004-05-11 (+57d) | 2004-05-07 → 2004-06-08 (+32d) | 40d → 20d |  | 53d → 29d | Perform Detector Noise & breakdown Testing, Perform Detector Thermal Vac Testing, Perform Detector Alphas Testing, Analyze Detector Testing Data, Capacitance, Current, Depletion, Alpha Resolution, Life Test LET Flight Detectors, 386 → 497, 440, 386 | baseline start none → 2004-05-11; baseline finish none → 2004-06-08 |
| 514 | **SEPT - Kiel/ESTEC** |  | 2004-08-18 → 2004-07-28 (-21d) | 260d → 245d | 35% → 71% | 68d → 338d |  | baseline start none → 2003-08-08; baseline finish none → 2004-07-28 |
| 515 | **Deliveries** | 2004-03-01 → 2004-03-11 (+10d) | 2004-08-18 → 2004-07-28 (-21d) | 122d → 99d |  |  |  | baseline start none → 2004-03-11; baseline finish none → 2004-07-28 |
| 516 | Deliver SEPT-NS FM 1 to CIT for SEP I&T and Suite EMC | 2004-03-12 → 2004-03-11 (-1d) | 2004-03-18 → 2004-03-17 (-1d) |  |  | 81d → 71d |  | baseline start none → 2004-03-11; baseline finish none → 2004-03-17 |
| 517 | Deliver SEPT-E FM 1 to CIT for SEP I&T and Suite EMC | 2004-03-01 → 2004-03-11 (+10d) | 2004-03-05 → 2004-03-17 (+12d) |  |  | 90d → 71d |  | baseline start none → 2004-03-11; baseline finish none → 2004-03-17 |
| 518 | Final Delivery of SEPT FM 1 to APL (after Therm Bal @ GSFC) | 2004-08-17 → 2004-07-27 (-21d) | 2004-08-18 → 2004-07-28 (-21d) |  |  | 35d → 49d |  | was named Final Delivery of SEPT FM 1 to APL; baseline start none → 2004-07-27; baseline finish none → 2004-07-28 |
| 519 | Deliver SEPT-NS FM 2 to CIT for SEP I&T and Suite EMC | 2004-03-08 → 2004-03-22 (+14d) | 2004-03-12 → 2004-03-26 (+14d) |  |  | 91d → 78d |  | baseline start none → 2004-03-22; baseline finish none → 2004-03-26 |
| 520 | Deliver SEPT-E FM 2 to CIT for SEP I&T and Suite EMC | 2004-03-08 → 2004-03-22 (+14d) | 2004-03-12 → 2004-03-26 (+14d) |  |  | 91d → 78d |  | baseline start none → 2004-03-22; baseline finish none → 2004-03-26 |
| 521 | **Mechanical Assembly** |  |  |  | 66% → 77% | 190d → 445d |  | baseline start none → 2003-12-22; baseline finish none → 2004-02-27 |

| ID | Task | Start | Finish | Duration | Complete | Total float | Predecessors | Other |
| --- | --- | --- | --- | --- | --- | --- | --- | --- |
| 522 | **FM 1** |  |  |  |  |  |  | baseline start none → 2003-12-22; baseline finish none → 2004-01-09 |
| 523 | Assemble SEPT-NS FM 1 Sensor and E-Box Housing |  |  |  |  |  |  | baseline start none → 2003-12-22; baseline finish none → 2004-01-09 |
| 524 | Assemble SEPT-E FM 1 Sensor and E-Box Housing |  |  |  |  |  |  | baseline start none → 2003-12-22; baseline finish none → 2004-01-09 |
| 525 | **FM 2** |  |  |  |  |  |  | baseline start none → 2003-12-29; baseline finish none → 2004-01-16 |
| 526 | Assemble SEPT-NS FM 2 Sensor and E-Box Housing |  |  |  |  |  |  | baseline start none → 2003-12-29; baseline finish none → 2004-01-16 |
| 527 | Assemble SEPT-E FM 2 Sensor and E-Box Housing |  |  |  |  |  |  | baseline start none → 2003-12-29; baseline finish none → 2004-01-16 |
| 528 | **Spare** | 2004-01-20 A |  |  | 0% → 32% | 190d → 445d |  | baseline start none → 2004-01-20; baseline finish none → 2004-02-27 |
| 529 | Assemble SEPT Spare Sensor and E-Box Housing | 2004-01-20 A |  |  | 0% → 32% | 190d → 445d |  | baseline start none → 2004-01-20; baseline finish none → 2004-02-27 |
| 530 | **Electronics** |  | 2004-03-08 → 2004-05-21 (+74d) | 144d → 198d | 43% → 84% | 184d → 385d |  | baseline start none → 2003-08-08; baseline finish none → 2004-05-21 |
| 531 | **Assembly** |  | 2004-02-06 → 2004-04-15 (+69d) | 124d → 172d | 44% → 86% | 184d → 396d |  | baseline start none → 2003-08-08; baseline finish none → 2004-04-15 |
| 532 | **FM 2** |  |  |  |  |  |  | baseline start none → 2003-08-08; baseline finish none → 2004-01-12 |
| 533 | Assemble SEPT-NS FM 2 Electronics |  |  |  |  |  |  | baseline start none → 2003-08-08; baseline finish none → 2004-01-12 |
| 534 | Assemble SEPT-E FM 2 Electronics |  |  |  |  |  |  | baseline start none → 2003-08-08; baseline finish none → 2003-12-19 |
| 535 | **Spare** | 2003-08-08 A | 2004-02-06 → 2004-04-15 (+69d) | 124d → 172d | 0% → 69% | 184d → 396d |  | baseline start none → 2003-08-08; baseline finish none → 2004-04-15 |
| 536 | Assemble SEPT FS Electronics | 2003-08-08 A | 2004-02-06 → 2004-04-15 (+69d) | 124d → 172d | 0% → 69% | 184d → 396d |  | was named Assemble SEPT-NS FS Electronics; baseline start none → 2003-08-08; baseline finish none → 2004-04-15 |
| 537 | **Test** |  | 2004-03-08 → 2004-05-21 (+74d) | 59d → 113d | 35% → 70% | 184d → 385d |  | baseline start none → 2003-12-11; baseline finish none → 2004-05-21 |
| 538 | **FM 2** |  | 2004-01-30 A |  | 74% → 100% | 209d → none |  | baseline start none → 2003-12-11; baseline finish none → 2004-01-30 |
| 539 | SEPT-NS FM 2 Electronics Test |  |  |  |  |  |  | baseline start none → 2004-01-13; baseline finish none → 2004-01-16 |
| 540 | SEPT-E FM 2 Electronics Test |  |  |  |  |  |  | baseline start none → 2003-12-11; baseline finish none → 2003-12-16 |
| 541 | Coat SEPT-NS FM 2 Electronics Board | 2004-01-20 A | 2004-01-23 A |  | 0% → 100% | 209d → none |  | baseline start none → 2004-01-20; baseline finish none → 2004-01-23 |
| 542 | Coat SEPT-E FM 2 Electronics Board |  |  |  |  |  |  | baseline start none → 2003-12-17; baseline finish none → 2003-12-23 |
| 543 | SEPT-NS FM 2 Mechanical Integration | 2004-01-26 A | 2004-01-30 A |  | 0% → 100% | 209d → none |  | baseline start none → 2004-01-26; baseline finish none → 2004-01-30 |
| 544 | SEPT-E FM 2 Mechanical Integration |  |  |  |  |  |  | baseline start none → 2003-12-24; baseline finish none → 2004-01-13 |
| 545 | **Spare** | 2004-02-09 → 2004-04-26 (+77d) | 2004-03-08 → 2004-05-21 (+74d) |  |  | 184d → 385d |  | baseline start none → 2004-04-26; baseline finish none → 2004-05-21 |
| 546 | SEPT Flight Spare Electronics Test | 2004-02-09 → 2004-04-26 (+77d) | 2004-02-13 → 2004-04-30 (+77d) |  |  | 184d → 390d |  | was named SEPT-NS Flight Spare Electronics Test; constraint none → start no earlier than 2004-04-26; baseline start none → 2004-04-26; baseline finish none → 2004-04-30 |
| 547 | Coat SEPT FS Electronics Board | 2004-02-17 → 2004-05-10 (+83d) | 2004-02-23 → 2004-05-14 (+81d) |  |  | 184d → 385d |  | was named Coat SEPT-NS FS Electronics Board; constraint none → start no earlier than 2004-05-10; baseline start none → 2004-05-10; baseline finish none → 2004-05-14 |
| 548 | SEPT FS Mechanical Integration | 2004-02-24 → 2004-05-17 (+83d) | 2004-03-08 → 2004-05-21 (+74d) | 10d → 5d |  | 184d → 385d |  | was named SEPT-NS FS Mechanical Integration; baseline start none → 2004-05-17; baseline finish none → 2004-05-21 |
| 549 | **Integration & Test** |  | 2004-08-16 → 2004-07-26 (-21d) | 153d → 138d | 3% → 35% |  |  | baseline start none → 2004-01-12; baseline finish none → 2004-07-26 |
| 550 | **FM 1** |  | 2004-08-16 → 2004-07-26 (-21d) | 153d → 138d | 6% → 29% | 35d → 49d |  | baseline start none → 2004-01-12; baseline finish none → 2004-07-26 |
| 551 | **SEPT-NS** | 2004-01-26 A | 2004-08-16 → 2004-07-26 (-21d) | 144d → 129d | 0% → 29% | 35d → 49d |  | baseline start none → 2004-01-26; baseline finish none → 2004-07-26 |
| 552 | SEPT-NS FM 1 Integration & Test | 2004-01-26 A | 2004-01-30 A |  | 0% → 100% | 81d → none |  | baseline start none → 2004-01-26; baseline finish none → 2004-01-30 |
| 553 | Muon and Radioactive Source Test | 2004-02-02 A | 2004-02-06 A |  | 0% → 100% | 81d → none |  | baseline start none → 2004-02-02; baseline finish none → 2004-02-06 |
| 554 | SEPT-NS FM 1 Vibration | 2004-02-09 → 2004-02-17 (+8d) | 2004-02-23 → 2004-02-20 (-3d) | 10d → 4d |  | 81d → 69d |  | was named SEPT-NS FM 1 Vibration and Acoustics; constraint none → start no earlier than 2004-02-17; baseline start none → 2004-02-17; baseline finish none → 2004-02-20 |
| 555 | SEPT-NS FM 1 Thermal Vac | 2004-02-24 → 2004-02-25 (+1d) |  | 10d → 9d |  | 81d → 71d | 554 → 554FS+2d | baseline start none → 2004-02-25; baseline finish none → 2004-03-08 |
| 556 | SEPT-NS FM 1 Bake Out |  | 2004-03-11 → 2004-03-10 (-1d) | 3d → 2d |  | 81d → 71d |  | baseline start none → 2004-03-09; baseline finish none → 2004-03-10 |
| 557 | SEPT-NS FM 1 Thermal Balance (at GSFC after Suite EMC) | 2004-08-03 → 2004-07-13 (-21d) | 2004-08-16 → 2004-07-26 (-21d) |  |  | 35d → 49d |  | was named SEPT-NS FM 1 Thermal Balance; baseline start none → 2004-07-13; baseline finish none → 2004-07-26 |
| 558 | **SEPT-E** |  | 2004-08-16 → 2004-07-26 (-21d) | 153d → 138d | 12% → 29% | 35d → 49d |  | baseline start none → 2004-01-12; baseline finish none → 2004-07-26 |
| 559 | SEPT-E FM 1 Integration & Test |  |  |  |  |  |  | baseline start none → 2004-01-12; baseline finish none → 2004-01-16 |
| 560 | Muon and Radioactive Source Test | 2004-01-20 → 2004-01-29 A (+9d) | 2004-01-26 → 2004-02-04 A (+9d) |  | 0% → 100% | 90d → none |  | constraint none → start no earlier than 2004-01-29; baseline start none → 2004-01-29; baseline finish none → 2004-02-04 |
| 562 | SEPT-E FM 1 Thermal Vac | 2004-02-10 → 2004-02-25 (+15d) | 2004-02-24 → 2004-03-08 (+13d) | 10d → 9d |  | 90d → 71d | SEPT-E FM 1 Vibration and Acoustics → 561, 555SS | baseline start none → 2004-02-25; baseline finish none → 2004-03-08 |
| 563 | SEPT-E FM 1 Bake Out | 2004-02-25 → 2004-03-09 (+13d) | 2004-02-27 → 2004-03-10 (+12d) | 3d → 2d |  | 90d → 71d |  | baseline start none → 2004-03-09; baseline finish none → 2004-03-10 |
| 564 | SEPT-E FM 1 Thermal Balance (at GSFC after Suite EMC) | 2004-08-03 → 2004-07-13 (-21d) | 2004-08-16 → 2004-07-26 (-21d) |  |  | 35d → 49d |  | was named SEPT-E FM 1 Thermal Balance; baseline start none → 2004-07-13; baseline finish none → 2004-07-26 |
| 565 | **FM 2** | 2004-01-20 → 2004-01-12 A (-8d) | 2004-08-16 → 2004-03-19 (-150d) | 148d → 48d | 0% → 44% | 49d → 78d |  | baseline start none → 2004-01-12; baseline finish none → 2004-03-19 |
| 566 | **SEPT-NS** | 2004-01-20 A | 2004-08-16 → 2004-03-19 (-150d) | 148d → 43d | 0% → 48% | 49d → 78d |  | baseline start none → 2004-01-20; baseline finish none → 2004-03-19 |
| 567 | SEPT-NS FM 2 Integration & Test | 2004-01-20 A | 2004-01-26 → 2004-01-29 A (+3d) | 5d → 8d | 0% → 100% | 91d → none |  | baseline start none → 2004-01-20; baseline finish none → 2004-01-29 |
| 568 | Muon and Radioactive Source Test | 2004-01-27 → 2004-01-30 A (+3d) | 2004-02-02 → 2004-02-06 A (+4d) | 5d → 6d | 0% → 100% | 91d → none |  | baseline start none → 2004-01-30; baseline finish none → 2004-02-06 |
| 569 | SEPT-NS FM 2 Vibration | 2004-02-03 → 2004-02-17 (+14d) | 2004-02-17 → 2004-02-20 (+3d) | 10d → 4d |  | 91d → 87d | 568 → 568, 554SS | was named SEPT-NS FM 2 Vibration and Acoustics; baseline start none → 2004-02-17; baseline finish none → 2004-02-20 |
| 570 | SEPT-NS FM 2 Thermal Vac | 2004-02-18 → 2004-03-09 (+20d) | 2004-03-02 → 2004-03-17 (+15d) | 10d → 9d |  | 91d → 78d | 569 → 569, 555 | baseline start none → 2004-03-09; baseline finish none → 2004-03-17 |
| 571 | SEPT-NS FM 2 Bake Out | 2004-03-03 → 2004-03-18 (+15d) | 2004-03-05 → 2004-03-19 (+14d) | 3d → 2d |  | 91d → 78d |  | baseline start none → 2004-03-18; baseline finish none → 2004-03-19 |
| 572 | **SEPT-E** | 2004-01-20 → 2004-01-12 A (-8d) | 2004-08-16 → 2004-03-19 (-150d) | 148d → 48d | 0% → 40% | 49d → 78d |  | baseline start none → 2004-01-12; baseline finish none → 2004-03-19 |
| 573 | SEPT-E FM 2 Integration & Test | 2004-01-20 → 2004-01-12 A (-8d) | 2004-01-26 → 2004-01-16 A (-10d) |  | 0% → 100% | 91d → none | 527 → 559SS | baseline start none → 2004-01-12; baseline finish none → 2004-01-16 |
| 574 | Muon and Radioactive Source Test | 2004-01-27 → 2004-01-29 A (+2d) | 2004-02-02 → 2004-02-04 A (+2d) |  | 0% → 100% | 91d → none | 573 → 573, 560SS | baseline start none → 2004-01-29; baseline finish none → 2004-02-04 |
| 575 | SEPT-E FM 2 Vibration | 2004-02-03 → 2004-02-21 (+18d) | 2004-02-17 → 2004-02-24 (+7d) | 10d → 4d |  | 91d → 87d | 574 → 574, 561SS | was named SEPT-E FM 2 Vibration and Acoustics; baseline start none → 2004-02-21; baseline finish none → 2004-02-24 |
| 576 | SEPT-E FM 2 Thermal Vac | 2004-02-18 → 2004-03-09 (+20d) | 2004-03-02 → 2004-03-17 (+15d) | 10d → 9d |  | 91d → 78d | 575 → 575, 570SS | baseline start none → 2004-03-09; baseline finish none → 2004-03-17 |
| 577 | SEPT-E FM 2 Bake Out | 2004-03-03 → 2004-03-18 (+15d) | 2004-03-05 → 2004-03-19 (+14d) | 3d → 2d |  | 91d → 78d |  | baseline start none → 2004-03-18; baseline finish none → 2004-03-19 |
| 578 | **SIT - UMD** |  | 2004-10-15 → 2004-10-20 (+5d) | 348d → 351d | 27% → 42% | 28d → 280d |  | baseline start none → 2003-06-02; baseline finish none → 2004-10-20 |
| 579 | **Deliveries** | 2004-07-13 → 2004-06-18 (-25d) | 2004-09-30 → 2004-10-12 (+12d) | 57d → 81d |  | 10d → 9d |  | baseline start none → 2004-06-18; baseline finish none → 2004-10-12 |
| 580 | Deliver SIT FM 1 to CIT for SEP I&T and Suite EMC | 2004-07-13 → 2004-06-18 (-25d) | 2004-07-14 → 2004-06-21 (-23d) |  |  | 10d → 9d | 678 → 407, 679 | baseline start none → 2004-06-18; baseline finish none → 2004-06-21 |
| 581 | Deliver SIT FM 1 back to GSFC for Environmental Testing (after EMC Test) | 2004-08-03 → 2004-07-13 (-21d) | 2004-08-04 → 2004-07-14 (-21d) |  |  | 10d → 24d |  | was named Deliver SIT FM 1 back to GSFC for Environmental Testing; baseline start none → 2004-07-13; baseline finish none → 2004-07-14 |
| 582 | Final Delivery of SIT FM 1 to APL | 2004-09-30 → 2004-09-01 (-29d) | 2004-09-30 → 2004-09-01 (-29d) |  |  | 5d → 24d | 720 → 711 | baseline start none → 2004-09-01; baseline finish none → 2004-09-01 |
| 583 | Deliver SIT FM 2 to CIT for SEP I&T | 2004-07-20 → 2004-07-23 (+3d) | 2004-07-21 → 2004-07-26 (+5d) |  |  | 9d → 16d | 684 → 684, 407 | baseline start none → 2004-07-23; baseline finish none → 2004-07-26 |
| 584 | Deliver SIT FM 2 back to GSFC for Environmental Testing | 2004-08-10 → 2004-08-19 (+9d) | 2004-08-11 → 2004-08-20 (+9d) |  |  | 5d → 11d |  | baseline start none → 2004-08-19; baseline finish none → 2004-08-20 |
| 585 | Final Delivery of SIT FM 2 to APL | 2004-09-30 → 2004-10-12 (+12d) | 2004-09-30 → 2004-10-12 (+12d) |  |  | 19d → 11d |  | baseline start none → 2004-10-12; baseline finish none → 2004-10-12 |
| 586 | **Detectors** | 2004-01-05 A | 2004-03-05 → 2004-03-30 (+25d) | 43d → 60d | 0% → 50% | 58d → 51d |  | baseline start none → 2004-01-05; baseline finish none → 2004-03-30 |
| 587 | **Detector Testing** | 2004-01-05 A | 2004-03-05 → 2004-03-30 (+25d) | 43d → 60d | 0% → 50% | 58d → 51d |  | baseline start none → 2004-01-05; baseline finish none → 2004-03-30 |
| 588 | **FM 1** | 2004-01-05 A | 2004-03-05 → 2004-03-30 (+25d) | 43d → 60d | 0% → 50% | 53d → 16d |  | baseline start none → 2004-01-05; baseline finish none → 2004-03-30 |
| 589 | Test FM 1 Solid States Detectors | 2004-01-05 A | 2004-02-06 → 2004-02-20 (+14d) | 24d → 33d | 0% → 58% | 62d → 33d |  | baseline start none → 2004-01-05; baseline finish none → 2004-02-20 |
| 590 | Test FM 1 Foils | 2004-01-05 A | 2004-02-06 → 2004-02-20 (+14d) | 24d → 33d | 0% → 58% | 62d → 33d |  | baseline start none → 2004-01-05; baseline finish none → 2004-02-20 |
| 591 | Alpha Tests FM 1 w/Proto Elect | 2004-02-23 → 2004-03-17 (+23d) | 2004-03-05 → 2004-03-30 (+25d) |  |  | 53d → 16d |  | baseline start none → 2004-03-17; baseline finish none → 2004-03-30 |
| 592 | **FM 2** | 2004-01-05 A | 2004-03-05 → 2004-03-30 (+25d) | 43d → 60d | 0% → 50% | 58d → 51d |  | baseline start none → 2004-01-05; baseline finish none → 2004-03-30 |

| ID | Task | Start | Finish | Duration | Complete | Total float | Other |
| --- | --- | --- | --- | --- | --- | --- | --- |
| 593 | Test FM 2 Solid States Detectors | 2004-01-05 A | 2004-02-06 → 2004-02-20 (+14d) | 24d → 33d | 0% → 58% | 67d → 68d | baseline start none → 2004-01-05; baseline finish none → 2004-02-20 |
| 594 | Test FM 2 Foils | 2004-01-05 A | 2004-02-06 → 2004-02-20 (+14d) | 24d → 33d | 0% → 58% | 67d → 68d | baseline start none → 2004-01-05; baseline finish none → 2004-02-20 |
| 595 | Alpha Tests FM 2 w/Proto Elect | 2004-02-23 → 2004-03-17 (+23d) | 2004-03-05 → 2004-03-30 (+25d) |  |  | 58d → 51d | baseline start none → 2004-03-17; baseline finish none → 2004-03-30 |
| 596 | **ACTEL - for SIT Logic Board** |  |  |  |  | 81d → 60d | baseline start none → 2004-02-27; baseline finish none → 2004-03-12 |
| 597 | Burn Final SIT ACTEL Chip (at GSFC) |  |  |  |  | 81d → 60d | baseline start none → 2004-02-27; baseline finish none → 2004-02-27 |
| 598 | Evaluate (Test) SIT Final ACTEL Chip |  |  |  |  | 81d → 60d | baseline start none → 2004-03-01; baseline finish none → 2004-03-12 |
| 599 | **TOF Boards** | 2004-01-30 → 2004-02-12 A (+13d) | 2004-02-27 → 2004-03-11 (+13d) |  |  | 66d → 67d | baseline start none → 2004-02-12; baseline finish none → 2004-03-11 |
| 600 | Receive Analog and Digital TOF Boards (FM 1 & FM 2) | 2004-01-30 → 2004-02-12 A (+13d) | 2004-01-30 → 2004-02-12 A (+13d) |  | 0% → 100% | 66d → none | constraint start no earlier than 2004-01-30 → start no earlier than 2004-02-12; baseline start none → 2004-02-12; baseline finish none → 2004-02-12 |
| 601 | **Test** | 2004-01-30 → 2004-02-12 (+13d) | 2004-02-27 → 2004-03-11 (+13d) |  |  | 66d → 42d | baseline start none → 2004-02-12; baseline finish none → 2004-03-11 |
| 602 | **FM 1** | 2004-01-30 → 2004-02-12 (+13d) | 2004-02-12 → 2004-02-26 (+14d) |  |  | 66d → 42d | baseline start none → 2004-02-12; baseline finish none → 2004-02-26 |
| 603 | FM 1 TOF Boards Functional Test | 2004-01-30 → 2004-02-12 (+13d) | 2004-02-12 → 2004-02-26 (+14d) |  |  | 66d → 42d | baseline start none → 2004-02-12; baseline finish none → 2004-02-26 |
| 604 | **FM 2** | 2004-02-13 → 2004-02-27 (+14d) | 2004-02-27 → 2004-03-11 (+13d) |  |  | 66d → 67d | baseline start none → 2004-02-27; baseline finish none → 2004-03-11 |
| 605 | FM 2 TOF Boards Functional Test | 2004-02-13 → 2004-02-27 (+14d) | 2004-02-27 → 2004-03-11 (+13d) |  |  | 66d → 67d | baseline start none → 2004-02-27; baseline finish none → 2004-03-11 |
| 606 | **Energy Board** |  | 2004-03-02 → 2004-04-02 (+31d) | 76d → 99d | 57% → 65% | 64d → 51d | baseline start none → 2003-11-10; baseline finish none → 2004-04-02 |
| 607 | **Assembly** |  | 2004-01-16 → 2004-02-20 (+35d) | 46d → 69d | 76% → 80% | 79d → 66d | baseline start none → 2003-11-10; baseline finish none → 2004-02-20 |
| 608 | **FM 1** |  | 2004-01-16 → 2004-02-20 (+35d) | 46d → 69d | 76% → 80% | 64d → 31d | baseline start none → 2003-11-10; baseline finish none → 2004-02-20 |
| 609 | Assemble FM 1 Energy Board |  | 2004-01-16 → 2004-02-20 (+35d) | 46d → 69d | 76% → 80% | 64d → 31d | baseline start none → 2003-11-10; baseline finish none → 2004-02-20 |
| 610 | **FM 2** |  | 2004-01-16 → 2004-02-20 (+35d) | 46d → 69d | 76% → 80% | 79d → 66d | baseline start none → 2003-11-10; baseline finish none → 2004-02-20 |
| 611 | Assemble FM 2 Energy Board |  | 2004-01-16 → 2004-02-20 (+35d) | 46d → 69d | 76% → 80% | 79d → 66d | baseline start none → 2003-11-10; baseline finish none → 2004-02-20 |
| 612 | **Test** | 2004-01-20 → 2004-02-23 (+34d) | 2004-03-02 → 2004-04-02 (+31d) |  |  | 64d → 31d | baseline start none → 2004-02-23; baseline finish none → 2004-04-02 |
| 613 | **FM 1** | 2004-01-20 → 2004-02-23 (+34d) | 2004-02-09 → 2004-03-12 (+32d) |  |  | 64d → 31d | baseline start none → 2004-02-23; baseline finish none → 2004-03-12 |
| 614 | Bench Test/Calibration | 2004-01-20 → 2004-02-23 (+34d) | 2004-02-02 → 2004-03-05 (+32d) |  |  | 64d → 31d | baseline start none → 2004-02-23; baseline finish none → 2004-03-05 |
| 615 | Thermal | 2004-02-03 → 2004-03-08 (+34d) | 2004-02-05 → 2004-03-10 (+34d) |  |  | 64d → 31d | baseline start none → 2004-03-08; baseline finish none → 2004-03-10 |
| 616 | Voltage Margin | 2004-02-06 → 2004-03-11 (+34d) | 2004-02-09 → 2004-03-12 (+32d) |  |  | 64d → 31d | baseline start none → 2004-03-11; baseline finish none → 2004-03-12 |
| 617 | **FM 2** | 2004-02-10 → 2004-03-15 (+34d) | 2004-03-02 → 2004-04-02 (+31d) |  |  | 64d → 51d | baseline start none → 2004-03-15; baseline finish none → 2004-04-02 |
| 618 | FM 2 Energy Board Functional Test | 2004-02-10 → 2004-03-15 (+34d) | 2004-03-02 → 2004-04-02 (+31d) |  |  | 64d → 51d | baseline start none → 2004-03-15; baseline finish none → 2004-04-02 |
| 619 | **Logic Board** |  | 2004-07-06 → 2004-07-09 (+3d) | 165d → 168d | 31% → 39% | 9d → 16d | baseline start none → 2003-11-10; baseline finish none → 2004-07-09 |
| 620 | **Design** |  |  |  |  |  | baseline start none → 2003-11-17; baseline finish none → 2003-11-19 |
| 621 | Layout new Logic Board Design |  |  |  |  |  | baseline start none → 2003-11-17; baseline finish none → 2003-11-19 |
| 622 | **Fabrication** | 2004-02-02 → 2004-02-09 (+7d) | 2004-02-13 → 2004-02-23 (+10d) |  |  | 24d → 9d | baseline start none → 2004-02-09; baseline finish none → 2004-02-23 |
| 623 | FM 1 & FM 2 Logic Board Fabrication | 2004-02-02 → 2004-02-09 (+7d) | 2004-02-13 → 2004-02-23 (+10d) |  |  | 24d → 9d | baseline start none → 2004-02-09; baseline finish none → 2004-02-23 |
| 624 | **Assembly** | 2004-03-02 → 2004-03-09 (+7d) | 2004-07-02 → 2004-07-07 (+5d) | 88d → 86d |  |  | baseline start none → 2004-03-09; baseline finish none → 2004-07-07 |
| 625 | **FM 1** | 2004-03-02 → 2004-03-09 (+7d) | 2004-06-25 → 2004-05-27 (-29d) | 83d → 58d |  | 10d → 9d | baseline start none → 2004-03-09; baseline finish none → 2004-05-27 |
| 626 | Assemble FM 1 Logic Board with ETU ACTELs | 2004-03-02 → 2004-03-09 (+7d) | 2004-03-16 → 2004-03-23 (+7d) |  |  | 24d → 9d | baseline start none → 2004-03-09; baseline finish none → 2004-03-23 |
| 627 | Disassembel FM 1 Logic Board with ETU ACTELs | 2004-06-22 → 2004-05-24 (-29d) | 2004-06-22 → 2004-05-24 (-29d) |  |  | 10d → 9d | baseline start none → 2004-05-24; baseline finish none → 2004-05-24 |
| 628 | Retrofit/Inspect FM 1 Flight ACTELs | 2004-06-23 → 2004-05-25 (-29d) | 2004-06-24 → 2004-05-26 (-29d) |  |  | 10d → 9d | baseline start none → 2004-05-25; baseline finish none → 2004-05-26 |
| 629 | Reassemble FM 1 Logic Board with Flight ACTELs | 2004-06-25 → 2004-05-27 (-29d) | 2004-06-25 → 2004-05-27 (-29d) |  |  | 10d → 9d | baseline start none → 2004-05-27; baseline finish none → 2004-05-27 |
| 630 | **FM 2** | 2004-03-02 → 2004-03-09 (+7d) | 2004-07-02 → 2004-07-07 (+5d) | 88d → 86d |  | 9d → 16d | baseline start none → 2004-03-09; baseline finish none → 2004-07-07 |
| 631 | Assemble FM 2 Logic Board with ETU ACTELS | 2004-03-02 → 2004-03-09 (+7d) | 2004-03-16 → 2004-03-23 (+7d) |  |  | 39d → 44d | baseline start none → 2004-03-09; baseline finish none → 2004-03-23 |
| 632 | Disassemble FM 2 Logic Boards | 2004-06-29 → 2004-07-02 (+3d) | 2004-06-29 → 2004-07-02 (+3d) |  |  | 9d → 16d | baseline start none → 2004-07-02; baseline finish none → 2004-07-02 |
| 633 | Retrofit/Inspect Flight ACTELS | 2004-06-30 → 2004-07-05 (+5d) | 2004-07-01 → 2004-07-06 (+5d) |  |  | 9d → 16d | baseline start none → 2004-07-05; baseline finish none → 2004-07-06 |
| 634 | Reassemble FM 2 Logic Boards | 2004-07-02 → 2004-07-07 (+5d) | 2004-07-02 → 2004-07-07 (+5d) |  |  | 9d → 16d | baseline start none → 2004-07-07; baseline finish none → 2004-07-07 |
| 635 | **Test** |  | 2004-07-06 → 2004-07-09 (+3d) | 165d → 168d | 42% → 53% | 9d → 16d | baseline start none → 2003-11-10; baseline finish none → 2004-07-09 |
| 636 | **ETU** |  | 2004-01-30 → 2004-02-06 (+7d) | 55d → 60d | 75% → 92% | 24d → 9d | baseline start none → 2003-11-10; baseline finish none → 2004-02-06 |
| 637 | Test New ETU Logic Board |  | 2004-01-30 → 2004-02-06 (+7d) | 55d → 60d | 75% → 92% | 24d → 9d | baseline start none → 2003-11-10; baseline finish none → 2004-02-06 |
| 638 | **FM1 & FM 2** | 2004-02-17 → 2004-02-24 (+7d) | 2004-03-01 → 2004-03-08 (+7d) |  |  | 24d → 9d | baseline start none → 2004-02-24; baseline finish none → 2004-03-08 |
| 639 | Coupon Testing | 2004-02-17 → 2004-02-24 (+7d) | 2004-03-01 → 2004-03-08 (+7d) |  |  | 24d → 9d | baseline start none → 2004-02-24; baseline finish none → 2004-03-08 |
| 640 | **FM 1** | 2004-03-17 → 2004-03-24 (+7d) | 2004-06-29 → 2004-06-01 (-28d) | 74d → 49d |  | 10d → 9d | baseline start none → 2004-03-24; baseline finish none → 2004-06-01 |
| 641 | Functional Test of FM 1 Logic Board w/ETU ACTELS | 2004-03-17 → 2004-03-24 (+7d) | 2004-04-06 → 2004-04-13 (+7d) |  |  | 24d → 9d | baseline start none → 2004-03-24; baseline finish none → 2004-04-13 |
| 642 | Funtional Test of FM 1 Logic Board w/Flight ACTELS | 2004-06-28 → 2004-05-28 (-31d) | 2004-06-29 → 2004-06-01 (-28d) |  |  | 10d → 9d | baseline start none → 2004-05-28; baseline finish none → 2004-06-01 |
| 643 | **FM 2** | 2004-04-07 → 2004-04-14 (+7d) | 2004-07-06 → 2004-07-09 (+3d) | 64d → 62d |  | 9d → 16d | baseline start none → 2004-04-14; baseline finish none → 2004-07-09 |
| 644 | Functional Test of FM 2 Logic Board w/ETU ACTELS | 2004-04-07 → 2004-04-14 (+7d) | 2004-04-27 → 2004-05-04 (+7d) |  |  | 24d → 29d | baseline start none → 2004-04-14; baseline finish none → 2004-05-04 |
| 645 | Functional Test of FM 2 Logic Board w/Flight ACTELS | 2004-07-05 → 2004-07-08 (+3d) | 2004-07-06 → 2004-07-09 (+3d) |  |  | 9d → 16d | baseline start none → 2004-07-08; baseline finish none → 2004-07-09 |
| 646 | **Mother Board** | 2003-12-22 A | 2004-03-04 → 2004-03-25 (+21d) | 50d → 65d | 0% → 30% | 49d → 426d | baseline start none → 2003-12-22; baseline finish none → 2004-03-25 |
| 647 | **Design** | 2003-12-22 A | 2004-01-13 → 2004-02-04 (+22d) | 15d → 30d | 0% → 90% | 49d → 27d | baseline start none → 2003-12-22; baseline finish none → 2004-02-04 |
| 648 | **FM 1 & FM 2** | 2003-12-22 A | 2004-01-13 → 2004-02-04 (+22d) | 15d → 30d | 0% → 90% | 49d → 27d | baseline start none → 2003-12-22; baseline finish none → 2004-02-04 |
| 649 | Finalize Mother Board Layout | 2003-12-22 A | 2004-01-13 → 2004-02-04 (+22d) | 15d → 30d | 0% → 90% | 49d → 27d | baseline start none → 2003-12-22; baseline finish none → 2004-02-04 |
| 650 | **Fabrication** | 2004-01-14 → 2004-02-05 (+22d) | 2004-02-04 → 2004-02-26 (+22d) |  |  | 49d → 27d | baseline start none → 2004-02-05; baseline finish none → 2004-02-26 |
| 651 | **FM 1 & FM 2** | 2004-01-14 → 2004-02-05 (+22d) | 2004-02-04 → 2004-02-26 (+22d) |  |  | 49d → 27d | baseline start none → 2004-02-05; baseline finish none → 2004-02-26 |
| 652 | Fabricate FM 1 & FM 2 Mother Boards | 2004-01-14 → 2004-02-05 (+22d) | 2004-02-04 → 2004-02-26 (+22d) |  |  | 49d → 27d | baseline start none → 2004-02-05; baseline finish none → 2004-02-26 |
| 653 | **Assembly** | 2004-02-05 → 2004-02-27 (+22d) | 2004-02-19 → 2004-03-11 (+21d) |  |  | 49d → 27d | baseline start none → 2004-02-27; baseline finish none → 2004-03-11 |
| 654 | Assemble FM 1 Mother Board | 2004-02-05 → 2004-02-27 (+22d) | 2004-02-19 → 2004-03-11 (+21d) |  |  | 49d → 27d | baseline start none → 2004-02-27; baseline finish none → 2004-03-11 |
| 655 | Assemble FM 2 Mother Board | 2004-02-05 → 2004-02-27 (+22d) | 2004-02-19 → 2004-03-11 (+21d) |  |  | 54d → 49d | baseline start none → 2004-02-27; baseline finish none → 2004-03-11 |
| 656 | **Test** | 2004-02-05 → 2004-02-27 (+22d) | 2004-03-04 → 2004-03-25 (+21d) |  |  | 59d → 37d | baseline start none → 2004-02-27; baseline finish none → 2004-03-25 |
| 657 | **FM 1 & FM 2** | 2004-02-05 → 2004-02-27 (+22d) | 2004-02-26 → 2004-03-18 (+21d) |  |  | 191d → 431d | baseline start none → 2004-02-27; baseline finish none → 2004-03-18 |
| 658 | Coupon Testing of Mother Boards | 2004-02-05 → 2004-02-27 (+22d) | 2004-02-26 → 2004-03-18 (+21d) |  |  | 191d → 431d | baseline start none → 2004-02-27; baseline finish none → 2004-03-18 |
| 659 | **FM 1** | 2004-02-20 → 2004-03-12 (+21d) | 2004-02-26 → 2004-03-18 (+21d) |  |  | 49d → 27d | baseline start none → 2004-03-12; baseline finish none → 2004-03-18 |
| 660 | Functional Test FM 1 Mother Board | 2004-02-20 → 2004-03-12 (+21d) | 2004-02-26 → 2004-03-18 (+21d) |  |  | 49d → 27d | baseline start none → 2004-03-12; baseline finish none → 2004-03-18 |
| 661 | **FM 2** | 2004-02-27 → 2004-03-19 (+21d) | 2004-03-04 → 2004-03-25 (+21d) |  |  | 49d → 44d | baseline start none → 2004-03-19; baseline finish none → 2004-03-25 |
| 662 | Functional Test FM 2 Mother Board | 2004-02-27 → 2004-03-19 (+21d) | 2004-03-04 → 2004-03-25 (+21d) |  |  | 49d → 44d | baseline start none → 2004-03-19; baseline finish none → 2004-03-25 |

| ID | Task | Start | Finish | Duration | Complete | Total float | Predecessors | Other |
| --- | --- | --- | --- | --- | --- | --- | --- | --- |
| 663 | **HVPS** | 2004-01-12 A | 2004-04-08 → 2004-04-27 (+19d) | 62d → 75d | 0% → 47% | 34d → 31d |  | baseline start none → 2004-01-12; baseline finish none → 2004-04-27 |
| 664 | **Test** | 2004-01-12 A | 2004-04-08 → 2004-04-27 (+19d) | 62d → 75d | 0% → 47% | 34d → 31d |  | baseline start none → 2004-01-12; baseline finish none → 2004-04-27 |
| 665 | **FM 1** | 2004-01-12 A | 2004-01-26 → 2004-02-09 (+14d) | 10d → 20d | 0% → 70% | 81d → 51d |  | baseline start none → 2004-01-12; baseline finish none → 2004-02-09 |
| 666 | Functional Test SIT FM 1 HVPS | 2004-01-12 A | 2004-01-26 → 2004-02-09 (+14d) | 10d → 20d | 0% → 70% | 81d → 51d |  | baseline start none → 2004-01-12; baseline finish none → 2004-02-09 |
| 667 | **FM 2** | 2004-03-26 → 2004-04-14 (+19d) | 2004-04-08 → 2004-04-27 (+19d) |  |  | 34d → 31d |  | baseline start none → 2004-04-14; baseline finish none → 2004-04-27 |
| 668 | Functional Test SIT FM 2 HVPS | 2004-03-26 → 2004-04-14 (+19d) | 2004-04-08 → 2004-04-27 (+19d) |  |  | 34d → 31d |  | baseline start none → 2004-04-14; baseline finish none → 2004-04-27 |
| 669 | **Flight Software** |  |  |  | 70% → 80% | 65d → 44d |  | baseline start none → 2003-06-02; baseline finish none → 2004-04-01 |
| 670 | **Test** |  |  |  | 70% → 80% | 65d → 44d |  | baseline start none → 2003-06-02; baseline finish none → 2004-04-01 |
| 671 | **FM 1 & FM 2** |  |  |  | 70% → 80% | 65d → 44d |  | baseline start none → 2003-06-02; baseline finish none → 2004-04-01 |
| 672 | Validate SIT On-Board Code |  |  |  | 70% → 80% | 65d → 44d |  | baseline start none → 2003-06-02; baseline finish none → 2004-04-01 |
| 673 | **Integration & Test (using ETU Telescope for FM 1)** | 2004-03-08 → 2004-03-31 (+23d) | 2004-07-19 → 2004-07-22 (+3d) | 95d → 81d |  | 9d → 16d |  | was named Integration & Test; baseline start none → 2004-03-31; baseline finish none → 2004-07-22 |
| 674 | **FM 1 (Flight Telescope)** | 2004-06-30 → 2004-06-02 (-28d) | 2004-07-12 → 2004-06-17 (-25d) | 9d → 12d |  | 10d → 9d |  | was named FM 1; baseline start none → 2004-06-02; baseline finish none → 2004-06-17 |
| 675 | Disassemble SIT FM 1 | 2004-06-30 → 2004-06-02 (-28d) | 2004-06-30 → 2004-06-02 (-28d) |  |  | 10d → 9d |  | baseline start none → 2004-06-02; baseline finish none → 2004-06-02 |
| 676 | Conformal Coat SIT FM 1 Boards | 2004-07-01 → 2004-06-03 (-28d) | 2004-07-02 → 2004-06-04 (-28d) |  |  | 10d → 9d |  | baseline start none → 2004-06-03; baseline finish none → 2004-06-04 |
| 677 | Reassemble SIT FM 1 with Flight Telescope | 2004-07-05 → 2004-06-07 (-28d) | 2004-07-05 → 2004-06-07 (-28d) |  |  | 10d → 9d | 676 → 676, 401 | was named Reassemble SIT FM 1; baseline start none → 2004-06-07; baseline finish none → 2004-06-07 |
| 678 | Bench Calibration SIT FM 1 w/Flight Telescope | 2004-07-06 → 2004-06-08 (-28d) | 2004-07-12 → 2004-06-10 (-32d) | 5d → 3d |  | 10d → 9d |  | was named Post-Coat Retest SIT FM 1; baseline start none → 2004-06-08; baseline finish none → 2004-06-10 |
| 680 | **FM 2** | 2004-07-07 → 2004-07-12 (+5d) | 2004-07-19 → 2004-07-22 (+3d) |  |  | 9d → 16d |  | baseline start none → 2004-07-12; baseline finish none → 2004-07-22 |
| 681 | Disassemble SIT FM 2 | 2004-07-07 → 2004-07-12 (+5d) | 2004-07-07 → 2004-07-12 (+5d) |  |  | 9d → 16d |  | baseline start none → 2004-07-12; baseline finish none → 2004-07-12 |
| 682 | Conformal Coat SIT FM 2 Boards | 2004-07-08 → 2004-07-13 (+5d) | 2004-07-09 → 2004-07-14 (+5d) |  |  | 9d → 16d |  | baseline start none → 2004-07-13; baseline finish none → 2004-07-14 |
| 683 | Reassemble SIT FM 2 | 2004-07-12 → 2004-07-15 (+3d) | 2004-07-12 → 2004-07-15 (+3d) |  |  | 9d → 16d |  | baseline start none → 2004-07-15; baseline finish none → 2004-07-15 |
| 684 | Post-Coat Retest SIT FM 2 | 2004-07-13 → 2004-07-16 (+3d) | 2004-07-19 → 2004-07-22 (+3d) |  |  | 9d → 16d |  | baseline start none → 2004-07-16; baseline finish none → 2004-07-22 |
| 685 | **FM 1 (ETU Telescope)** | 2004-03-08 → 2004-03-31 (+23d) | 2004-06-21 → 2004-05-21 (-31d) | 75d → 38d |  | 10d → 9d |  | was named FM 1; baseline start none → 2004-03-31; baseline finish none → 2004-05-21 |
| 686 | Integrate SIT FM 1 HVPS and SIT ETU Telescope Without Electronics | 2004-03-08 → 2004-03-31 (+23d) | 2004-03-10 → 2004-04-02 (+23d) |  |  | 53d → 16d |  | was named Integrate SIT FM 1 HVPS and SIT FM 1 Telescope Without Electronics; baseline start none → 2004-03-31; baseline finish none → 2004-04-02 |
| 687 | Integrate Electronics to SIT ETU Telescope | 2004-05-12 → 2004-04-14 (-28d) | 2004-05-13 → 2004-04-15 (-28d) |  |  |  | 641, 603, 660, 616, 686, 401 → 641, 603, 660, 616, 686 | was named Integrate SIT FM 1Telescope; baseline start none → 2004-04-14; baseline finish none → 2004-04-15 |
| 688 | SIT FM 1 Debug | 2004-05-14 → 2004-04-16 (-28d) | 2004-05-20 → 2004-04-22 (-28d) |  |  |  |  | baseline start none → 2004-04-16; baseline finish none → 2004-04-22 |
| 689 | SIT FM 1 Bench Test | 2004-05-21 → 2004-04-23 (-28d) | 2004-05-27 → 2004-04-29 (-28d) |  |  |  |  | baseline start none → 2004-04-23; baseline finish none → 2004-04-29 |
| 690 | SIT FM 1 Alpha TEST | 2004-05-28 → 2004-04-30 (-28d) | 2004-06-04 → 2004-05-06 (-29d) |  |  |  |  | baseline start none → 2004-04-30; baseline finish none → 2004-05-06 |
| 691 | SIT FM 1 Noise Removal | 2004-06-07 → 2004-05-07 (-31d) | 2004-06-11 → 2004-05-13 (-29d) |  |  |  |  | baseline start none → 2004-05-07; baseline finish none → 2004-05-13 |
| 692 | SIT FM 1 Thermal Test | 2004-06-14 → 2004-05-14 (-31d) | 2004-06-18 → 2004-05-20 (-29d) |  |  | 10d → 9d |  | baseline start none → 2004-05-14; baseline finish none → 2004-05-20 |
| 693 | SIT FM 1 Functional Test | 2004-06-21 → 2004-05-21 (-31d) | 2004-06-21 → 2004-05-21 (-31d) |  |  | 10d → 9d |  | baseline start none → 2004-05-21; baseline finish none → 2004-05-21 |
| 694 | **FM 2** | 2004-04-09 → 2004-05-19 (+40d) | 2004-06-28 → 2004-07-01 (+3d) | 56d → 31d |  | 9d → 16d |  | baseline start none → 2004-05-19; baseline finish none → 2004-07-01 |
| 695 | Integrate SIT FM 2 HVPS and SIT FM 2 Telescope Without Electronics | 2004-04-09 → 2004-05-19 (+40d) | 2004-04-13 → 2004-05-21 (+38d) |  |  | 34d → 16d | 668, 595 → 668, 595, 401 | baseline start none → 2004-05-19; baseline finish none → 2004-05-21 |
| 696 | Integrate Electronics to SIT FM 2 Telescope | 2004-05-12 → 2004-05-24 (+12d) | 2004-05-13 → 2004-05-25 (+12d) |  |  | 14d → 16d | 644, 605, 662, 618, 695, 401 → 644, 605, 662, 618, 695 | was named Integrate SIT FM 2 Telescope; baseline start none → 2004-05-24; baseline finish none → 2004-05-25 |
| 697 | SIT FM 2 Debug | 2004-05-14 → 2004-05-26 (+12d) | 2004-05-20 → 2004-06-02 (+13d) |  |  | 14d → 16d |  | baseline start none → 2004-05-26; baseline finish none → 2004-06-02 |
| 698 | SIT FM 2 Bench Test | 2004-05-21 → 2004-06-03 (+13d) | 2004-05-27 → 2004-06-09 (+13d) |  |  | 14d → 16d |  | baseline start none → 2004-06-03; baseline finish none → 2004-06-09 |
| 699 | SIT FM 2 Alpha Test | 2004-05-28 → 2004-06-10 (+13d) | 2004-06-04 → 2004-06-16 (+12d) |  |  | 14d → 16d |  | baseline start none → 2004-06-10; baseline finish none → 2004-06-16 |
| 700 | SIT FM 2 Noise Removal | 2004-06-14 → 2004-06-17 (+3d) | 2004-06-18 → 2004-06-23 (+5d) |  |  | 9d → 16d |  | baseline start none → 2004-06-17; baseline finish none → 2004-06-23 |
| 701 | SIT FM 2 Thermal Test | 2004-06-21 → 2004-06-24 (+3d) | 2004-06-25 → 2004-06-30 (+5d) |  |  | 9d → 16d |  | baseline start none → 2004-06-24; baseline finish none → 2004-06-30 |
| 702 | SIT FM 2 Functional Test | 2004-06-28 → 2004-07-01 (+3d) | 2004-06-28 → 2004-07-01 (+3d) |  |  | 9d → 16d |  | baseline start none → 2004-07-01; baseline finish none → 2004-07-01 |
| 712 | **Environmental Testing at GSFC (FM 2)** | 2004-08-12 → 2004-08-23 (+11d) | 2004-09-29 → 2004-10-08 (+9d) |  |  | 5d → 11d |  | was named Environmental Testing at GSFC (FM 1 & FM 2); baseline start none → 2004-08-23; baseline finish none → 2004-10-08 |
| 713 | SIT FM 2 Vibration and Acoustics | 2004-08-12 → 2004-08-23 (+11d) | 2004-08-25 → 2004-09-03 (+9d) |  |  | 5d → 11d | 581, 584 → 584 | was named SIT FM 1 & FM 2 Vibration and Acoustics; baseline start none → 2004-08-23; baseline finish none → 2004-09-03 |
| 714 | Functional Test | 2004-08-26 → 2004-09-07 (+12d) | 2004-08-26 → 2004-09-07 (+12d) |  |  | 5d → 11d |  | baseline start none → 2004-09-07; baseline finish none → 2004-09-07 |
| 715 | SIT FM 2 Thermal Balance | 2004-08-27 → 2004-09-08 (+12d) | 2004-09-02 → 2004-09-14 (+12d) |  |  | 5d → 11d |  | was named SIT FM 1 & FM 2 Thermal Balance; baseline start none → 2004-09-08; baseline finish none → 2004-09-14 |
| 716 | SIT FM 2 Thermal Vac | 2004-09-03 → 2004-09-15 (+12d) | 2004-09-17 → 2004-09-28 (+11d) |  |  | 5d → 11d |  | was named SIT FM 1 & FM 2 Thermal Vac; baseline start none → 2004-09-15; baseline finish none → 2004-09-28 |
| 717 | Disassemble SIT Instruments | 2004-09-20 → 2004-09-29 (+9d) | 2004-09-21 → 2004-09-30 (+9d) |  |  | 5d → 11d |  | baseline start none → 2004-09-29; baseline finish none → 2004-09-30 |
| 718 | Bake Out | 2004-09-22 → 2004-10-01 (+9d) | 2004-09-24 → 2004-10-05 (+11d) |  |  | 5d → 11d |  | baseline start none → 2004-10-01; baseline finish none → 2004-10-05 |
| 719 | Reassemble Instruments | 2004-09-27 → 2004-10-06 (+9d) | 2004-09-28 → 2004-10-07 (+9d) |  |  | 5d → 11d |  | baseline start none → 2004-10-06; baseline finish none → 2004-10-07 |
| 720 | Functional Test | 2004-09-29 → 2004-10-08 (+9d) | 2004-09-29 → 2004-10-08 (+9d) |  |  | 5d → 11d |  | baseline start none → 2004-10-08; baseline finish none → 2004-10-08 |
| 721 | **Emulators/Simulators/GSE** |  | 2004-10-15 → 2004-10-20 (+5d) | 211d → 214d | 9% → 27% | 28d → 280d |  | baseline start none → 2003-12-17; baseline finish none → 2004-10-20 |
| 722 | **Simulators** |  |  |  | 13% → 38% | 159d → 414d |  | baseline start none → 2003-12-17; baseline finish none → 2004-04-12 |
| 723 | Labview CPU Ready |  |  |  | 13% → 38% | 159d → 414d |  | baseline start none → 2003-12-17; baseline finish none → 2004-04-12 |
| 724 | Test Simulator |  |  |  | 13% → 38% | 159d → 414d |  | baseline start none → 2003-12-17; baseline finish none → 2004-04-12 |
| 725 | **GSE** | 2004-07-22 → 2004-07-27 (+5d) | 2004-10-15 → 2004-10-20 (+5d) |  |  | 28d → 280d |  | baseline start none → 2004-07-27; baseline finish none → 2004-10-20 |
| 726 | Pulse Generator | 2004-07-22 → 2004-07-27 (+5d) | 2004-10-15 → 2004-10-20 (+5d) |  |  | 28d → 280d |  | baseline start none → 2004-07-27; baseline finish none → 2004-10-20 |
| 727 | **SEP Suite I&T - CIT** |  | 2004-11-26 → 2004-10-21 (-36d) | 333d → 309d | 28% → 32% | 0d → 279d |  | baseline start none → 2003-08-01; baseline finish none → 2004-10-21 |
| 728 | **ETU** | 2004-02-23 → 2004-01-26 A (-28d) | 2004-02-27 → 2004-01-30 A (-28d) |  | 0% → 100% | 190d → none |  | baseline start none → 2004-01-26; baseline finish none → 2004-01-30 |
| 729 | Complete Integration/Test of SEP Central EM with Sensors | 2004-02-23 → 2004-01-26 A (-28d) | 2004-02-27 → 2004-01-30 A (-28d) |  | 0% → 100% | 190d → none |  | constraint start no earlier than 2004-02-23 → start no earlier than 2004-01-26; baseline start none → 2004-01-26; baseline finish none → 2004-01-30 |
| 730 | **FM 1 & FM 2** | 2004-03-08 → 2004-03-05 (-3d) | 2004-09-24 → 2004-10-21 (+27d) | 143d → 162d |  | 42d → 75d |  | baseline start none → 2004-03-05; baseline finish none → 2004-10-21 |
| 731 | Software Support For SEP Integration | 2004-04-15 → 2004-05-11 (+26d) | 2004-09-24 → 2004-10-21 (+27d) |  |  | 42d → 279d |  | baseline start none → 2004-05-11; baseline finish none → 2004-10-21 |
| 732 | Generate SEPT integration & test procedure | 2004-03-08 → 2004-03-05 (-3d) | 2004-03-12 → 2004-03-11 (-1d) |  |  | 86d → 76d |  | baseline start none → 2004-03-05; baseline finish none → 2004-03-11 |
| 733 | Generate LET integration & test procedure | 2004-04-05 → 2004-05-05 (+30d) | 2004-04-09 → 2004-05-11 (+32d) |  |  | 67d → 34d |  | baseline start none → 2004-05-05; baseline finish none → 2004-05-11 |
| 734 | Generate HET integration & test procedure | 2004-06-07 → 2004-05-20 (-18d) | 2004-06-11 → 2004-05-26 (-16d) |  |  |  |  | baseline start none → 2004-05-20; baseline finish none → 2004-05-26 |
| 735 | Generate SIT integration & test procedure | 2004-07-02 → 2004-06-09 (-23d) | 2004-07-08 → 2004-06-15 (-23d) |  |  | 15d → 14d |  | baseline start none → 2004-06-09; baseline finish none → 2004-06-15 |
| 736 | Generate SEP system test procedure | 2004-07-05 → 2004-06-10 (-25d) | 2004-07-09 → 2004-06-16 (-23d) |  |  | 15d → 14d |  | baseline start none → 2004-06-10; baseline finish none → 2004-06-16 |
| 737 | Software Support For Acceptance Testing of SEP Instruments | 2004-07-19 → 2004-06-24 (-25d) | 2004-08-24 → 2004-07-30 (-25d) |  |  | 64d → 336d |  | baseline start none → 2004-06-24; baseline finish none → 2004-07-30 |
| 738 | Generate SEP-IDPU integration procedure | 2004-06-08 → 2004-05-27 (-12d) | 2004-06-14 → 2004-06-03 (-11d) |  |  | 20d → 16d |  | baseline start none → 2004-05-27; baseline finish none → 2004-06-03 |
| 739 | Generate SEP-IDPU test procedure | 2004-06-15 → 2004-06-04 (-11d) | 2004-06-21 → 2004-06-10 (-11d) |  |  | 20d → 16d |  | baseline start none → 2004-06-04; baseline finish none → 2004-06-10 |
| 740 | Software Support of SEP Accelerator Tests | 2004-07-01 → 2004-06-29 (-2d) | 2004-07-28 → 2004-07-26 (-2d) |  |  | 83d → 340d |  | baseline start none → 2004-06-29; baseline finish none → 2004-07-26 |
| 741 | **FM 1** | 2004-03-19 → 2004-03-18 (-1d) | 2004-07-19 → 2004-06-28 (-21d) | 86d → 72d |  | 10d → 9d |  | baseline start none → 2004-03-18; baseline finish none → 2004-06-28 |
| 742 | Integrate/test SEP Central FM 1 | 2004-04-15 → 2004-05-11 (+26d) | 2004-04-15 → 2004-05-17 (+32d) | 1d → 5d |  | 42d → 29d | 416, Deliver SEP Cen FM 1 Analog/Post-Reg Board (stays at CIT for SEP Suite I&T), Deliver SEP Cen FM 1 SSD Bias Supply Board (stays at CIT for SEP Suite I&T), 68, 377, 419 → 416, 418, 377 | baseline start none → 2004-05-11; baseline finish none → 2004-05-17 |

| ID | Task | Start | Finish | Duration | Complete | Total float | Predecessors | Other |
| --- | --- | --- | --- | --- | --- | --- | --- | --- |
| 743 | Receive & inspect SEPT FM 1 | 2004-03-19 → 2004-03-18 (-1d) | 2004-03-19 → 2004-03-18 (-1d) |  |  | 81d → 71d |  | baseline start none → 2004-03-18; baseline finish none → 2004-03-18 |
| 744 | Integrate & test SEPT FM 1 | 2004-04-16 → 2004-05-18 (+32d) | 2004-04-16 → 2004-05-18 (+32d) |  |  | 62d → 29d |  | baseline start none → 2004-05-18; baseline finish none → 2004-05-18 |
| 745 | Integrate & test LET FM 1 | 2004-05-10 → 2004-06-09 (+30d) | 2004-05-10 → 2004-06-09 (+30d) |  |  | 47d → 15d |  | baseline start none → 2004-06-09; baseline finish none → 2004-06-09 |
| 746 | Receive & inspect HET FM 1 | 2004-06-18 → 2004-06-03 (-15d) | 2004-06-18 → 2004-06-03 (-15d) |  |  |  | 446 → 446, 448 | baseline start none → 2004-06-03; baseline finish none → 2004-06-03 |
| 747 | Integrate & test HET FM 1 | 2004-06-21 → 2004-06-10 (-11d) | 2004-06-21 → 2004-06-10 (-11d) |  |  | 19d → 15d |  | baseline start none → 2004-06-10; baseline finish none → 2004-06-10 |
| 748 | Integrate SEP FM 1 - IDPU FM 1 | 2004-06-22 → 2004-06-11 (-11d) | 2004-06-22 → 2004-06-11 (-11d) |  |  | 19d → 15d | 738, 747, 161 → 738, 747 | baseline start none → 2004-06-11; baseline finish none → 2004-06-11 |
| 749 | Test SEP FM 1 - IDPU FM 1 | 2004-06-23 → 2004-06-22 (-1d) | 2004-06-23 → 2004-06-22 (-1d) |  |  | 19d → 9d | 739, 748 → 739, 748, 353 | baseline start none → 2004-06-22; baseline finish none → 2004-06-22 |
| 750 | Receive & inspect SIT FM 1 | 2004-07-15 → 2004-06-22 (-23d) | 2004-07-15 → 2004-06-22 (-23d) |  |  | 10d → 9d |  | baseline start none → 2004-06-22; baseline finish none → 2004-06-22 |
| 751 | Integrate & test SIT FM 1 | 2004-07-16 → 2004-06-23 (-23d) | 2004-07-16 → 2004-06-23 (-23d) |  |  | 10d → 9d | 735, 747, 750, Rework SEP FM 1 - IDPU FM 1 issues and retest → 735, 747, 750, 749 | baseline start none → 2004-06-23; baseline finish none → 2004-06-23 |
| 752 | SEP system test FM 1 | 2004-07-19 → 2004-06-24 (-25d) | 2004-07-19 → 2004-06-28 (-21d) | 1d → 3d |  | 10d → 9d | 736, 751 → 736, 751, 413 | baseline start none → 2004-06-24; baseline finish none → 2004-06-28 |
| 753 | **FM 2** | 2004-03-15 → 2004-03-29 (+14d) | 2004-08-02 → 2004-08-11 (+9d) | 100d → 97d |  | 5d → 9d |  | baseline start none → 2004-03-29; baseline finish none → 2004-08-11 |
| 754 | Integrate/testSEP Central FM 2 | 2004-04-15 → 2004-05-11 (+26d) | 2004-04-15 → 2004-05-17 (+32d) | 1d → 5d |  | 68d → 43d | 417, Deliver SEP Cen FM 2 Analog/Post-Reg Board (stays at CIT for SEP Suite I&T), Deliver SEP Cen FM 2 SSD Bias Supply Board (stays at CIT for SEP Suite I&T), 377, 419 → 417, 418, 377 | baseline start none → 2004-05-11; baseline finish none → 2004-05-17 |
| 755 | Receive & inspect SEPT FM 2 | 2004-03-15 → 2004-03-29 (+14d) | 2004-03-15 → 2004-03-29 (+14d) |  |  | 91d → 78d |  | baseline start none → 2004-03-29; baseline finish none → 2004-03-29 |
| 756 | Integrate & test SEPT FM 2 | 2004-04-16 → 2004-05-18 (+32d) | 2004-04-16 → 2004-05-18 (+32d) |  |  | 68d → 43d |  | baseline start none → 2004-05-18; baseline finish none → 2004-05-18 |
| 757 | Integrate & test LET FM 2 | 2004-05-10 → 2004-06-09 (+30d) | 2004-05-10 → 2004-06-09 (+30d) |  |  | 53d → 29d |  | baseline start none → 2004-06-09; baseline finish none → 2004-06-09 |
| 758 | Receive & inspect HET FM 2 | 2004-07-16 → 2004-06-24 (-22d) | 2004-07-16 → 2004-06-24 (-22d) |  |  | 5d → 18d |  | baseline start none → 2004-06-24; baseline finish none → 2004-06-24 |
| 759 | Integrate & test HET FM 2 | 2004-07-19 → 2004-06-25 (-24d) | 2004-07-19 → 2004-06-25 (-24d) |  |  | 5d → 18d |  | baseline start none → 2004-06-25; baseline finish none → 2004-06-25 |
| 760 | Integrate SEP FM 2 - IDPU FM 2 | 2004-07-20 → 2004-06-28 (-22d) | 2004-07-20 → 2004-06-28 (-22d) |  |  | 5d → 18d |  | baseline start none → 2004-06-28; baseline finish none → 2004-06-28 |
| 761 | Test SEP FM 2 - IDPU FM 2 | 2004-07-21 → 2004-06-29 (-22d) | 2004-07-21 → 2004-06-29 (-22d) |  |  | 5d → 18d |  | baseline start none → 2004-06-29; baseline finish none → 2004-06-29 |
| 762 | Receive & inspect SIT FM 2 | 2004-07-22 → 2004-07-27 (+5d) | 2004-07-22 → 2004-07-27 (+5d) |  |  | 9d → 16d |  | baseline start none → 2004-07-27; baseline finish none → 2004-07-27 |
| 763 | Integrate & test SIT FM 2 | 2004-07-29 → 2004-08-06 (+8d) | 2004-07-29 → 2004-08-06 (+8d) |  |  | 5d → 9d | 735, Rework SEP FM 2 - IDPU FM 2 issues and retest, 762 → 735, 762, 777 | baseline start none → 2004-08-06; baseline finish none → 2004-08-06 |
| 764 | SEP FM 2 system test | 2004-08-02 → 2004-08-09 (+7d) | 2004-08-02 → 2004-08-11 (+9d) | 1d → 3d |  | 5d → 9d | 736, 763, Integrate FM 2 LVPS into SEP Central (if necessary) → 736, 763 | baseline start none → 2004-08-09; baseline finish none → 2004-08-11 |
| 765 | **Environmental Test (at JPL)** | 2004-05-03 → 2004-05-17 (+14d) | 2004-10-19 → 2004-09-24 (-25d) | 119d → 93d |  | 26d → 23d |  | baseline start none → 2004-05-17; baseline finish none → 2004-09-24 |
| 766 | Generate Environmental Test Procedures | 2004-05-03 → 2004-05-17 (+14d) | 2004-05-21 → 2004-06-07 (+17d) |  |  | 54d → 46d |  | constraint start no earlier than 2004-05-03 → start no earlier than 2004-05-17; baseline start none → 2004-05-17; baseline finish none → 2004-06-07 |
| 767 | Manufacture test cables (JPL) | 2004-05-24 → 2004-06-01 (+8d) | 2004-06-07 → 2004-06-28 (+21d) | 10d → 20d |  | 54d → 31d | 766 → none | constraint none → start no earlier than 2004-06-01; baseline start none → 2004-06-01; baseline finish none → 2004-06-28 |
| 768 | **FM 1** | 2004-08-06 → 2004-07-23 (-14d) | 2004-10-04 → 2004-09-24 (-10d) | 41d → 45d |  | 11d → 9d |  | baseline start none → 2004-07-23; baseline finish none → 2004-09-24 |
| 769 | FM 1 LET/HET/SEP Central Vibration/Acoustics Test | 2004-08-06 → 2004-07-23 (-14d) | 2004-08-19 → 2004-08-05 (-14d) |  |  | 11d → 13d | 19FS+3d, 766, 767 → 19FS+3d, 766, 767, 783FS+3d | baseline start none → 2004-07-23; baseline finish none → 2004-08-05 |
| 770 | FM 1 LET/HET/SEP Central Thermal Balance Test | 2004-08-20 → 2004-08-06 (-14d) | 2004-08-26 → 2004-08-12 (-14d) |  |  | 11d → 13d |  | baseline start none → 2004-08-06; baseline finish none → 2004-08-12 |
| 771 | FM 1 LET/HET/SEP Central T/V Test | 2004-08-27 → 2004-08-19 (-8d) | 2004-09-17 → 2004-09-09 (-8d) |  |  | 11d → 9d | 770 → 770, 776 | baseline start none → 2004-08-19; baseline finish none → 2004-09-09 |
| 772 | Evaluate SEP performance | 2004-09-20 → 2004-09-10 (-10d) | 2004-10-01 → 2004-09-23 (-8d) |  |  | 36d → 9d |  | baseline start none → 2004-09-10; baseline finish none → 2004-09-23 |
| 773 | Generate test reports | 2004-09-20 → 2004-09-10 (-10d) | 2004-10-04 → 2004-09-24 (-10d) |  |  | 36d → 9d |  | constraint none → finish no later than 2004-10-07; baseline start none → 2004-09-10; baseline finish none → 2004-09-24 |
| 774 | Bakeout Clean SEP exterior & prepare for delivery | 2004-09-20 → 2004-09-10 (-10d) | 2004-09-22 → 2004-09-14 (-8d) |  |  | 11d → 16d |  | baseline start none → 2004-09-10; baseline finish none → 2004-09-14 |
| 775 | **FM 2** | 2004-08-03 → 2004-07-23 (-11d) | 2004-10-19 → 2004-09-24 (-25d) | 54d → 45d |  | 5d → 9d |  | baseline start none → 2004-07-23; baseline finish none → 2004-09-24 |
| 776 | FM 2 EMI/EMC Test at CalTech | 2004-08-03 → 2004-08-12 (+9d) | 2004-08-09 → 2004-08-18 (+9d) |  |  | 5d → 9d |  | baseline start none → 2004-08-12; baseline finish none → 2004-08-18 |
| 777 | FM 2 LET/HET/SEP Central Vibration/Acoustics Test | 2004-08-20 → 2004-07-23 (-28d) | 2004-09-02 → 2004-08-05 (-28d) |  |  | 15d → 9d | 776, 769 → 784FS+3d | baseline start none → 2004-07-23; baseline finish none → 2004-08-05 |
| 778 | FM 2 LET/HET/SEP Central T/V Test | 2004-09-13 → 2004-08-19 (-25d) | 2004-10-01 → 2004-09-09 (-22d) |  |  | 15d → 23d | FM 2 LET/HET/SEP Central Thermal Balance Test → 776 | baseline start none → 2004-08-19; baseline finish none → 2004-09-09 |
| 779 | Evaluate SEP performance | 2004-10-04 → 2004-09-10 (-24d) | 2004-10-18 → 2004-09-23 (-25d) |  |  | 26d → 23d |  | baseline start none → 2004-09-10; baseline finish none → 2004-09-23 |
| 780 | Generate test reports | 2004-10-04 → 2004-09-10 (-24d) | 2004-10-19 → 2004-09-24 (-25d) |  |  | 26d → 23d |  | constraint none → finish no later than 2004-10-28; baseline start none → 2004-09-10; baseline finish none → 2004-09-24 |
| 781 | Bakeout Clean SEP exterior & prepare for delivery | 2004-10-04 → 2004-09-10 (-24d) | 2004-10-06 → 2004-09-14 (-22d) |  |  | 15d → 30d |  | baseline start none → 2004-09-10; baseline finish none → 2004-09-14 |
| 782 | **Accelerator Test (at MSU)** | 2004-07-15 → 2004-07-13 (-2d) | 2004-07-28 → 2004-07-19 (-9d) | 10d → 5d |  | 83d → 9d |  | baseline start none → 2004-07-13; baseline finish none → 2004-07-19 |
| 783 | FM 1 LET/SEP Cen end-to-end test at Accelerator | 2004-07-15 → 2004-07-13 (-2d) | 2004-07-28 → 2004-07-19 (-9d) | 10d → 5d |  | 83d → 9d | 789 → 789, 19, 408 | was named LET/SEP Cen end-to-end test at Accelerator; baseline start none → 2004-07-13; baseline finish none → 2004-07-19 |
| 785 | **GSE** |  | 2004-11-26 → 2004-10-15 (-42d) | 333d → 305d | 48% → 55% | 0d → 283d |  | baseline start none → 2003-08-01; baseline finish none → 2004-10-15 |
| 786 | **End-to-End Test Equipment** |  | 2004-07-14 → 2004-06-22 (-22d) | 234d → 218d | 86% → 84% | 83d → 23d |  | baseline start none → 2003-08-11; baseline finish none → 2004-06-22 |
| 787 | Design |  | 2004-06-01 → 2004-05-14 (-18d) | 203d → 192d | 90% → 95% | 83d → 23d |  | baseline start none → 2003-08-11; baseline finish none → 2004-05-14 |
| 788 | Assemble | 2004-07-01 → 2004-05-17 (-45d) | 2004-07-07 → 2004-06-15 (-22d) | 5d → 21d |  | 83d → 23d | 787FS+21d → 787 | baseline start none → 2004-05-17; baseline finish none → 2004-06-15 |
| 789 | Test | 2004-07-08 → 2004-06-16 (-22d) | 2004-07-14 → 2004-06-22 (-22d) |  |  | 83d → 23d |  | baseline start none → 2004-06-16; baseline finish none → 2004-06-22 |
| 790 | **GSE software** |  | 2004-11-26 → 2004-10-15 (-42d) | 333d → 305d | 31% → 34% | 0d → 283d |  | baseline start none → 2003-08-01; baseline finish none → 2004-10-15 |
| 791 | Build GSE software release 2 |  | 2004-01-15 → 2004-03-18 (+63d) | 114d → 157d | 70% → 66% | 14d → 306d |  | baseline start none → 2003-08-01; baseline finish none → 2004-03-18 |
| 792 | Write user's guide | 2004-02-02 → 2004-03-22 (+49d) | 2004-02-05 → 2004-03-31 (+55d) | 4d → 8d |  | 0d → 305d | none → 791 | constraint start no earlier than 2004-02-02 → start no earlier than 2004-03-22; baseline start none → 2004-03-22; baseline finish none → 2004-03-31 |
| 793 | Build GSE software release 3 | 2004-05-24 → 2004-05-03 (-21d) | 2004-11-26 → 2004-10-15 (-42d) | 130d → 117d |  | 0d → 283d | 794FS+65d → 792 | constraint none → start no earlier than 2004-05-03; baseline start none → 2004-05-03; baseline finish none → 2004-10-15 |
| 794 | Write user's guide supplement | 2004-02-06 → 2004-09-15 (+222d) | 2004-02-20 → 2004-10-15 (+238d) | 10d → 22d |  | 0d → 283d | 792, 791 → 793FS-22d | baseline start none → 2004-09-15; baseline finish none → 2004-10-15 |

## Version 3 (data date 2004-02-29, saved 2004-04-26, file IMPACT Master Schedule_31 March 2004.mpp)

Last finish 2005-11-18 → 2005-11-21 (+3d). Complete tasks 92 → 169.

Added:

| ID | Task | Duration | Start | Finish | Predecessors | Constraint |
| --- | --- | --- | --- | --- | --- | --- |
| 145 | Bakeout SEP LVPS FM 2 Boards | 3d | 2004-06-22 | 2004-06-24 | 144 |  |
| 407 | **SIT Door (Priority 10)** | 27d | 2004-05-18 | 2004-06-24 |  |  |
| 408 | Complete Design/Drawings for SIT Door | 10d | 2004-05-18 | 2004-06-01 | 401 |  |
| 409 | Fabrication | 10d | 2004-06-02 | 2004-06-15 | 408 |  |
| 410 | Inspection | 5d | 2004-06-16 | 2004-06-22 | 409 |  |
| 411 | Final Assembly | 1d | 2004-06-23 | 2004-06-23 | 410 |  |
| 412 | Deliver SIT Door (stay at GSFC for Environmental Testing) | 1d | 2004-06-24 | 2004-06-24 | 411 |  |
| 451 | Deliver HET FM 1 w/ replacement detectors (to CIT for SEP Suite I&T) | 2d | 2004-07-20 | 2004-07-21 | 499 |  |
| 453 | Deliver HET FM 2 w/ replacement detectors (to CIT for SEP Suite I&T) | 2d | 2004-07-20 | 2004-07-21 | 504, 794 |  |
| 460 | **Replacement HET Detectors (Batch 2)** | 66d | 2004-03-12 A | 2004-06-14 |  |  |
| 461 | Receive H1 Detector Mounts | 0d | 2004-03-12 A | 2004-03-12 A |  | start no earlier than 2004-03-12 |
| 462 | Receive H3 Detector Mounts | 0d | 2004-03-26 A | 2004-03-26 A |  | start no earlier than 2004-03-26 |
| 463 | Detector Mounting at Micron | 20d | 2004-04-15 | 2004-05-12 | 461, 462 | start no earlier than 2004-04-15 |
| 464 | Detector Delivery to GSFC | 2d | 2004-05-13 | 2004-05-14 | 463 |  |
| 465 | Detector Testing at GSFC | 20d | 2004-05-17 | 2004-06-14 | 464 |  |
| 486 | Design Change of HET PH Event Processing | 15d | 2004-04-05 | 2004-04-23 |  | start no earlier than 2004-04-05 |
| 497 | Receive HET FM1 from CIT | 0d | 2004-07-15 | 2004-07-15 | 792 |  |
| 498 | Install new HET Flight Detectors in FM 1 | 1d | 2004-07-16 | 2004-07-16 | 465, 497 |  |
| 499 | Performance Test FM 1 with New Flight Detectors | 1d | 2004-07-19 | 2004-07-19 | 498 |  |
| 503 | Receive HET FM2 from CIT | 0d | 2004-07-16 | 2004-07-16 | 795, 502 |  |
| 504 | Install new HET Flight Detectors in FM 2 | 1d | 2004-07-19 | 2004-07-19 | 465, 503 |  |
| 605 | Receive Analog and Digital TOF Boards (FM 2) | 20d | 2004-03-25 A | 2004-04-21 | 608 |  |
| 655 | Redesign Mother Board Layout | 17d | 2004-03-05 A | 2004-03-29 A | 654, 665 |  |
| 659 | Refabricate FM1 & FM2 Mother Boards | 15d | 2004-03-30 A | 2004-04-19 | 665, 655 |  |
| 666 | Coupon Testing of 2nd Mother Boards | 5d | 2004-04-20 | 2004-04-26 | 659 |  |
| 711 | Integrate SIT Door FM 1 | 1d | 2004-08-20 | 2004-08-20 | 595, 412 |  |
| 712 | Integrate SIT Door FM 2 | 1d | 2004-09-02 | 2004-09-02 | 598, 711 |  |
| 791 | Detach HET FM1 from SEP Suite | 1d | 2004-07-13 | 2004-07-13 | 790 |  |
| 792 | Deliver HET FM1 to GSFC for Replacement Detectors | 2d | 2004-07-14 | 2004-07-15 | 791 |  |
| 794 | Detach HET FM2 from SEP Suite | 1d | 2004-07-14 | 2004-07-14 | 791, 793SS |  |
| 795 | Deliver HET FM2 to GSFC for Replacement Detectors | 2d | 2004-07-15 | 2004-07-16 | 794, 792SS |  |

Removed: 136 Coat & Stake SIT FM 1 HVPS Boards (at UMD); 137 Retest SIT FM 1 HVPS Boards (at UMD); 163 Deliver IDPU S/W Build 3 (to UNH); 467 Bakeout HET FM 1 Electronics Board; 468 Retest Bakedout HET FM 1 Electronics Board; 473 Bakeout HET FM 2 Electronics Board; 474 Retest Bakedout HET FM 2 Electronics Board; 586 Detectors; 587 Detector Testing; 588 FM 1; 589 Test FM 1 Solid States Detectors; 590 Test FM 1 Foils; 591 Alpha Tests FM 1 w/Proto Elect; 592 FM 2; 593 Test FM 2 Solid States Detectors; 594 Test FM 2 Foils; 595 Alpha Tests FM 2 w/Proto Elect; 731 Software Support For SEP Integration; 737 Software Support For Acceptance Testing of SEP Instruments; 740 Software Support of SEP Accelerator Tests

Changed:

| ID | Task | Start | Finish | Duration | Complete | Total float | Predecessors | Other |
| --- | --- | --- | --- | --- | --- | --- | --- | --- |
| 1 | **IMPACT - Dave Curtis (UCB) & Lil Reichenthal (GSFC)** |  | 2005-11-18 → 2005-11-21 (+3d) | 698d → 699d | 50% → 63% |  |  |  |
| 2 | **Suite Deliveries to APL** | 2004-08-13 → 2004-09-21 (+39d) |  | 51d → 25d |  |  |  |  |
| 4 | FM 2 Target Delivery Date |  |  |  |  |  |  | was named FM 1 Target Delivery Date |
| 5 | Boom Suite FM 1 Ready for Delivery to APL | 2004-08-13 → 2004-09-21 (+39d) | 2004-08-13 → 2004-09-21 (+39d) |  |  | 37d → 11d |  |  |
| 6 | Boom Suite FM 2 Ready for Delivery to APL | 2004-09-28 → 2004-10-06 (+8d) | 2004-09-28 → 2004-10-06 (+8d) |  |  | 20d → 14d |  |  |
| 7 | SEP Suite FM 1 Ready for Delivery to APL | 2004-09-14 → 2004-10-12 (+28d) | 2004-09-14 → 2004-10-12 (+28d) |  |  | 16d → -3d |  |  |
| 8 | SEP Suite FM 2 Ready for Delivery to APL | 2004-10-12 → 2004-10-25 (+13d) | 2004-10-12 → 2004-10-25 (+13d) |  |  | 11d → 2d |  |  |
| 9 | **Environmental Testing - PER, Impact Suite EMC, Snapshots of Boom & SEP Suite Test Flows** |  | 2004-10-05 → 2004-10-19 (+14d) | 186d → 195d | 1% → 11% | 290d → 282d |  |  |
| 10 | **Reviews (PER and TRR's) - TRR Dates are Tentative** |  | 2004-07-08 → 2004-08-16 (+39d) | 124d → 151d | 25% → 50% | 352d → 326d |  |  |
| 13 | TRR 2 - Prior to FM 1 STE-U Thermal Vac/Thermal Balance | 2004-03-25 → 2004-04-19 A (+25d) | 2004-03-25 → 2004-04-19 A (+25d) |  | 0% → 100% | 426d → none | 21SS-5d → 21SS-6d | constraint none → start no earlier than 2004-04-19 |
| 14 | TRR 3 - Prior to FM 1 Boom Structure Vibration | 2004-04-20 → 2004-04-19 A (-1d) | 2004-04-20 → 2004-04-19 A (-1d) |  | 0% → 100% | 408d → none | 22SS-5d → 22SS-19d |  |
| 15 | TRR 4 - Prior to FM 1 IDPU Vibration | 2004-04-26 → 2004-05-26 (+30d) | 2004-04-26 → 2004-05-26 (+30d) |  |  | 404d → 383d |  |  |
| 16 | TRR 5 - Prior to FM 1 SWEA Vibration | 2004-05-28 → 2004-06-29 (+32d) | 2004-05-28 → 2004-06-29 (+32d) |  |  | 380d → 360d |  |  |
| 17 | TRR 6 - Prior to FM 1 Impact Suite EMC (for Boom and SEP) | 2004-06-22 → 2004-07-28 (+36d) | 2004-06-22 → 2004-07-28 (+36d) |  |  | 364d → 339d |  |  |
| 18 | TRR 7 - Prior to FM 1 SIT Vibration | 2004-07-08 → 2004-08-16 (+39d) | 2004-07-08 → 2004-08-16 (+39d) |  |  | 352d → 326d |  |  |
| 19 | IMPACT Suite FM 1 EMC Testing at UCB | 2004-06-29 → 2004-08-04 (+36d) | 2004-07-12 → 2004-08-17 (+36d) |  |  | 9d → -8d |  |  |
| 20 | **Boom Suite FM 1 Environmental Test Flow Snapshot - UCB** | 2004-04-01 → 2004-04-26 (+25d) | 2004-07-30 → 2004-09-07 (+39d) | 86d → 95d |  | 336d → 311d |  |  |
| 21 | STE-U Thermal Vac/Thermal Balance/Bake Out | 2004-04-01 → 2004-04-26 (+25d) | 2004-04-20 → 2004-05-13 (+23d) |  |  | 408d → 392d |  |  |
| 22 | Boom Structure Vibration | 2004-04-27 → 2004-05-14 (+17d) | 2004-04-30 → 2004-05-19 (+19d) |  |  | 400d → 388d |  |  |
| 23 | IDPU Vibration | 2004-05-03 → 2004-06-03 (+31d) | 2004-05-07 → 2004-06-09 (+33d) |  |  | 395d → 374d |  |  |
| 24 | Boom Structure Thermal Vac & Bake Out | 2004-05-03 → 2004-05-20 (+17d) | 2004-05-21 → 2004-06-10 (+20d) |  |  | 385d → 373d |  |  |
| 25 | IDPU Thermal Vac & Bake Out | 2004-05-10 → 2004-06-10 (+31d) | 2004-05-21 → 2004-06-23 (+33d) |  |  | 385d → 364d |  |  |
| 26 | SWEA/STE Vibration | 2004-06-07 → 2004-07-06 (+29d) | 2004-06-11 → 2004-07-12 (+31d) |  |  | 371d → 351d |  |  |
| 27 | SWEA/STE Thermal Vac/Thermal Balance/Bake Out | 2004-07-13 → 2004-08-18 (+36d) | 2004-07-30 → 2004-09-07 (+39d) |  |  | 336d → 311d |  |  |
| 28 | **Boom Suite FM 2 Environmental Test Flow Snapshot - UCB** | 2004-04-27 → 2004-06-16 (+50d) | 2004-09-14 → 2004-09-22 (+8d) | 99d → 70d |  | 305d → 300d |  |  |
| 29 | STE-U Thermal Vac/Bake Out | 2004-04-27 → 2004-06-16 (+50d) | 2004-05-10 → 2004-06-29 (+50d) |  |  | 394d → 360d |  |  |
| 30 | IDPU Vibration | 2004-05-10 → 2004-07-15 (+66d) | 2004-05-14 → 2004-07-21 (+68d) |  |  | 390d → 344d |  |  |
| 31 | Boom Structure Vibration | 2004-05-17 → 2004-07-06 (+50d) | 2004-05-20 → 2004-07-09 (+50d) |  |  | 386d → 352d |  |  |
| 32 | IDPU Thermal Vac & Bake Out | 2004-05-17 → 2004-07-22 (+66d) | 2004-05-28 → 2004-08-04 (+68d) |  |  | 380d → 334d |  |  |
| 33 | Boom Structure Thermal Vac & Bake Out | 2004-05-24 → 2004-07-12 (+49d) | 2004-06-14 → 2004-07-30 (+46d) |  |  | 370d → 337d |  |  |
| 34 | SWEA/STE Vibration | 2004-08-09 → 2004-08-17 (+8d) | 2004-08-13 → 2004-08-23 (+10d) |  |  | 326d → 321d |  |  |
| 35 | SWEA/STE Thermal Vac & Bake Out | 2004-08-16 → 2004-08-24 (+8d) | 2004-08-27 → 2004-09-07 (+11d) |  |  | 316d → 311d |  |  |
| 36 | Boom Suite FM 2 EMC | 2004-09-08 → 2004-09-16 (+8d) | 2004-09-14 → 2004-09-22 (+8d) |  |  | 305d → 300d |  |  |
| 37 | **SEP Suite FM 1 Environmental Test Flow Snapshot** | 2004-02-17 → 2004-02-19 A (+2d) | 2004-09-14 → 2004-10-07 (+23d) | 149d → 164d | 0% → 19% | 305d → 289d |  |  |
| 38 | SEPT (NS & E) Vibration (in Europe) | 2004-02-17 → 2004-02-19 A (+2d) | 2004-02-24 A | 8d → 4d | 0% → 100% | 450d → none | 568SS, 575FF → 568SS |  |
| 39 | SEPT (NS & E) Thermal Vac (in Europe) | 2004-02-25 → 2004-02-27 A (+2d) | 2004-03-08 → 2004-03-12 A (+4d) | 9d → 11d | 0% → 100% | 439d → none |  |  |
| 40 | SEPT (NS & E) Bake Out (in Europe) | 2004-03-09 → 2004-03-05 A (-4d) | 2004-03-10 → 2004-03-08 A (-2d) |  | 0% → 100% | 437d → none |  |  |
| 41 | SEPT (NS & E) Thermal Balance (at GSFC) | 2004-07-13 → 2004-08-18 (+36d) | 2004-07-26 → 2004-08-31 (+36d) |  |  | 340d → 315d |  |  |
| 42 | LET/HET/SEP Cen Accelerator Test (at MSU) | 2004-07-13 → 2004-07-10 (-3d) | 2004-07-27 → 2004-07-12 (-15d) | 11d → 3d |  | 339d → 355d |  |  |
| 43 | SIT Vibe and Acoustics (at GSFC) | 2004-07-15 → 2004-08-23 (+39d) | 2004-07-28 → 2004-09-03 (+37d) |  |  | 338d → 312d |  |  |
| 44 | LET/HET/SEP Cen Vibe and Acoustics (at JPL) | 2004-07-23 → 2004-08-23 (+31d) | 2004-08-05 → 2004-09-03 (+29d) |  |  | 332d → 312d |  |  |
| 45 | SIT Thermal Balance (at GSFC) | 2004-07-30 → 2004-09-08 (+40d) | 2004-08-05 → 2004-09-14 (+40d) |  |  | 332d → 306d |  |  |
| 46 | LET/HET/SEP Cen Thermal Balance (at JPL) | 2004-08-06 → 2004-09-07 (+32d) | 2004-08-12 → 2004-09-13 (+32d) |  |  | 327d → 307d |  |  |
| 47 | SIT Thermal Vac (at GSFC) | 2004-08-06 → 2004-09-15 (+40d) | 2004-08-19 → 2004-09-28 (+40d) |  |  | 322d → 296d |  |  |
| 48 | LET/HET/SEP Cen Thermal Vac (at JPL) | 2004-08-19 → 2004-09-14 (+26d) | 2004-09-09 → 2004-10-04 (+25d) |  |  | 308d → 292d |  |  |
| 49 | SIT Bake Out (at GSFC) | 2004-08-24 → 2004-10-01 (+38d) | 2004-08-26 → 2004-10-05 (+40d) |  |  | 317d → 291d |  |  |
| 50 | LET/HET/SEP Cen Bake Out (at JPL) | 2004-09-10 → 2004-10-05 (+25d) | 2004-09-14 → 2004-10-07 (+23d) |  |  | 305d → 289d |  |  |
| 51 | **SEP Suite FM 2 Environmental Test Flow Snapshot** | 2004-02-17 → 2004-02-19 A (+2d) | 2004-10-05 → 2004-10-19 (+14d) | 164d → 171d | 0% → 17% | 290d → 282d |  |  |
| 52 | SEPT (NS & E) Vibe and Acoustics (in Europe) | 2004-02-17 → 2004-02-19 A (+2d) | 2004-02-24 A | 8d → 4d | 0% → 100% | 450d → none | 583SS, 589FF → 583SS |  |
| 53 | SEPT (NS & E) Thermal Vac (in Europe) | 2004-03-09 → 2004-03-05 A (-4d) | 2004-03-17 A |  | 0% → 100% | 432d → none |  |  |
| 54 | SEPT (NS & E) Bake Out (in Europe) | 2004-03-18 → 2004-03-12 A (-6d) | 2004-03-19 → 2004-03-15 A (-4d) |  | 0% → 100% | 430d → none |  |  |
| 56 | LET/HET/SEP Cen Vibe and Acoustics (at JPL) | 2004-07-23 → 2004-08-31 (+39d) | 2004-08-05 → 2004-09-14 (+40d) |  |  | 332d → 306d |  |  |
| 57 | SEP Suite FM 2 EMC (at Caltech) | 2004-08-12 → 2004-08-24 (+12d) | 2004-08-18 → 2004-08-30 (+12d) |  |  | 323d → 316d |  |  |
| 58 | LET/HET/SEP Cen Thermal Vac (at JPL) | 2004-08-19 → 2004-09-15 (+27d) | 2004-09-09 → 2004-10-05 (+26d) |  |  | 308d → 291d |  |  |
| 59 | SIT Vibe and Acoustics (at GSFC) | 2004-08-23 → 2004-09-03 (+11d) | 2004-09-03 → 2004-09-17 (+14d) |  |  | 311d → 303d |  |  |
| 60 | SIT Thermal Balance (at GSFC) | 2004-09-08 → 2004-09-21 (+13d) | 2004-09-14 → 2004-09-27 (+13d) |  |  | 305d → 297d |  |  |
| 61 | LET/HET/SEP Cen Bake Out (at JPL) | 2004-09-10 → 2004-10-06 (+26d) | 2004-09-14 → 2004-10-08 (+24d) |  |  | 305d → 288d |  |  |
| 62 | SIT Thermal Vac (at GSFC) | 2004-09-15 → 2004-09-28 (+13d) | 2004-09-28 → 2004-10-12 (+14d) |  |  | 295d → 287d |  |  |
| 63 | SIT Bake Out (at GSFC) | 2004-10-01 → 2004-10-15 (+14d) | 2004-10-05 → 2004-10-19 (+14d) |  |  | 290d → 282d |  |  |
| 64 | **Power Converters - UCB** |  | 2004-06-23 → 2004-07-07 (+14d) | 335d → 345d | 57% → 67% | 363d → 37d |  |  |
| 65 | **Deliveries** |  | 2004-04-30 → 2004-07-07 (+68d) | 100d → 147d |  | 49d → 37d |  |  |
| 66 | **FM 1** |  | 2004-04-23 → 2004-05-25 (+32d) | 95d → 117d |  | 25d → 15d |  |  |
| 67 | Deliver IDPU FM 1 LVPS (stays at UCB) | 2004-04-23 → 2004-05-25 (+32d) | 2004-04-23 → 2004-05-25 (+32d) |  |  | 25d → 15d |  |  |
| 68 | Deliver SEP FM 1 LVPS (to Caltech) | 2004-04-06 → 2004-05-03 (+27d) | 2004-04-06 → 2004-05-03 (+27d) |  |  | 36d → 16d |  |  |
| 69 | Deliver SWEA/STE FM 1 LVPS (stays at UCB) | 2004-04-15 → 2004-04-16 (+1d) | 2004-04-15 → 2004-04-16 (+1d) |  |  | 9d → 22d |  |  |
| 70 | Deliver PLASTIC FM 1 LVPS (to UNH) | 2004-03-24 → 2004-05-17 (+54d) | 2004-03-25 → 2004-05-18 (+54d) |  |  | 28d → 16d |  | constraint finish no later than 2004-05-04 → finish no later than 2004-06-10 |
| 72 | **FM 2** | 2004-04-12 → 2004-05-21 (+39d) | 2004-04-30 → 2004-07-07 (+68d) | 15d → 33d |  | 31d → 2d |  |  |
| 73 | Deliver IDPU FM 2 LVPS (stays at UCB) | 2004-04-30 → 2004-07-07 (+68d) | 2004-04-30 → 2004-07-07 (+68d) |  |  |  |  |  |
| 74 | Deliver SEP FM 2 LVPS (to Caltech) | 2004-04-19 → 2004-06-25 (+67d) | 2004-04-19 → 2004-06-25 (+67d) |  |  | 27d → 37d | 144 → 145 |  |
| 75 | Deliver SWEA/STE FM 2 LVPS (stays at UCB) | 2004-04-26 → 2004-05-28 (+32d) | 2004-04-26 → 2004-05-28 (+32d) |  |  | 53d → 29d |  |  |

| ID | Task | Start | Finish | Duration | Complete | Total float | Predecessors | Other |
| --- | --- | --- | --- | --- | --- | --- | --- | --- |
| 76 | Deliver PLASTIC FM 2 LVPS (to UNH) | 2004-04-12 → 2004-06-28 (+77d) | 2004-04-13 → 2004-06-29 (+77d) |  |  | 41d → 16d |  | constraint finish no later than 2004-06-10 → finish no later than 2004-07-21 |
| 77 | Deliver SIT FM 2 HVPS (to UMD) | 2004-04-12 → 2004-05-21 (+39d) | 2004-04-13 → 2004-05-24 (+41d) |  |  | 31d → 2d |  |  |
| 78 | **Remaining Flight Procurements** |  | 2004-02-19 → 2004-03-12 A (+22d) | 79d → 95d | 75% → 100% | 25d → none |  |  |
| 79 | Procure IDPU Flight Printed Wiring Board | 2004-02-05 → 2004-03-01 A (+25d) | 2004-02-19 → 2004-03-12 A (+22d) |  | 0% → 100% | 25d → none |  | constraint start no earlier than 2004-02-05 → start no earlier than 2004-03-01 |
| 99 | **Assembly** |  | 2004-03-19 → 2004-06-02 (+75d) | 57d → 109d | 27% → 55% | 49d → 37d |  |  |
| 100 | **FM 1** |  | 2004-03-12 → 2004-04-20 (+39d) | 52d → 79d | 51% → 89% | 25d → 15d |  |  |
| 101 | Assemble IDPU FM 1 LVPS | 2004-02-26 → 2004-04-05 (+39d) | 2004-03-12 → 2004-04-20 (+39d) |  |  | 25d → 15d | 89, 113 → 89, 113FS+2d |  |
| 102 | Assemble SEP FM 1 LVPS |  | 2004-02-23 → 2004-03-09 A (+15d) | 29d → 40d | 48% → 100% | 36d → none |  |  |
| 103 | Assemble SWEA FM 1 LVPS | 2004-02-13 A | 2004-03-04 → 2004-03-26 A (+22d) | 14d → 30d | 0% → 100% | 9d → none |  |  |
| 105 | **FM 2** | 2004-02-09 → 2004-03-29 A (+49d) | 2004-03-19 → 2004-06-02 (+75d) | 29d → 47d | 0% → 4% | 31d → 37d |  |  |
| 106 | Assemble IDPU FM 2 LVPS | 2004-03-01 → 2004-05-12 (+72d) | 2004-03-19 → 2004-06-02 (+75d) |  |  |  | 95 → 95, 119 |  |
| 107 | Assemble SEP FM 2 LVPS | 2004-02-13 → 2004-04-26 (+73d) | 2004-03-05 → 2004-05-14 (+70d) |  |  | 27d → 37d | 96 → 96, 123FS+5d |  |
| 108 | Assemble SWEA FM 2 LVPS | 2004-02-24 → 2004-04-05 (+41d) | 2004-03-15 → 2004-04-23 (+39d) |  |  | 53d → 29d | 97 → 97, 127 |  |
| 109 | Assemble PLASTIC FM 2 LVPS | 2004-02-09 → 2004-05-03 (+84d) | 2004-02-27 → 2004-05-20 (+83d) |  |  | 41d → 16d | 98 → 98, 131 |  |
| 110 | Assemble SIT FM 2 HVPS | 2004-02-09 → 2004-03-29 A (+49d) | 2004-02-27 → 2004-04-15 (+48d) |  | 0% → 21% | 31d → 2d | 94 → 94, 103 |  |
| 111 | **Testing** |  | 2004-06-23 → 2004-07-07 (+14d) | 162d → 172d | 12% → 26% | 363d → 37d |  |  |
| 112 | **FM 1 & FM 2** |  | 2004-02-25 → 2004-03-31 A (+35d) | 63d → 88d | 80% → 100% | 25d → none |  |  |
| 113 | Coupon Test IDPU Flight Printed Wiring Board | 2004-02-20 → 2004-03-26 A (+35d) | 2004-02-25 → 2004-03-31 A (+35d) |  | 0% → 100% | 25d → none | 79 → 79FS+9d |  |
| 117 | **FM 1** |  | 2004-06-23 → 2004-05-25 (-29d) | 162d → 142d | 16% → 37% | 363d → 15d |  |  |
| 118 | **IDPU** | 2004-03-15 → 2004-04-21 (+37d) | 2004-04-23 → 2004-05-25 (+32d) | 30d → 25d |  | 25d → 15d |  |  |
| 119 | Test IDPU FM 1 LVPS | 2004-03-15 → 2004-04-21 (+37d) | 2004-04-02 → 2004-05-11 (+39d) |  |  | 25d → 15d |  |  |
| 120 | Coat & Stake IDPU LVPS FM 1 Boards | 2004-04-05 → 2004-05-12 (+37d) | 2004-04-09 → 2004-05-18 (+39d) |  |  | 25d → 15d |  |  |
| 121 | Retest IDPU LVPS FM 1 Boards | 2004-04-12 → 2004-05-19 (+37d) | 2004-04-23 → 2004-05-25 (+32d) | 10d → 5d |  | 25d → 15d |  |  |
| 122 | **SEP** | 2004-02-24 → 2004-03-10 A (+15d) | 2004-04-05 → 2004-04-30 (+25d) | 30d → 38d | 0% → 42% | 36d → 16d |  |  |
| 123 | Test SEP FM 1 LVPS | 2004-02-24 → 2004-03-10 A (+15d) | 2004-03-15 → 2004-04-16 (+32d) | 15d → 28d | 0% → 57% | 36d → 16d |  |  |
| 124 | Coat & Stake SEP LVPS FM 1 Boards | 2004-03-16 → 2004-04-19 (+34d) | 2004-03-22 → 2004-04-23 (+32d) |  |  | 36d → 16d |  |  |
| 125 | Retest SEP LVPS FM 1 Boards | 2004-03-23 → 2004-04-26 (+34d) | 2004-04-05 → 2004-04-30 (+25d) | 10d → 5d |  | 36d → 16d |  |  |
| 126 | **SWEA** | 2004-03-05 → 2004-03-15 A (+10d) | 2004-04-15 → 2004-04-16 (+1d) | 30d → 25d | 0% → 52% | 9d → 22d |  |  |
| 127 | Test SWEA FM 1 LVPS | 2004-03-05 → 2004-03-15 A (+10d) | 2004-03-25 → 2004-04-02 (+8d) |  | 0% → 87% | 9d → 22d |  |  |
| 128 | Coat & Stake SWEA LVPS FM 1 Boards | 2004-03-26 → 2004-04-05 (+10d) | 2004-04-01 → 2004-04-09 (+8d) |  |  | 9d → 22d |  |  |
| 129 | Retest SWEA LVPS FM 1 Boards | 2004-04-02 → 2004-04-12 (+10d) | 2004-04-15 → 2004-04-16 (+1d) | 10d → 5d |  | 9d → 22d |  |  |
| 130 | **PLASTIC** | 2004-02-10 A | 2004-03-23 → 2004-05-14 (+52d) | 30d → 68d | 0% → 19% | 28d → 16d |  |  |
| 131 | Test PLASTIC FM 1 LVPS | 2004-02-10 A | 2004-03-02 → 2004-04-30 (+59d) | 15d → 58d | 0% → 22% | 28d → 16d |  |  |
| 132 | Coat & Stake PLASTIC LVPS FM 1 Boards | 2004-03-03 → 2004-05-03 (+61d) | 2004-03-09 → 2004-05-07 (+59d) |  |  | 28d → 16d |  |  |
| 133 | Retest PLASTIC LVPS FM 1 Boards | 2004-03-10 → 2004-05-10 (+61d) | 2004-03-23 → 2004-05-14 (+52d) | 10d → 5d |  | 28d → 16d |  |  |
| 134 | **SIT** |  | 2004-06-23 → 2003-12-08 A (-198d) | 162d → 25d | 63% → 100% | 363d → none |  |  |
| 136 | **FM 2** | 2004-03-01 → 2004-04-16 (+46d) | 2004-04-30 → 2004-07-07 (+68d) | 45d → 58d |  | 31d → 2d |  |  |
| 137 | **IDPU** | 2004-03-22 → 2004-06-03 (+73d) | 2004-04-30 → 2004-07-07 (+68d) | 30d → 25d |  |  |  |  |
| 138 | Test IDPU FM 2 LVPS | 2004-03-22 → 2004-06-03 (+73d) | 2004-04-09 → 2004-06-23 (+75d) |  |  |  |  |  |
| 139 | Coat & Stake IDPU LVPS FM 2 Boards | 2004-04-12 → 2004-06-24 (+73d) | 2004-04-16 → 2004-06-30 (+75d) |  |  |  |  |  |
| 140 | Retest IDPU LVPS FM 2 Boards | 2004-04-19 → 2004-07-01 (+73d) | 2004-04-30 → 2004-07-07 (+68d) | 10d → 5d |  |  |  |  |
| 141 | **SEP** | 2004-03-08 → 2004-05-17 (+70d) | 2004-04-16 → 2004-06-24 (+69d) | 30d → 28d |  | 27d → 37d |  |  |
| 142 | Test SEP FM 2 LVPS | 2004-03-08 → 2004-05-17 (+70d) | 2004-03-26 → 2004-06-07 (+73d) |  |  | 27d → 37d |  |  |
| 143 | Coat & Stake SEP LVPS FM 2 Boards | 2004-03-29 → 2004-06-08 (+71d) | 2004-04-02 → 2004-06-14 (+73d) |  |  | 27d → 37d |  |  |
| 144 | Retest SEP LVPS FM 2 Boards | 2004-04-05 → 2004-06-15 (+71d) | 2004-04-16 → 2004-06-21 (+66d) | 10d → 5d |  | 27d → 37d |  |  |
| 146 | **SWEA** | 2004-03-16 → 2004-04-26 (+41d) | 2004-04-26 → 2004-05-28 (+32d) | 30d → 25d |  | 53d → 29d |  |  |
| 147 | Test SWEA FM 2 LVPS | 2004-03-16 → 2004-04-26 (+41d) | 2004-04-05 → 2004-05-14 (+39d) |  |  | 53d → 29d |  |  |
| 148 | Coat & Stake SWEA LVPS FM 2 Boards | 2004-04-06 → 2004-05-17 (+41d) | 2004-04-12 → 2004-05-21 (+39d) |  |  | 53d → 29d |  |  |
| 149 | Retest SWEA LVPS FM 2 Boards | 2004-04-13 → 2004-05-24 (+41d) | 2004-04-26 → 2004-05-28 (+32d) | 10d → 5d |  | 53d → 29d |  |  |
| 150 | **PLASTIC** | 2004-03-01 → 2004-05-21 (+81d) | 2004-04-09 → 2004-06-25 (+77d) | 30d → 25d |  | 41d → 16d |  |  |
| 151 | Test PLASTIC FM 2 LVPS | 2004-03-01 → 2004-05-21 (+81d) | 2004-03-19 → 2004-06-11 (+84d) |  |  | 41d → 16d |  |  |
| 152 | Coat & Stake PLASTIC LVPS FM 2 Boards | 2004-03-22 → 2004-06-14 (+84d) | 2004-03-26 → 2004-06-18 (+84d) |  |  | 41d → 16d |  |  |
| 153 | Retest PLASTIC LVPS FM 2 Boards | 2004-03-29 → 2004-06-21 (+84d) | 2004-04-09 → 2004-06-25 (+77d) | 10d → 5d |  | 41d → 16d |  |  |
| 154 | **SIT** | 2004-03-01 → 2004-04-16 (+46d) | 2004-04-09 → 2004-05-20 (+41d) | 30d → 25d |  | 31d → 2d |  |  |
| 155 | Test SIT FM 2 HVPS | 2004-03-01 → 2004-04-16 (+46d) | 2004-03-19 → 2004-05-06 (+48d) |  |  | 31d → 2d |  |  |
| 156 | Coat & Stake SIT FM 2 HVPS Boards | 2004-03-22 → 2004-05-07 (+46d) | 2004-03-26 → 2004-05-13 (+48d) |  |  | 31d → 2d |  |  |
| 157 | Retest SIT FM 2 HVPS Boards | 2004-03-29 → 2004-05-14 (+46d) | 2004-04-09 → 2004-05-20 (+41d) | 10d → 5d |  | 31d → 2d |  |  |
| 158 | **IDPU - UCB** |  |  |  | 69% → 76% | 310d → 14d |  |  |
| 159 | **Deliveries** | 2004-04-13 → 2004-06-23 (+71d) | 2004-05-28 → 2004-08-04 (+68d) | 33d → 30d |  | 53d → 15d |  |  |
| 160 | IDPU FM 1 Complete (to UCB for Boom I&T, then to CIT for SEP I&T, Suite EMC, BO & Final Boom I&T) | 2004-05-21 → 2004-06-23 (+33d) | 2004-05-21 → 2004-06-23 (+33d) |  |  | 25d → 15d |  |  |
| 161 | IDPU FM 2 Complete (to CIT for SEP I&T, then to UCB for Boom I&T, Boom EMC, BO & Final Boom I&T) | 2004-05-28 → 2004-08-04 (+68d) | 2004-05-28 → 2004-08-04 (+68d) |  |  |  |  |  |
| 162 | **Flight Software** |  | 2004-04-13 → 2004-05-13 (+30d) | 237d → 259d | 83% → 90% | 60d → 85d |  |  |
| 164 | IDPU S/W Build #3 (also goes to UNH) |  | 2004-04-13 → 2004-05-13 (+30d) | 165d → 187d | 69% → 83% | 60d → 85d |  | was named IDPU S/W Build #3 |
| 165 | **GSE** |  |  |  | 65% → 72% | 310d → 0d |  |  |
| 167 | SWEA Science Display |  | 2004-02-23 → 2004-03-01 A (+7d) | 162d → 167d | 91% → 100% | 449d → none |  |  |
| 168 | GSE Continued Development (LOE) |  |  |  | 47% → 54% | 310d → 0d |  | was named GSE Continued Development; constraint start no earlier than 2003-07-15 → must start on 2003-07-15 |
| 169 | **Integration & Test** |  | 2004-05-28 → 2004-08-04 (+68d) | 162d → 209d |  |  |  |  |
| 172 | **FM 1** | 2004-04-26 → 2004-05-26 (+30d) | 2004-05-21 → 2004-06-23 (+33d) |  |  | 25d → 15d |  |  |
| 173 | IDPU FM 1 I & T | 2004-04-26 → 2004-05-26 (+30d) | 2004-04-30 → 2004-06-02 (+33d) |  |  | 25d → 15d |  |  |
| 174 | IDPU FM 1 Vibration | 2004-05-03 → 2004-06-03 (+31d) | 2004-05-07 → 2004-06-09 (+33d) |  |  | 25d → 15d |  |  |

| ID | Task | Start | Finish | Duration | Complete | Total float | Predecessors | Other |
| --- | --- | --- | --- | --- | --- | --- | --- | --- |
| 175 | IDPU FM 1 Thermal Vacuum & Bake Out | 2004-05-10 → 2004-06-10 (+31d) | 2004-05-21 → 2004-06-23 (+33d) |  |  | 25d → 15d |  |  |
| 176 | **FM 2** | 2004-05-03 → 2004-07-08 (+66d) | 2004-05-28 → 2004-08-04 (+68d) |  |  |  |  |  |
| 177 | IDPU FM 2 I & T | 2004-05-03 → 2004-07-08 (+66d) | 2004-05-07 → 2004-07-14 (+68d) |  |  |  |  |  |
| 178 | IDPU FM 2 Vibration | 2004-05-10 → 2004-07-15 (+66d) | 2004-05-14 → 2004-07-21 (+68d) |  |  |  |  |  |
| 179 | IDPU FM 2 Thermal Vacuum & Bake Out | 2004-05-17 → 2004-07-22 (+66d) | 2004-05-28 → 2004-08-04 (+68d) |  |  |  |  |  |
| 180 | **BOOM Suite - UCB** |  | 2004-09-28 → 2004-10-06 (+8d) | 315d → 321d | 67% → 76% | 20d → 14d |  |  |
| 181 | **BOOM Structure - UCB** |  | 2004-06-18 → 2004-08-05 (+48d) | 195d → 229d | 73% → 86% | 70d → 36d |  |  |
| 182 | **Deliveries** |  | 2004-06-18 → 2004-08-05 (+48d) | 112d → 146d |  | 70d → 36d |  |  |
| 184 | Deliver Boom Structure FM 1 (stays at UCB for Boom Suite FM 1 I&T) | 2004-05-27 → 2004-06-16 (+20d) | 2004-05-27 → 2004-06-16 (+20d) |  |  | 19d → 20d |  |  |
| 185 | Deliver Boom Structure FM 2 (stays at UCB for Boom Suite FM 2 I&T) | 2004-06-18 → 2004-08-05 (+48d) | 2004-06-18 → 2004-08-05 (+48d) |  |  | 70d → 36d |  |  |
| 192 | **FM 1** |  | 2004-05-27 → 2004-06-16 (+20d) | 167d → 180d | 65% → 82% | 19d → 20d |  |  |
| 193 | **Telescoping** |  | 2004-02-29 A |  | 86% → 100% | 26d → none |  |  |
| 194 | **Fabrication, Assembly & Test** |  | 2004-02-29 A |  | 86% → 100% | 26d → none |  |  |
| 197 | Assemble FM 1 Boom Structure Telescoping Assembly | 2004-02-23 A | 2004-02-27 A |  | 0% → 100% | 24d → none |  |  |
| 198 | Test FM 1 Boom Structure Telescoping Assembly | 2004-02-28 A | 2004-02-29 A |  | 0% → 100% | 28d → none |  |  |
| 199 | **Harness** |  | 2004-03-08 A |  | 76% → 100% | 20d → none |  |  |
| 200 | **Fabrication** |  | 2004-02-27 A |  | 82% → 100% | 18d → none |  |  |
| 201 | Machine FM 1 Harness Parts |  | 2004-02-27 A |  | 82% → 100% | 18d → none |  |  |
| 202 | **Assembly & Test** | 2004-03-01 A | 2004-03-08 A |  | 0% → 100% | 18d → none |  |  |
| 203 | Assemble FM 1 Harness subassembly | 2004-03-01 A | 2004-03-07 A |  | 0% → 100% | 20d → none |  |  |
| 204 | FM1 Harness Test | 2004-03-08 A | 2004-03-08 A |  | 0% → 100% | 20d → none |  |  |
| 208 | **Integration & Test** | 2004-03-09 → 2004-03-15 A (+6d) | 2004-05-27 → 2004-06-16 (+20d) | 58d → 67d | 0% → 22% | 19d → 20d |  |  |
| 209 | Integrate FM 1 Boom Structure subassemblies & Harness Completion | 2004-03-09 → 2004-03-15 A (+6d) | 2004-04-05 → 2004-04-16 (+11d) | 20d → 25d | 0% → 52% | 20d → 25d | 198, 204 → 198, 204FS+5d |  |
| 210 | FM 1 Boom Structure Deployment Test | 2004-04-06 → 2004-04-19 (+13d) | 2004-04-19 → 2004-04-30 (+11d) |  |  | 20d → 25d |  |  |
| 211 | FM 1 Boom Structure Vibration Test | 2004-04-27 → 2004-05-14 (+17d) | 2004-04-30 → 2004-05-19 (+19d) |  |  | 19d → 20d |  |  |
| 212 | FM 1 Boom Structure Themal Vac & Bake Out | 2004-05-03 → 2004-05-20 (+17d) | 2004-05-21 → 2004-06-10 (+20d) |  |  | 19d → 20d |  |  |
| 213 | FM 1 Boom Structure Post Environmental Deployment Test | 2004-05-24 → 2004-06-11 (+18d) | 2004-05-27 → 2004-06-16 (+20d) |  |  | 19d → 20d |  |  |
| 214 | **FM 2** |  | 2004-06-18 → 2004-08-05 (+48d) | 182d → 216d | 65% → 82% | 70d → 36d |  |  |
| 215 | **Telescoping** |  | 2004-03-16 → 2004-03-02 A (-14d) | 88d → 78d | 88% → 100% | 80d → none |  |  |
| 216 | **Fabrication, Assembly & Test** |  | 2004-03-16 → 2004-03-02 A (-14d) | 88d → 78d | 88% → 100% | 80d → none |  |  |
| 219 | Assemble FM 2 Boom Structure Telescoping Assembly | 2004-02-23 A | 2004-02-27 A |  | 0% → 100% | 80d → none |  |  |
| 220 | Test FM 2 Boom Structure Telescoping Assembly | 2004-03-15 → 2004-03-01 A (-14d) | 2004-03-16 → 2004-03-02 A (-14d) |  | 0% → 100% | 80d → none | 219FS+10d → 219 |  |
| 221 | **Harness** |  | 2004-03-16 → 2004-03-09 A (-7d) | 115d → 110d | 73% → 100% | 80d → none |  |  |
| 222 | **Fabrication** |  | 2004-02-27 A |  | 82% → 100% | 80d → none |  |  |
| 223 | Machine FM 2 Harness Parts |  | 2004-02-27 A |  | 82% → 100% | 80d → none |  |  |
| 224 | **Assembly & Test** | 2004-03-01 A | 2004-03-16 → 2004-03-09 A (-7d) | 12d → 7d | 0% → 100% | 80d → none |  |  |
| 225 | Assemble FM 2 Harness subassembly | 2004-03-01 A | 2004-03-15 → 2004-03-08 A (-7d) | 11d → 6d | 0% → 100% | 80d → none |  |  |
| 226 | FM 2 Harness Test | 2004-03-16 → 2004-03-09 A (-7d) | 2004-03-16 → 2004-03-09 A (-7d) |  | 0% → 100% | 80d → none |  |  |
| 230 | **Integration & Test** | 2004-03-17 → 2004-03-29 A (+12d) | 2004-06-18 → 2004-08-05 (+48d) | 67d → 93d | 0% → 6% | 70d → 36d |  |  |
| 231 | Integrate FM 2 Boom Structure subassemblies & Harness Completion | 2004-03-17 → 2004-03-29 A (+12d) | 2004-04-13 → 2004-04-16 (+3d) | 20d → 15d | 0% → 20% | 80d → 77d | 220, 226 → 220, 226, 209SS+10d |  |
| 232 | FM 2 Boom Structure Deployment Test | 2004-04-14 → 2004-04-19 (+5d) | 2004-04-27 → 2004-04-30 (+3d) |  |  | 80d → 77d |  |  |
| 233 | FM 2 Boom Structure Vibration Test | 2004-05-17 → 2004-07-06 (+50d) | 2004-05-20 → 2004-07-09 (+50d) |  |  | 71d → 36d |  |  |
| 234 | FM 2 Boom Structure Themal Vac & Bake Out | 2004-05-24 → 2004-07-12 (+49d) | 2004-06-14 → 2004-07-30 (+46d) |  |  | 70d → 36d |  |  |
| 235 | FM 2 Boom Structure Post Environmental Deployment Test | 2004-06-15 → 2004-08-02 (+48d) | 2004-06-18 → 2004-08-05 (+48d) |  |  | 70d → 36d |  |  |
| 236 | **MAG - GSFC** | 2004-02-20 A | 2004-03-29 → 2004-05-10 (+42d) | 27d → 57d | 0% → 55% | 35d → 71d |  |  |
| 237 | **Deliveries** | 2004-03-26 → 2004-04-23 (+28d) | 2004-03-29 → 2004-05-10 (+42d) | 2d → 12d |  | 35d → 29d |  |  |
| 238 | Deliver MAG FM 1 (to UCB for IDPU/BOOM Suite FM 1 I&T) | 2004-03-26 → 2004-04-23 (+28d) | 2004-03-29 → 2004-04-26 (+28d) |  |  | 35d → 29d |  |  |
| 239 | Deliver MAG FM 2 (to UCB for IDPU/BOOM Suite FM 2 I&T) | 2004-03-26 → 2004-05-07 (+42d) | 2004-03-29 → 2004-05-10 (+42d) |  |  | 61d → 71d |  |  |
| 240 | **FM 1** | 2004-02-20 A | 2004-03-25 → 2004-04-22 (+28d) | 25d → 45d | 0% → 62% | 35d → 29d |  |  |
| 241 | FM 1 MAG Testing | 2004-02-20 A | 2004-03-04 → 2004-03-18 A (+14d) | 10d → 20d | 0% → 100% | 35d → none |  |  |
| 242 | MAG FM 1 Calibration | 2004-03-05 → 2004-03-26 A (+21d) | 2004-03-25 → 2004-04-22 (+28d) | 15d → 19d | 0% → 21% | 35d → 29d | 241 → 241FS+10d |  |
| 243 | **FM 2** | 2004-02-20 → 2004-03-05 A (+14d) | 2004-03-25 → 2004-05-06 (+42d) | 25d → 45d | 0% → 54% | 61d → 71d |  |  |
| 244 | FM 2 MAG Testing | 2004-02-20 → 2004-03-05 A (+14d) | 2004-03-04 → 2004-04-01 (+28d) | 10d → 20d | 0% → 95% | 61d → 71d | none → 241FF+10d | constraint start no earlier than 2004-02-20 → none |
| 245 | MAG FM 2 Calibration | 2004-03-05 → 2004-04-16 (+42d) | 2004-03-25 → 2004-05-06 (+42d) |  |  | 61d → 71d | 244 → 244FS+10d |  |
| 246 | **SWEA - CESR** |  |  |  | 6% → 53% |  |  |  |
| 250 | **FM 2** | 2004-02-10 → 2004-03-15 A (+34d) |  | 47d → 24d | 0% → 54% |  |  |  |
| 251 | SWEA FM 2 Final Assembly (Block 2) | 2004-02-10 → 2004-03-15 A (+34d) | 2004-02-12 → 2004-03-19 A (+36d) | 3d → 5d | 0% → 100% | 67d → none |  | constraint start no earlier than 2004-02-10 → start no earlier than 2004-03-15 |
| 252 | SWEA FM 2 Calibration | 2004-02-13 → 2004-03-22 A (+38d) |  | 44d → 19d | 0% → 42% |  |  |  |
| 253 | **STE - UCB** |  | 2004-05-10 → 2004-06-29 (+50d) | 174d → 209d | 67% → 74% | 71d → 36d |  |  |
| 254 | **Deliveries** | 2004-04-14 → 2004-05-05 (+21d) | 2004-05-10 → 2004-06-29 (+50d) | 18d → 38d |  | 20d → 19d |  |  |
| 255 | Deliver STE-D FM 1 (stays at UCB for SWEA/STE-D FM 1 I&T) | 2004-04-14 → 2004-05-05 (+21d) | 2004-04-14 → 2004-05-05 (+21d) |  |  | 20d → 19d |  |  |
| 256 | Deliver STE-D FM 2 (stays at UCB for SWEA/STE-D FM 2 I&T) | 2004-05-10 → 2004-06-29 (+50d) | 2004-05-10 → 2004-06-29 (+50d) |  |  | 53d → 18d |  |  |
| 257 | Deliver STE-U FM 1 (stays at UCB for BOOM Suite FM 1 I&T) | 2004-04-20 → 2004-05-07 (+17d) | 2004-04-20 → 2004-05-07 (+17d) |  |  | 19d → 20d |  |  |
| 258 | Deliver STE-U FM 2 (stays at UCB for BOOM Suite FM 2 I&T) | 2004-05-10 → 2004-06-29 (+50d) | 2004-05-10 → 2004-06-29 (+50d) |  |  | 71d → 36d |  |  |
| 262 | **STE-U/D Detector Boards** |  | 2004-05-10 → 2004-06-29 (+50d) | 174d → 209d | 56% → 67% | 71d → 36d |  |  |
| 264 | **FM 1** |  | 2004-04-20 → 2004-05-07 (+17d) | 160d → 173d | 58% → 74% | 19d → 20d |  |  |
| 267 | Test STE FM 1 Detector Printed Wiring Board | 2004-02-04 A | 2004-02-18 A |  | 0% → 100% | 19d → none |  |  |
| 268 | **Integration & Test** | 2004-02-19 A | 2004-04-20 → 2004-05-07 (+17d) | 44d → 57d | 0% → 40% | 19d → 20d |  |  |
| 269 | Integrate & Test STE-U/D FM 1 Detectors W/ FM 1 Housings | 2004-02-19 A | 2004-03-17 → 2004-04-23 (+37d) | 20d → 47d | 0% → 64% | 19d → 18d |  |  |
| 270 | Calibrate STE-U/D FM 1 | 2004-03-18 → 2004-04-12 (+25d) | 2004-04-14 → 2004-05-05 (+21d) | 20d → 18d |  | 19d → 18d | 269 → 269FS-10d |  |

| ID | Task | Start | Finish | Duration | Complete | Total float | Predecessors | Other |
| --- | --- | --- | --- | --- | --- | --- | --- | --- |
| 271 | STE-U FM 1 Thermal Vacuum/Balance/Bake Out | 2004-04-01 → 2004-04-26 (+25d) | 2004-04-20 → 2004-05-07 (+17d) | 14d → 10d |  | 19d → 20d | 270FS-10d → 270FS-8d |  |
| 272 | **FM 2** |  | 2004-05-10 → 2004-06-29 (+50d) | 174d → 209d | 48% → 57% | 71d → 36d |  |  |
| 274 | Load STE FM 2 Detector Printed Wiring Board |  | 2004-03-17 → 2004-03-12 A (-5d) |  | 60% → 100% | 53d → none | 263, 267FF+20d → 263, 267FF+17d |  |
| 275 | Test STE FM 2 Detector Printed Wiring Board | 2004-03-18 → 2004-03-15 A (-3d) | 2004-03-31 → 2004-04-30 (+30d) | 10d → 35d | 0% → 37% | 53d → 21d |  |  |
| 276 | **Integration & Test** | 2004-04-01 → 2004-05-06 (+35d) | 2004-05-10 → 2004-06-29 (+50d) | 28d → 38d |  | 53d → 18d |  |  |
| 277 | Integrate & Test STE-U/D FM 2 Detectors W/ FM 2 Housings | 2004-04-01 → 2004-05-06 (+35d) | 2004-04-14 → 2004-06-03 (+50d) | 10d → 20d |  | 53d → 18d | 261, 275, 269 → 261, 275, 269FS-10d, 270 |  |
| 278 | Calibrate STE-U/D FM 2 | 2004-04-15 → 2004-05-20 (+35d) | 2004-05-10 → 2004-06-29 (+50d) | 18d → 28d |  | 53d → 18d | 277 → 277FS-10d |  |
| 279 | STE-U FM 2 Thermal Vacuum/Bake Out | 2004-04-27 → 2004-06-16 (+50d) | 2004-05-10 → 2004-06-29 (+50d) |  |  | 71d → 36d |  |  |
| 280 | **STE and SWEA - UCB** |  | 2004-08-27 → 2004-09-07 (+11d) | 294d → 300d | 73% → 75% | 20d → 14d |  |  |
| 281 | **Deliveries** | 2004-02-27 → 2004-04-16 (+49d) | 2004-08-27 → 2004-09-07 (+11d) | 129d → 100d |  | 20d → 14d |  |  |
| 282 | Deliver STE-U FM 1 Interface (stays at UCB for IDPU FM 1 I&T) | 2004-02-27 → 2004-04-16 (+49d) | 2004-02-27 → 2004-04-16 (+49d) |  |  | 65d → 42d |  |  |
| 283 | Deliver STE-U FM 2 Interface (stays at UCB for IDPU FM 2 I&T) | 2004-03-01 → 2004-04-23 (+53d) | 2004-03-01 → 2004-04-23 (+53d) |  |  | 81d → 89d |  |  |
| 284 | Deliver SWEA/STE-D FM 1 (stays at UCB for Boom Suite FM 1 I&T) | 2004-06-11 → 2004-07-12 (+31d) | 2004-06-11 → 2004-07-12 (+31d) |  |  | 9d → 2d |  |  |
| 285 | Deliver SWEA/STE-D FM 2 (stays at UCB for Boom Suite FM 2 I&T) | 2004-08-27 → 2004-09-07 (+11d) | 2004-08-27 → 2004-09-07 (+11d) |  |  | 20d → 14d |  |  |
| 289 | **STE-D Pre-Amp Board** |  | 2004-02-23 → 2004-04-16 (+53d) | 104d → 143d | 89% → 83% | 78d → 39d |  |  |
| 290 | **FM 1** |  | 2004-02-23 → 2004-04-16 (+53d) | 104d → 143d | 87% → 81% | 27d → 2d |  |  |
| 292 | Load STE-D FM 1 Preamp Printed Wiring Board | 2004-02-17 → 2004-03-09 A (+21d) | 2004-02-23 → 2004-04-16 (+53d) | 5d → 29d | 0% → 59% | 27d → 2d |  | constraint start no earlier than 2004-02-17 → start no earlier than 2004-03-09 |
| 293 | **FM 2** |  | 2004-02-23 → 2004-04-16 (+53d) | 104d → 143d | 87% → 81% | 78d → 39d |  |  |
| 295 | Load STE-D FM 2 Preamp Printed Wiring Board | 2004-02-17 → 2004-03-09 A (+21d) | 2004-02-23 → 2004-04-16 (+53d) | 5d → 29d | 0% → 59% | 78d → 39d |  |  |
| 297 | **STE-D Shaper Board** |  | 2004-05-13 → 2004-05-21 (+8d) | 112d → 118d | 78% → 89% | 20d → 14d |  |  |
| 298 | **FM 1** |  | 2004-02-20 → 2004-03-11 A (+20d) | 53d → 67d | 67% → 100% | 28d → none |  |  |
| 300 | Load STE-D FM 1 Shaper Printed Wiring Board | 2004-02-13 → 2004-03-05 A (+21d) | 2004-02-20 → 2004-03-11 A (+20d) |  | 0% → 100% | 28d → none |  | constraint start no earlier than 2004-02-13 → start no earlier than 2004-03-05 |
| 301 | **FM 2** |  | 2004-05-13 → 2004-05-21 (+8d) | 112d → 118d |  | 20d → 14d |  |  |
| 303 | Load STE-D FM 2 Shaper Printed Wiring Board | 2004-05-07 → 2004-05-17 (+10d) | 2004-05-13 → 2004-05-21 (+8d) |  |  | 20d → 14d | 304, 335 → 304, 332 |  |
| 305 | **STE-D Interface Board** |  | 2004-05-13 → 2004-05-21 (+8d) | 112d → 118d | 78% → 89% | 20d → 14d |  |  |
| 306 | **FM 1** |  | 2004-02-20 → 2004-03-11 A (+20d) | 53d → 67d | 67% → 100% | 28d → none |  |  |
| 308 | Load SWEA / STE-D FM 1 Digital to Analog Converter Printed Wiring Board | 2004-02-13 → 2004-03-05 A (+21d) | 2004-02-20 → 2004-03-11 A (+20d) |  | 0% → 100% | 28d → none |  |  |
| 309 | **FM 2** |  | 2004-05-13 → 2004-05-21 (+8d) | 112d → 118d |  | 20d → 14d |  |  |
| 311 | Load SWEA / STE-D FM 2 Digital to Analog Converter Printed Wiring Board | 2004-05-07 → 2004-05-17 (+10d) | 2004-05-13 → 2004-05-21 (+8d) |  |  | 20d → 14d |  |  |
| 313 | **STE-U Pre-Amp Board** |  | 2004-02-23 → 2004-04-16 (+53d) | 104d → 143d | 95% → 90% | 81d → 89d |  |  |
| 317 | **FM 2** |  | 2004-02-23 → 2004-04-16 (+53d) | 104d → 143d | 87% → 81% | 81d → 89d |  |  |
| 319 | Load STE-U FM 2 Preamp Printed Wiring Board | 2004-02-17 → 2004-03-09 A (+21d) | 2004-02-23 → 2004-04-16 (+53d) | 5d → 29d | 0% → 59% | 81d → 89d |  | constraint start no earlier than 2004-02-17 → start no earlier than 2004-03-09 |
| 321 | **STE-U Shaper & Interface Board** |  | 2004-02-20 → 2004-03-26 A (+35d) | 53d → 78d | 78% → 100% | 82d → none |  |  |
| 322 | **FM 1** |  | 2004-02-20 → 2004-03-19 A (+28d) | 53d → 73d | 67% → 100% | 65d → none |  |  |
| 324 | Load STE-U FM 1 Shaper & Interface Printed Wiring Board | 2004-02-13 → 2004-03-03 A (+19d) | 2004-02-20 → 2004-03-19 A (+28d) | 5d → 13d | 0% → 100% | 65d → none |  | constraint start no earlier than 2004-02-13 → start no earlier than 2004-03-03 |
| 325 | **FM 2** |  | 2004-02-20 → 2004-03-26 A (+35d) | 53d → 78d | 67% → 100% | 82d → none |  |  |
| 327 | Load STE-U FM 2 Shaper & Interface Printed Wiring Board | 2004-02-13 → 2004-03-22 A (+38d) | 2004-02-20 → 2004-03-26 A (+35d) |  | 0% → 100% | 82d → none | 324SS → 324 |  |
| 329 | **Integration & Test** | 2004-02-23 → 2004-03-22 A (+28d) | 2004-08-27 → 2004-09-07 (+11d) | 134d → 120d | 0% → 4% | 20d → 14d |  |  |
| 330 | **FM 1** | 2004-02-23 → 2004-03-22 A (+28d) | 2004-07-30 → 2004-09-07 (+39d) | 114d → 120d | 0% → 8% | 28d → 11d |  |  |
| 331 | Integrate & Test STE-U FM 1 Interface Boards | 2004-02-23 → 2004-03-22 A (+28d) | 2004-02-27 → 2004-04-16 (+49d) | 5d → 20d | 0% → 40% | 65d → 42d |  |  |
| 332 | Integrate & Test SWEA/STE-D FM 1 Interface Boards | 2004-02-24 → 2004-04-19 (+55d) | 2004-03-22 → 2004-05-14 (+53d) |  |  | 27d → 2d |  |  |
| 333 | Integrate & Test SWEA/STE-D FM 1 Interface with SWEA/STE-D FM 1 LVPS | 2004-04-16 → 2004-05-17 (+31d) | 2004-04-29 → 2004-05-28 (+29d) |  |  | 9d → 2d |  |  |
| 334 | Clean/Coat/Stake SWEA/STE-D Interface | 2004-03-23 → 2004-05-17 (+55d) | 2004-04-05 → 2004-05-28 (+53d) |  |  | 27d → 2d |  |  |
| 335 | Integrate & Test SWEA/STE-D FM 1 Combined | 2004-04-30 → 2004-06-01 (+32d) | 2004-05-06 → 2004-06-07 (+32d) |  |  | 9d → 2d |  |  |
| 336 | Calibrate SWEA/STE FM 1 | 2004-05-07 → 2004-06-08 (+32d) | 2004-06-04 → 2004-07-05 (+31d) |  |  | 9d → 2d |  |  |
| 337 | SWEA/STE FM 1 Vibration | 2004-06-07 → 2004-07-06 (+29d) | 2004-06-11 → 2004-07-12 (+31d) |  |  | 9d → 2d |  |  |
| 338 | SWEA/STE-D FM 1 Thermal Vac/Thermal Balance/Bake Out | 2004-07-13 → 2004-08-18 (+36d) | 2004-07-30 → 2004-09-07 (+39d) |  |  | 37d → 11d |  |  |
| 339 | **FM 2** | 2004-02-24 → 2004-04-19 (+55d) | 2004-08-27 → 2004-09-07 (+11d) | 133d → 100d |  | 20d → 14d |  |  |
| 340 | Integrate & Test STE-U FM 2 Interface Boards | 2004-02-24 → 2004-04-19 (+55d) | 2004-03-01 → 2004-04-23 (+53d) |  |  | 81d → 89d |  |  |
| 341 | Integrate & Test SWEA/STE-D FM 2 Interface Boards | 2004-05-14 → 2004-05-24 (+10d) | 2004-06-11 → 2004-06-21 (+10d) |  |  | 20d → 14d |  |  |
| 342 | Integrate & Test SWEA/STE-D FM 2 Interface with SWEA/STE-D FM 2 LVPS | 2004-06-14 → 2004-06-22 (+8d) | 2004-06-25 → 2004-07-05 (+10d) |  |  | 20d → 14d |  |  |
| 343 | Integrate & Test SWEA/STE-D FM 2 Combined | 2004-06-28 → 2004-07-06 (+8d) | 2004-07-09 → 2004-07-19 (+10d) |  |  | 20d → 14d |  |  |
| 344 | Calibrate SWEA/STE FM 2 | 2004-07-12 → 2004-07-20 (+8d) | 2004-08-06 → 2004-08-16 (+10d) |  |  | 20d → 14d |  |  |
| 345 | SWEA/STE FM 2 Vibration | 2004-08-09 → 2004-08-17 (+8d) | 2004-08-13 → 2004-08-23 (+10d) |  |  | 20d → 14d |  |  |
| 346 | SWEA/STE-D FM 2 Thermal Vac & bake Out | 2004-08-16 → 2004-08-24 (+8d) | 2004-08-27 → 2004-09-07 (+11d) |  |  | 20d → 14d |  |  |
| 347 | **Boom Suite I&T - UCB** | 2004-04-21 → 2004-05-10 (+19d) | 2004-09-28 → 2004-10-06 (+8d) | 113d → 106d |  | 19d → 14d |  |  |
| 348 | **FM 1** | 2004-04-21 → 2004-05-10 (+19d) | 2004-08-13 → 2004-09-21 (+39d) | 82d → 95d |  | 19d → 11d |  |  |
| 349 | FM 1 Boom/MAG/STE-U I&T | 2004-04-21 → 2004-05-10 (+19d) | 2004-04-26 → 2004-05-13 (+17d) |  |  | 19d → 20d |  |  |
| 350 | FM 1 Boom/SWEA/STE/MAG I&T | 2004-06-14 → 2004-07-13 (+29d) | 2004-06-15 → 2004-07-14 (+29d) |  |  | 9d → 2d |  |  |
| 351 | FM 1 Integrated Boom/IDPU I&T | 2004-06-16 → 2004-07-26 (+40d) | 2004-06-21 → 2004-07-29 (+38d) |  |  | 9d → -5d | 350, 184, 160 → 350, 184, 756 |  |
| 352 | Final BOOM Suite FM 1 I & T | 2004-08-02 → 2004-09-08 (+37d) | 2004-08-13 → 2004-09-21 (+39d) |  |  | 37d → 11d |  |  |
| 353 | **FM 2** | 2004-05-11 → 2004-06-30 (+50d) | 2004-09-28 → 2004-10-06 (+8d) | 99d → 70d |  | 20d → 14d |  |  |
| 354 | FM 2 Boom/MAG/STE-U I&T | 2004-05-11 → 2004-06-30 (+50d) | 2004-05-14 → 2004-07-05 (+52d) |  |  | 71d → 36d |  |  |
| 355 | FM 2 Boom/SWEA/STE/MAG I&T | 2004-08-30 → 2004-09-08 (+9d) | 2004-08-31 → 2004-09-09 (+9d) |  |  | 20d → 14d |  |  |
| 356 | FM 2 Integrated Boom/IDPU I&T | 2004-09-01 → 2004-09-10 (+9d) | 2004-09-07 → 2004-09-15 (+8d) |  |  | 20d → 14d |  |  |
| 357 | Boom Suite FM 2 EMC | 2004-09-08 → 2004-09-16 (+8d) | 2004-09-14 → 2004-09-22 (+8d) |  |  | 20d → 14d |  |  |
| 358 | Final BOOM Suite FM 2 I & T | 2004-09-15 → 2004-09-23 (+8d) | 2004-09-28 → 2004-10-06 (+8d) |  |  | 20d → 14d |  |  |
| 359 | **SEP Suite - CIT** |  | 2004-10-21 → 2004-10-25 (+4d) | 352d → 354d | 42% → 57% | 279d → 3d |  |  |
| 360 | **SEP Mechanical - Sandy Shuman (GSFC)** |  | 2004-06-02 → 2004-07-07 (+35d) | 90d → 115d | 1% → 26% | 37d → 29d |  |  |
| 361 | **SIT Electronics Enclosure (Priority 1)** | 2004-02-09 A | 2004-03-16 → 2004-05-04 (+49d) | 26d → 61d | 0% → 34% | 15d → 26d |  |  |

| ID | Task | Start | Finish | Duration | Complete | Total float | Predecessors | Other |
| --- | --- | --- | --- | --- | --- | --- | --- | --- |
| 362 | Complete Design/Drawings for SIT Enclosure | 2004-02-09 A | 2004-02-23 A |  | 0% → 100% | 15d → none |  |  |
| 363 | Fabrication of SIT Enclosure | 2004-02-24 → 2004-04-08 (+44d) | 2004-03-08 → 2004-04-23 (+46d) | 10d → 12d |  | 16d → 26d | 362 → 362FS+32d |  |
| 364 | Inspection and Final Assembly of SIT Enclosure | 2004-03-09 → 2004-04-26 (+48d) | 2004-03-15 → 2004-05-03 (+49d) | 5d → 6d |  | 16d → 26d |  |  |
| 365 | Deliver SIT Enclosure to UMD | 2004-03-16 → 2004-05-04 (+49d) | 2004-03-16 → 2004-05-04 (+49d) |  |  | 16d → 26d |  |  |
| 366 | **SEP FM 1 & FM 2 LVPS Boxes (Priority 2)** | 2004-02-09 A | 2004-03-11 → 2004-04-22 (+42d) | 23d → 53d | 0% → 70% | 15d → 17d |  |  |
| 367 | Complete Design/Drawings for SEP LVPS Boxes | 2004-02-09 A | 2004-02-13 A |  | 0% → 100% | 15d → none |  |  |
| 368 | Fabrication of SEP LVPS Boxes | 2004-02-17 A | 2004-03-01 → 2004-04-05 (+35d) | 10d → 35d | 0% → 91% | 43d → 17d |  |  |
| 369 | Inspection of SEP LVPS Boxes (Final Assembly at UCB) | 2004-03-02 → 2004-04-06 (+35d) | 2004-03-08 → 2004-04-19 (+42d) | 5d → 10d |  | 43d → 17d |  | was named Inspection and Final Assembly of SEP LVPS Boxes |
| 370 | Deliver SEP LVPS Boxes to UCB | 2004-03-09 → 2004-04-20 (+42d) | 2004-03-11 → 2004-04-22 (+42d) |  |  | 43d → 17d |  | constraint none → start no earlier than 2004-04-07 |
| 371 | **SEP Electronics Enclosure (Priority 3)** | 2004-02-17 A | 2004-03-30 → 2004-05-21 (+52d) | 31d → 69d | 0% → 46% | 15d → 19d |  |  |
| 372 | Complete Design/Drawings for SEP Enclosure | 2004-02-17 A | 2004-03-04 → 2004-04-19 (+46d) | 13d → 45d | 0% → 71% | 15d → 2d |  |  |
| 373 | Fabrication of SEP Enclosure | 2004-03-05 → 2004-04-20 (+46d) | 2004-03-18 → 2004-05-10 (+53d) | 10d → 15d |  | 58d → 19d |  |  |
| 374 | Inspection and Final Assembly of SEP Enclosure | 2004-03-19 → 2004-05-11 (+53d) | 2004-03-25 → 2004-05-18 (+54d) | 5d → 6d |  | 58d → 19d |  |  |
| 375 | Deliver SEP Enclosure to CIT | 2004-03-26 → 2004-05-19 (+54d) | 2004-03-30 → 2004-05-21 (+52d) |  |  | 58d → 19d |  |  |
| 376 | **SEP Central Bias Supply Shields (Priority 4)** | 2004-03-05 → 2004-04-15 (+41d) | 2004-04-01 → 2004-05-12 (+41d) |  |  | 15d → 2d |  |  |
| 377 | Complete Design/Drawings for Bias Supply Shields | 2004-03-05 → 2004-04-15 (+41d) | 2004-03-11 → 2004-04-21 (+41d) |  |  | 15d → 2d | 372 → 372FS-3d |  |
| 378 | Fabrication of Bias Supply Shields | 2004-03-12 → 2004-04-22 (+41d) | 2004-03-25 → 2004-05-05 (+41d) |  |  | 15d → 68d |  |  |
| 379 | Inspection and Delivery (to CIT) of Bias Supply Shields | 2004-03-26 → 2004-05-06 (+41d) | 2004-04-01 → 2004-05-12 (+41d) |  |  | 15d → 68d |  |  |
| 380 | **LET Telescope (Priority 5)** | 2004-03-12 → 2004-04-15 (+34d) | 2004-04-16 → 2004-05-20 (+34d) |  |  | 18d → 2d |  |  |
| 381 | Complete Design/Drawings for LET Telescope | 2004-03-12 → 2004-04-15 (+34d) | 2004-03-23 → 2004-04-21 (+29d) | 8d → 5d |  | 18d → 2d | 377 → 377FS-5d |  |
| 382 | Fabrication of LET Telescope | 2004-03-24 → 2004-04-22 (+29d) | 2004-04-06 → 2004-05-05 (+29d) |  |  | 31d → 6d |  |  |
| 383 | Inspection and Final Assembly of LET Telescope (CIT has detectors) | 2004-04-07 → 2004-05-06 (+29d) | 2004-04-13 → 2004-05-17 (+34d) | 5d → 8d |  | 31d → 6d |  | was named Inspection and Final Assembly of LET Telescope |
| 384 | Deliver LET Telescope to CIT | 2004-04-14 → 2004-05-18 (+34d) | 2004-04-16 → 2004-05-20 (+34d) |  |  | 31d → 6d |  |  |
| 385 | **HET Electronics Enclosure (Priority 6)** | 2004-03-24 → 2004-03-22 A (-2d) | 2004-04-23 → 2004-05-13 (+20d) | 23d → 39d | 0% → 21% | 18d → 2d |  |  |
| 386 | Complete Design/Drawings for HET Enclosure | 2004-03-24 → 2004-03-22 A (-2d) | 2004-04-02 → 2004-04-22 (+20d) | 8d → 23d | 0% → 35% | 18d → 2d | 381 → 381FS-14d |  |
| 387 | Fabrication of HET Enclosure | 2004-04-05 → 2004-04-23 (+18d) | 2004-04-16 → 2004-05-06 (+20d) |  |  | 18d → 2d |  |  |
| 388 | Inspection and Final Assembly of HET Enclosure | 2004-04-19 → 2004-05-07 (+18d) | 2004-04-23 → 2004-05-13 (+20d) |  |  | 18d → 2d |  |  |
| 389 | Deliver HET Enclosure (stays at GSFC) | 2004-04-23 → 2004-05-13 (+20d) | 2004-04-23 → 2004-05-13 (+20d) |  |  | 18d → 2d |  |  |
| 390 | **HET Telescope (Priority 7)** |  | 2004-04-30 → 2004-05-24 (+24d) | 68d → 84d | 7% → 32% | 18d → 2d |  |  |
| 391 | On Going work for HET Telescope (Complete Design/Drawings & Prep for Fab) |  | 2004-03-31 → 2004-04-14 (+14d) | 46d → 56d | 9% → 41% | 16d → 1d |  |  |
| 392 | Fabrication of HET Telescope | 2004-04-01 → 2004-04-15 (+14d) | 2004-04-14 → 2004-04-28 (+14d) |  |  | 25d → 13d |  |  |
| 393 | Inspection and Final Assembly of HET Telescope | 2004-04-26 → 2004-05-14 (+18d) | 2004-04-30 → 2004-05-24 (+24d) | 5d → 7d |  | 18d → 2d |  |  |
| 394 | Deliver HET Telescope (stays at GSFC) | 2004-04-30 → 2004-05-24 (+24d) | 2004-04-30 → 2004-05-24 (+24d) |  |  | 18d → 2d |  |  |
| 395 | **SIT Telescope (Priority 8)** | 2004-04-01 → 2004-04-15 (+14d) | 2004-05-18 → 2004-06-09 (+22d) | 34d → 39d |  | 16d → 1d |  |  |
| 396 | Complete Design/Drawings for SIT Telescope | 2004-04-01 → 2004-04-15 (+14d) | 2004-04-26 → 2004-05-10 (+14d) |  |  | 16d → 1d |  |  |
| 397 | Fabrication of SIT Telescope | 2004-04-27 → 2004-05-11 (+14d) | 2004-05-10 → 2004-05-24 (+14d) |  |  | 16d → 1d |  |  |
| 398 | Inspection and Final Assembly of SIT Telescope | 2004-05-11 → 2004-05-25 (+14d) | 2004-05-17 → 2004-06-08 (+22d) | 5d → 10d |  | 16d → 1d |  |  |
| 399 | Deliver SIT Telescope to UMD (Includes the Foils and Detectors) | 2004-05-18 → 2004-06-09 (+22d) | 2004-05-18 → 2004-06-09 (+22d) |  |  | 16d → 1d |  | was named Deliver SIT Telescope to UMD |
| 400 | **Shipping Containers for HET, SIT & SEP Central (Priority 9)** | 2004-04-27 → 2004-05-11 (+14d) | 2004-05-27 → 2004-06-11 (+15d) |  |  | 23d → 8d |  |  |
| 401 | Design | 2004-04-27 → 2004-05-11 (+14d) | 2004-05-03 → 2004-05-17 (+14d) |  |  | 23d → 8d |  |  |
| 402 | Fabrication/Machining | 2004-05-04 → 2004-05-18 (+14d) | 2004-05-17 → 2004-06-01 (+15d) |  |  | 23d → 12d |  |  |
| 403 | Inspection and Assembly | 2004-05-18 → 2004-06-02 (+15d) | 2004-05-24 → 2004-06-08 (+15d) |  |  | 23d → 12d |  |  |
| 404 | HET Container stays at GSFC | 2004-05-24 → 2004-06-08 (+15d) | 2004-05-24 → 2004-06-08 (+15d) |  |  | 23d → 12d |  |  |
| 405 | SIT Container to UMD | 2004-05-25 → 2004-06-09 (+15d) | 2004-05-25 → 2004-06-09 (+15d) |  |  | 25d → 24d |  |  |
| 406 | SEP Central Container to CIT | 2004-05-25 → 2004-06-09 (+15d) | 2004-05-27 → 2004-06-11 (+15d) |  |  | 40d → 13d |  |  |
| 413 | **LET Radiation Test Fixture (Priority 11)** | 2004-05-04 → 2004-06-02 (+29d) | 2004-06-02 → 2004-07-07 (+35d) | 21d → 26d |  | 24d → 8d |  | was named LET Radiation Test Fixture (Priority 10) |
| 414 | Design | 2004-05-04 → 2004-06-02 (+29d) | 2004-05-10 → 2004-06-08 (+29d) |  |  | 24d → 8d | 401 → 408 |  |
| 415 | Fabrication | 2004-05-11 → 2004-06-09 (+29d) | 2004-05-24 → 2004-06-22 (+29d) |  |  | 24d → 8d |  |  |
| 416 | Inspection and Assembly | 2004-05-25 → 2004-06-23 (+29d) | 2004-06-01 → 2004-07-06 (+35d) | 5d → 10d |  | 24d → 8d |  |  |
| 417 | Deliver to CIT for SEP I&T | 2004-06-02 → 2004-07-07 (+35d) | 2004-06-02 → 2004-07-07 (+35d) |  |  | 24d → 8d |  |  |
| 418 | **SEP Central - CIT** |  | 2004-06-03 → 2004-06-25 (+22d) | 211d → 227d | 31% → 72% | 26d → 37d |  |  |
| 419 | **Deliveries** |  | 2004-06-03 → 2004-06-25 (+22d) | 35d → 51d |  | 26d → 37d |  |  |
| 420 | Deliver all SEP Cen FM 1 Boards to SEP I&T (stays at CIT) | 2004-05-10 → 2004-06-01 (+22d) | 2004-05-10 → 2004-06-01 (+22d) |  |  | 29d → 13d |  |  |
| 421 | Deliver all SEP Cen FM 2 Boards & FM 2 LVPS to SEP I&T (stays at CIT) | 2004-05-10 → 2004-06-25 (+46d) | 2004-05-10 → 2004-06-25 (+46d) |  |  | 43d → 37d | 444 → 444, 74, 379 |  |
| 424 | **Logic Board** | 2004-02-13 A | 2004-03-26 → 2004-05-06 (+41d) | 30d → 59d | 0% → 71% | 29d → 0d |  |  |
| 425 | **Assembly** | 2004-02-13 A | 2004-02-27 A |  | 0% → 100% | 29d → none |  |  |
| 426 | Assemble FM 1 SEP Central Logic board | 2004-02-13 A | 2004-02-27 A |  | 0% → 100% | 29d → none |  |  |
| 427 | Assemble FM 2 SEP Central Logic board | 2004-02-13 A | 2004-02-27 A |  | 0% → 100% | 29d → none |  |  |
| 428 | **Test** | 2004-03-01 A | 2004-03-26 → 2004-05-06 (+41d) | 20d → 49d | 0% → 62% | 29d → 0d |  |  |
| 429 | Test FM 1 SEP Central Logic board (initial) | 2004-03-01 A | 2004-03-26 A |  | 0% → 100% | 29d → none |  |  |
| 430 | Test FM 2 SEP Central Logic board (initial) | 2004-03-01 A | 2004-03-26 → 2004-05-06 (+41d) | 20d → 49d | 0% → 47% | 29d → -1d |  |  |
| 434 | **SEP Solid State Detector Bias Supply Board** |  | 2004-04-15 → 2004-04-06 (-9d) | 62d → 55d | 18% → 93% | 15d → 21d |  |  |
| 435 | **Assembly & Initial Test** |  | 2004-03-16 A |  | 23% → 100% | 27d → none |  |  |
| 436 | Assemble and Initial Test FM 1 SSD Bias Supply Board |  | 2004-03-16 A |  | 23% → 100% | 27d → none |  |  |
| 437 | Assemble and Initial Test FM 2 SSD Bias Supply Board |  | 2004-03-16 A |  | 23% → 100% | 27d → none |  |  |
| 438 | **Final Test** | 2004-04-02 → 2004-03-17 A (-16d) | 2004-04-15 → 2004-04-06 (-9d) | 10d → 15d | 0% → 73% | 15d → 21d |  |  |
| 439 | Final Test FM 1 SSD Bias Supply Board | 2004-04-02 → 2004-03-17 A (-16d) | 2004-04-15 → 2004-04-06 (-9d) | 10d → 15d | 0% → 73% | 15d → 21d | 436, 379 → 436 |  |
| 440 | Final Test FM 2 SSD Bias Supply Board | 2004-04-02 → 2004-03-17 A (-16d) | 2004-04-15 → 2004-04-06 (-9d) | 10d → 15d | 0% → 73% | 15d → 21d | 437, 379 → 437 |  |
| 441 | **Conformal Coat, Mass Properties and Bake Out (SEP Central, LET, SEP LVPS)** | 2004-04-16 → 2004-05-07 (+21d) | 2004-05-10 → 2004-06-01 (+22d) |  |  | 15d → -1d |  |  |
| 442 | Stake/Conformal Coat All SEP Central and LET Boards | 2004-04-16 → 2004-05-07 (+21d) | 2004-04-29 → 2004-05-20 (+21d) |  |  | 15d → -1d |  |  |

| ID | Task | Start | Finish | Duration | Complete | Total float | Predecessors | Other |
| --- | --- | --- | --- | --- | --- | --- | --- | --- |
| 443 | Mass Properties/Photo All SEP Central and LET Boards | 2004-04-30 → 2004-05-21 (+21d) | 2004-05-05 → 2004-05-26 (+21d) |  |  | 15d → -1d |  |  |
| 444 | Bake Out All SEP Central/LET Boards and SEP LVPS FM 1 | 2004-05-06 → 2004-05-27 (+21d) | 2004-05-10 → 2004-06-01 (+22d) |  |  | 15d → -1d | 443, 74, 68 → 443, 68 | was named Bake Out All SEP Central/LET Boards and SEP LVPS (FM 1 & 2) |
| 445 | **Flight Software** |  |  |  | 49% → 68% | 26d → 35d |  |  |
| 446 | SEP Central Build 3 |  |  |  | 59% → 81% | 26d → 35d |  |  |
| 448 | **HET - Tycho (GSFC)** |  | 2004-06-23 → 2004-07-21 (+28d) | 119d → 139d | 19% → 55% | 363d → 48d |  | was named HET - GSFC |
| 449 | **Deliveries** | 2004-04-30 → 2004-06-02 (+33d) | 2004-06-23 → 2004-07-21 (+28d) | 38d → 36d |  | 18d → 17d |  |  |
| 450 | Deliver HET FM 1w/o replacement detectors (to CIT for SEP Suite I&T) | 2004-06-01 → 2004-06-30 (+29d) | 2004-06-02 → 2004-07-01 (+29d) |  |  | 19d → -3d |  | was named Deliver HET FM 1 (to CIT for SEP Suite I&T) |
| 452 | Deliver HET FM 2 w/o replacement detectors (to CIT for SEP Suite I&T) | 2004-06-22 → 2004-07-07 (+15d) | 2004-06-23 → 2004-07-08 (+15d) |  |  | 18d → 34d |  | was named Deliver HET FM 2 (to CIT for SEP Suite I&T) |
| 454 | Deliver Final HET Flight Software to SEP I&T | 2004-04-30 → 2004-06-02 (+33d) | 2004-05-03 → 2004-06-03 (+31d) |  |  | 40d → 17d |  |  |
| 455 | **Detectors (Batch 1)** |  | 2004-03-31 → 2004-03-03 A (-28d) | 60d → 40d | 34% → 100% | 422d → none |  | was named Detectors |
| 456 | Receive & Inspect HET Flight Detectors |  | 2004-03-03 A |  | 45% → 100% | 442d → none |  |  |
| 457 | **Detector Testing** |  | 2004-03-31 → 2004-03-03 A (-28d) | 60d → 40d | 30% → 100% | 422d → none |  |  |
| 458 | Capacitance, Current, Depletion, Alpha Resolution Testing |  | 2004-03-31 → 2004-03-03 A (-28d) | 60d → 40d | 30% → 100% | 422d → none |  |  |
| 459 | Life Test HET Detectors |  | 2004-03-31 → 2004-03-03 A (-28d) | 60d → 40d | 30% → 100% | 40d → none |  |  |
| 466 | **Electronics Board** |  | 2004-05-13 → 2004-05-21 (+8d) | 80d → 86d | 9% → 56% | 24d → 45d |  |  |
| 467 | **Assembly** |  | 2004-03-12 → 2004-03-16 A (+4d) | 36d → 38d | 50% → 100% | 30d → none |  |  |
| 470 | Complete Population of HET Electronics FM 2 Board (Flight ACTEL) | 2004-03-11 → 2004-03-15 A (+4d) | 2004-03-12 → 2004-03-16 A (+4d) |  | 0% → 100% | 30d → none |  |  |
| 471 | **Test** |  | 2004-05-13 → 2004-05-21 (+8d) | 78d → 84d | 6% → 54% | 24d → 45d |  |  |
| 472 | **FM 1** |  | 2004-03-22 → 2004-05-14 (+53d) | 40d → 79d | 13% → 77% | 24d → 8d |  |  |
| 473 | Test HET FM 1 Electronics Board w/ETU ACTEL |  | 2004-02-23 → 2004-02-26 A (+3d) | 20d → 23d | 25% → 100% | 24d → none |  |  |
| 474 | Remove ETU ACTEL and socket from HET FM 1 Electronics Board | 2004-02-24 → 2004-02-27 A (+3d) | 2004-02-24 → 2004-02-27 A (+3d) | 1d → 0.5d | 0% → 100% | 24d → none |  |  |
| 475 | Install Flight ACTEL on HET FM 1 Electronics Board | 2004-02-25 → 2004-02-27 A (+2d) | 2004-02-25 → 2004-02-27 A (+2d) | 1d → 0.5d | 0% → 100% | 24d → none |  |  |
| 476 | Retest HET FM 1 Electronics Board w/Flight ACTEL | 2004-02-26 → 2004-03-01 A (+4d) | 2004-03-10 → 2004-03-12 A (+2d) |  | 0% → 100% | 24d → none |  |  |
| 477 | Clean, Bake, Conformal Coat HET FM 1 Electronics Board | 2004-03-11 → 2004-05-03 (+53d) | 2004-03-12 → 2004-05-07 (+56d) | 2d → 5d |  | 24d → 8d | 476 → 476FS+35d | was named Conformal Coat HET FM 1 Electronics Board |
| 478 | Retest Conformal Coated HET FM 1 Electronics Board | 2004-03-15 → 2004-05-10 (+56d) | 2004-03-16 → 2004-05-14 (+59d) | 2d → 5d |  | 24d → 8d |  |  |
| 479 | **FM 2** | 2004-03-23 → 2004-03-17 A (-6d) | 2004-05-13 → 2004-05-21 (+8d) | 38d → 48d | 0% → 28% | 24d → 45d |  |  |
| 480 | Test HET FM 2 Electronics Board | 2004-03-23 → 2004-03-17 A (-6d) | 2004-05-03 → 2004-04-27 (-6d) |  | 0% → 37% | 24d → 53d | 470, 473, Retest Bakedout HET FM 1 Electronics Board → 470, 473 |  |
| 481 | Clean, Bake, Conformal Coat HET FM 2 Electronics Board | 2004-05-04 → 2004-04-28 (-6d) | 2004-05-05 → 2004-05-04 (-1d) | 2d → 5d |  | 24d → 53d |  | was named Conformal Coat HET FM 2 Electronics Board |
| 482 | Retest Conformal Coated HET FM 2 Electronics Board | 2004-05-06 → 2004-05-17 (+11d) | 2004-05-07 → 2004-05-21 (+14d) | 2d → 5d |  | 24d → 45d |  |  |
| 483 | **Flight Software** |  | 2004-04-29 → 2004-06-01 (+33d) | 70d → 92d | 10% → 54% | 19d → -3d |  |  |
| 484 | **Design** |  | 2004-02-04 → 2004-04-23 (+79d) | 10d → 66d | 70% → 59% | 19d → -2d |  |  |
| 485 | Complete Definition of HET PH Event Processing |  | 2004-02-04 → 2004-02-23 A (+19d) | 10d → 22d | 70% → 100% | 19d → none |  |  |
| 487 | **Coding** | 2004-02-05 → 2004-02-24 A (+19d) | 2004-03-04 → 2004-04-14 (+41d) | 20d → 37d | 0% → 79% | 19d → 5d |  |  |
| 488 | Code HET PH Event Processing Update for Flight | 2004-02-05 → 2004-02-24 A (+19d) | 2004-02-19 → 2004-04-01 (+42d) | 10d → 28d | 0% → 96% | 19d → 14d |  |  |
| 489 | Code HET Telemetry Formatting Update for Flight | 2004-02-20 → 2004-03-12 A (+21d) | 2004-03-04 → 2004-04-14 (+41d) | 10d → 24d | 0% → 58% | 19d → 0d | 488 → 488FS-15d |  |
| 490 | **Test** | 2004-03-05 → 2004-03-23 A (+18d) | 2004-04-29 → 2004-06-01 (+33d) | 40d → 50d | 0% → 18% | 19d → -3d |  |  |
| 491 | Test Integrated HET S/W with Simulated Data | 2004-03-05 → 2004-03-23 A (+18d) | 2004-03-25 → 2004-04-26 (+32d) |  | 0% → 47% | 19d → 0d |  |  |
| 492 | Verify HET On-Board Software | 2004-03-26 → 2004-04-27 (+32d) | 2004-04-29 → 2004-06-01 (+33d) |  |  | 19d → -3d | 491 → 486, 491 |  |
| 493 | **Integration & Test** | 2004-05-03 → 2004-06-02 (+30d) | 2004-06-21 → 2004-07-19 (+28d) | 35d → 34d |  | 18d → -3d |  |  |
| 494 | **FM 1** | 2004-05-03 → 2004-06-02 (+30d) | 2004-05-28 → 2004-07-19 (+52d) | 20d → 34d |  | 18d → -5d |  |  |
| 495 | Integrate HET FM 1 Electronics Telescope (Ahead) | 2004-05-03 → 2004-06-02 (+30d) | 2004-05-07 → 2004-06-08 (+32d) |  |  | 18d → -3d | Retest Bakedout HET FM 1 Electronics Board, 459, 492, 394 → 459, 492, 394, 478 |  |
| 496 | Test HET FM 1 Telescope (Ahead) | 2004-05-10 → 2004-06-09 (+30d) | 2004-05-28 → 2004-06-29 (+32d) |  |  | 18d → -3d |  |  |
| 500 | **FM 2** | 2004-05-14 → 2004-06-09 (+26d) | 2004-06-21 → 2004-07-19 (+28d) | 26d → 29d |  | 18d → 34d |  |  |
| 501 | Integrate HET FM 2 Electronics Telescope (Behind) | 2004-05-14 → 2004-06-09 (+26d) | 2004-05-20 → 2004-06-15 (+26d) |  |  | 24d → 34d | Retest Bakedout HET FM 2 Electronics Board, 495, 459, 492, 394 → 495, 459, 492, 394, 482 |  |
| 502 | Test HET FM 2 Telescope (Behind) | 2004-06-01 → 2004-06-16 (+15d) | 2004-06-21 → 2004-07-06 (+15d) |  |  | 18d → 34d | 496, 501 → 501 |  |
| 505 | **LET - CIT** |  | 2004-06-08 → 2004-06-29 (+21d) | 228d → 243d | 66% → 78% | 29d → 41d |  |  |
| 506 | **Deliveries** |  | 2004-06-08 → 2004-06-29 (+21d) | 24d → 39d |  | 29d → 38d |  |  |
| 507 | Deliver LET FM 1 (stays at CIT for SEP I&T) | 2004-06-08 → 2004-06-29 (+21d) | 2004-06-08 → 2004-06-29 (+21d) |  |  | 15d → -1d |  |  |
| 508 | Deliver LET FM 2 (stays at CIT for SEP I&T) | 2004-06-08 → 2004-06-29 (+21d) | 2004-06-08 → 2004-06-29 (+21d) |  |  | 29d → 41d |  |  |
| 510 | **Detectors** |  | 2004-03-12 A |  | 83% → 100% | 56d → none |  |  |
| 511 | Complete LET Flight Detector Testing |  | 2004-03-12 A |  | 83% → 100% | 56d → none |  |  |
| 512 | **Hybrids** |  | 2004-03-01 A |  | 86% → 100% | 27d → none |  |  |
| 513 | Complete Test of Flight Hybrids (LET and to GSFC for HET FM 2) |  | 2004-03-01 A |  | 86% → 100% | 27d → none |  |  |
| 514 | **Detector/Misc Board** | 2004-03-02 A | 2004-03-30 → 2004-05-06 (+37d) | 21d → 48d | 0% → 46% | 27d → 0d |  |  |
| 515 | **Assembly** | 2004-03-02 A | 2004-03-15 A |  | 0% → 100% | 27d → none |  |  |
| 516 | Assemble LET FM 1 Detector Board | 2004-03-02 A | 2004-03-15 A |  | 0% → 100% | 27d → none |  |  |
| 517 | Assemble LET FM 2 Detector Board | 2004-03-02 A | 2004-03-15 A |  | 0% → 100% | 27d → none |  |  |
| 518 | **Test** | 2004-03-16 A | 2004-03-30 → 2004-05-06 (+37d) | 11d → 38d | 0% → 32% | 27d → 0d |  |  |
| 519 | Test LET FM 1 Detector Board | 2004-03-16 A | 2004-03-30 → 2004-05-06 (+37d) | 11d → 38d | 0% → 32% | 27d → -1d |  |  |
| 520 | Test LET FM 2 Detector Board | 2004-03-16 A | 2004-03-30 → 2004-05-06 (+37d) | 11d → 38d | 0% → 32% | 27d → -1d |  |  |
| 521 | **Flight Software** |  |  |  | 65% → 75% | 39d → 38d |  |  |
| 522 | Let Flight Software Build 3 |  |  |  | 65% → 75% | 39d → 38d |  |  |
| 523 | **Integration & Test** | 2004-05-11 → 2004-06-02 (+22d) | 2004-06-08 → 2004-06-29 (+21d) |  |  | 15d → -1d |  |  |
| 524 | **FM 1** | 2004-05-11 → 2004-06-02 (+22d) | 2004-06-08 → 2004-06-29 (+21d) |  |  | 15d → -1d |  |  |
| 525 | Integrate LET FM 1 Housing With Detectors | 2004-05-11 → 2004-06-02 (+22d) | 2004-06-08 → 2004-06-29 (+21d) |  |  | 15d → -1d |  |  |
| 526 | **FM 2** | 2004-05-11 → 2004-06-02 (+22d) | 2004-06-08 → 2004-06-29 (+21d) |  |  | 29d → 41d |  |  |
| 527 | Integrate LET FM 2 Housing With Detectors | 2004-05-11 → 2004-06-02 (+22d) | 2004-06-08 → 2004-06-29 (+21d) |  |  | 29d → 41d |  |  |
| 528 | **SEPT - Kiel/ESTEC** |  | 2004-07-28 → 2004-09-02 (+36d) | 245d → 271d | 71% → 90% | 338d → 23d |  |  |
| 529 | **Deliveries** | 2004-03-11 → 2004-03-15 (+4d) | 2004-07-28 → 2004-09-02 (+36d) | 99d → 123d |  | 49d → 8d |  |  |
| 530 | Deliver SEPT-NS FM 1 to CIT for SEP I&T and Suite EMC | 2004-03-11 → 2004-03-15 (+4d) | 2004-03-17 → 2004-03-19 (+2d) |  |  | 71d → 8d |  |  |

| ID | Task | Start | Finish | Duration | Complete | Total float | Predecessors | Other |
| --- | --- | --- | --- | --- | --- | --- | --- | --- |
| 531 | Deliver SEPT-E FM 1 to CIT for SEP I&T and Suite EMC | 2004-03-11 → 2004-03-15 (+4d) | 2004-03-17 → 2004-03-19 (+2d) |  |  | 71d → 8d |  |  |
| 532 | Final Delivery of SEPT FM 1 to APL (after Therm Bal @ GSFC) | 2004-07-27 → 2004-09-01 (+36d) | 2004-07-28 → 2004-09-02 (+36d) |  |  | 49d → 23d | 571, 578 → 571, 578, 562 |  |
| 533 | Deliver SEPT-NS FM 2 to CIT for SEP I&T and Suite EMC | 2004-03-22 → 2004-03-18 (-4d) | 2004-03-26 → 2004-03-24 (-2d) |  |  | 78d → 107d |  |  |
| 534 | Deliver SEPT-E FM 2 to CIT for SEP I&T and Suite EMC | 2004-03-22 → 2004-03-18 (-4d) | 2004-03-26 → 2004-03-24 (-2d) |  |  | 78d → 107d |  |  |
| 535 | **Mechanical Assembly** |  | 2004-02-27 A |  | 77% → 100% | 445d → none |  |  |
| 542 | **Spare** |  | 2004-02-27 A |  | 32% → 100% | 445d → none |  |  |
| 543 | Assemble SEPT Spare Sensor and E-Box Housing |  | 2004-02-27 A |  | 32% → 100% | 445d → none |  |  |
| 544 | **Electronics** |  |  |  | 84% → 94% | 385d → 94d |  |  |
| 545 | **Assembly** |  |  |  | 86% → 97% | 396d → 105d |  |  |
| 549 | **Spare** |  |  |  | 69% → 94% | 396d → 105d |  |  |
| 550 | Assemble SEPT FS Electronics |  |  |  | 69% → 94% | 396d → 105d |  |  |
| 563 | **Integration & Test** |  | 2004-07-26 → 2004-08-31 (+36d) | 138d → 164d | 35% → 84% | 49d → 23d |  |  |
| 564 | **FM 1** |  | 2004-07-26 → 2004-08-31 (+36d) | 138d → 164d | 29% → 73% | 49d → 23d |  |  |
| 565 | **SEPT-NS** |  | 2004-07-26 → 2004-08-31 (+36d) | 129d → 155d | 29% → 73% | 49d → 23d |  |  |
| 568 | SEPT-NS FM 1 Vibration | 2004-02-17 → 2004-02-19 A (+2d) | 2004-02-20 → 2004-02-24 A (+4d) |  | 0% → 100% | 69d → none |  | constraint start no earlier than 2004-02-17 → start no earlier than 2004-02-19 |
| 569 | SEPT-NS FM 1 Thermal Vac | 2004-02-25 → 2004-02-27 A (+2d) | 2004-03-08 → 2004-03-12 A (+4d) | 9d → 11d | 0% → 100% | 71d → none |  |  |
| 570 | SEPT-NS FM 1 Bake Out | 2004-03-09 → 2004-03-05 A (-4d) | 2004-03-10 → 2004-03-08 A (-2d) |  | 0% → 100% | 71d → none | 569 → 569FS-6d |  |
| 571 | SEPT-NS FM 1 Thermal Balance (at GSFC after Suite EMC) | 2004-07-13 → 2004-08-18 (+36d) | 2004-07-26 → 2004-08-31 (+36d) |  |  | 49d → 23d |  |  |
| 572 | **SEPT-E** |  | 2004-07-26 → 2004-08-31 (+36d) | 138d → 164d | 29% → 73% | 49d → 23d |  |  |
| 575 | SEPT-E FM 1 Vibration | 2004-02-21 → 2004-02-19 A (-2d) | 2004-02-24 A |  | 0% → 100% | 73d → none | 568, 574 → 574, 568SS |  |
| 576 | SEPT-E FM 1 Thermal Vac | 2004-02-25 → 2004-02-27 A (+2d) | 2004-03-08 → 2004-03-12 A (+4d) | 9d → 11d | 0% → 100% | 71d → none |  |  |
| 577 | SEPT-E FM 1 Bake Out | 2004-03-09 → 2004-03-05 A (-4d) | 2004-03-10 → 2004-03-08 A (-2d) |  | 0% → 100% | 71d → none | 576 → 576FS-6d |  |
| 578 | SEPT-E FM 1 Thermal Balance (at GSFC after Suite EMC) | 2004-07-13 → 2004-08-18 (+36d) | 2004-07-26 → 2004-08-31 (+36d) |  |  | 49d → 23d |  |  |
| 579 | **FM 2** |  | 2004-03-19 → 2004-03-17 A (-2d) | 48d → 46d | 44% → 100% | 78d → none |  |  |
| 580 | **SEPT-NS** |  | 2004-03-19 → 2004-03-17 A (-2d) | 43d → 41d | 48% → 100% | 78d → none |  |  |
| 583 | SEPT-NS FM 2 Vibration | 2004-02-17 → 2004-02-19 A (+2d) | 2004-02-20 → 2004-02-24 A (+4d) |  | 0% → 100% | 87d → none |  |  |
| 584 | SEPT-NS FM 2 Thermal Vac | 2004-03-09 → 2004-03-05 A (-4d) | 2004-03-17 A |  | 0% → 100% | 78d → none | 583, 569 → 583 | constraint none → start no earlier than 2004-03-05 |
| 585 | SEPT-NS FM 2 Bake Out | 2004-03-18 → 2004-03-12 A (-6d) | 2004-03-19 → 2004-03-15 A (-4d) |  | 0% → 100% | 78d → none | 584 → 584FS-4d |  |
| 586 | **SEPT-E** |  | 2004-03-19 → 2004-03-17 A (-2d) | 48d → 46d | 40% → 100% | 78d → none |  |  |
| 589 | SEPT-E FM 2 Vibration | 2004-02-21 → 2004-02-19 A (-2d) | 2004-02-24 A |  | 0% → 100% | 87d → none | 588, 575SS → 588, 568SS |  |
| 590 | SEPT-E FM 2 Thermal Vac | 2004-03-09 → 2004-03-05 A (-4d) | 2004-03-17 A |  | 0% → 100% | 78d → none |  |  |
| 591 | SEPT-E FM 2 Bake Out | 2004-03-18 → 2004-03-12 A (-6d) | 2004-03-19 → 2004-03-15 A (-4d) |  | 0% → 100% | 78d → none | 590 → 590FS-4d |  |
| 592 | **SIT - UMD** |  | 2004-10-20 → 2004-10-25 (+5d) | 351d → 354d | 42% → 52% | 280d → 2d |  |  |
| 593 | **Deliveries** | 2004-06-18 → 2004-07-26 (+38d) | 2004-10-12 → 2004-10-25 (+13d) | 81d → 64d |  | 9d → -8d |  |  |
| 594 | Deliver SIT FM 1 to CIT for SEP I&T and Suite EMC | 2004-06-18 → 2004-07-26 (+38d) | 2004-06-21 → 2004-07-27 (+36d) |  |  | 9d → -8d |  |  |
| 595 | Deliver SIT FM 1 back to GSFC for Environmental Testing (after EMC Test) | 2004-07-13 → 2004-08-18 (+36d) | 2004-07-14 → 2004-08-19 (+36d) |  |  | 24d → -3d | 19 → 19, 412 |  |
| 596 | Final Delivery of SIT FM 1 to APL | 2004-09-01 → 2004-10-12 (+41d) | 2004-09-01 → 2004-10-12 (+41d) |  |  | 24d → -3d |  |  |
| 597 | Deliver SIT FM 2 to CIT for SEP I&T | 2004-07-23 → 2004-08-13 (+21d) | 2004-07-26 → 2004-08-16 (+21d) |  |  | 16d → 1d |  |  |
| 598 | Deliver SIT FM 2 back to GSFC for Environmental Testing | 2004-08-19 → 2004-08-31 (+12d) | 2004-08-20 → 2004-09-01 (+12d) |  |  | 11d → 2d |  |  |
| 599 | Final Delivery of SIT FM 2 to APL | 2004-10-12 → 2004-10-25 (+13d) | 2004-10-12 → 2004-10-25 (+13d) |  |  | 11d → 2d | 730 → 730, 736 |  |
| 600 | **ACTEL - for SIT Logic Board** | 2004-02-27 → 2004-05-17 (+80d) | 2004-03-12 → 2004-06-01 (+81d) |  |  | 60d → 13d |  |  |
| 601 | Burn Final SIT ACTEL Chip (at GSFC) | 2004-02-27 → 2004-05-17 (+80d) | 2004-02-27 → 2004-05-17 (+80d) |  |  | 60d → 13d |  | constraint start no earlier than 2004-02-27 → start no earlier than 2004-05-17 |
| 602 | Evaluate (Test) SIT Final ACTEL Chip | 2004-03-01 → 2004-05-18 (+78d) | 2004-03-12 → 2004-06-01 (+81d) |  |  | 60d → 13d |  |  |
| 603 | **TOF Boards** |  | 2004-03-11 → 2004-05-05 (+55d) | 20d → 59d | 0% → 48% | 67d → 28d |  |  |
| 604 | Receive Analog and Digital TOF Boards (FM 1) |  |  |  |  |  |  | was named Receive Analog and Digital TOF Boards (FM 1 & FM 2) |
| 606 | **Test** | 2004-02-12 → 2004-03-01 A (+18d) | 2004-03-11 → 2004-05-05 (+55d) | 20d → 48d | 0% → 64% | 42d → 28d |  |  |
| 607 | **FM 1** | 2004-02-12 → 2004-03-01 A (+18d) | 2004-02-26 → 2004-03-24 A (+27d) | 10d → 18d | 0% → 100% | 42d → none |  |  |
| 608 | FM 1 TOF Boards Functional Test | 2004-02-12 → 2004-03-01 A (+18d) | 2004-02-26 → 2004-03-24 A (+27d) | 10d → 18d | 0% → 100% | 42d → none |  | constraint none → start no earlier than 2004-03-01 |
| 609 | **FM 2** | 2004-02-27 → 2004-04-22 (+55d) | 2004-03-11 → 2004-05-05 (+55d) |  |  | 67d → 28d |  |  |
| 610 | FM 2 TOF Boards Functional Test | 2004-02-27 → 2004-04-22 (+55d) | 2004-03-11 → 2004-05-05 (+55d) |  |  | 67d → 28d | 604, 608 → 604, 605 |  |
| 611 | **Energy Board** |  | 2004-04-02 → 2004-05-14 (+42d) | 99d → 129d | 65% → 83% | 51d → 21d |  |  |
| 612 | **Assembly** |  | 2004-02-20 → 2004-04-23 (+63d) | 69d → 114d | 80% → 94% | 66d → 21d |  |  |
| 613 | **FM 1** |  | 2004-02-20 → 2004-03-24 A (+33d) | 69d → 92d | 80% → 100% | 31d → none |  |  |
| 614 | Assemble FM 1 Energy Board |  | 2004-02-20 → 2004-03-24 A (+33d) | 69d → 92d | 80% → 100% | 31d → none |  |  |
| 615 | **FM 2** |  | 2004-02-20 → 2004-04-23 (+63d) | 69d → 114d | 80% → 88% | 66d → 21d |  |  |
| 616 | Assemble FM 2 Energy Board |  | 2004-02-20 → 2004-04-23 (+63d) | 69d → 84d | 80% → 88% | 66d → 21d | 614SS → 614FF+22d |  |
| 617 | **Test** | 2004-02-23 → 2004-03-25 A (+31d) | 2004-04-02 → 2004-05-14 (+42d) | 30d → 37d | 0% → 17% | 31d → 21d |  |  |
| 618 | **FM 1** | 2004-02-23 → 2004-03-25 A (+31d) | 2004-03-12 → 2004-04-14 (+33d) |  | 0% → 33% | 31d → 17d |  |  |
| 619 | Bench Test/Calibration | 2004-02-23 → 2004-03-25 A (+31d) | 2004-03-05 → 2004-04-07 (+33d) |  | 0% → 50% | 31d → 17d |  |  |
| 620 | Thermal | 2004-03-08 → 2004-04-08 (+31d) | 2004-03-10 → 2004-04-12 (+33d) |  |  | 31d → 17d |  |  |
| 621 | Voltage Margin | 2004-03-11 → 2004-04-13 (+33d) | 2004-03-12 → 2004-04-14 (+33d) |  |  | 31d → 17d |  |  |
| 622 | **FM 2** | 2004-03-15 → 2004-04-26 (+42d) | 2004-04-02 → 2004-05-14 (+42d) |  |  | 51d → 21d |  |  |
| 623 | FM 2 Energy Board Functional Test | 2004-03-15 → 2004-04-26 (+42d) | 2004-04-02 → 2004-05-14 (+42d) |  |  | 51d → 21d |  |  |
| 624 | **Logic Board** |  | 2004-07-09 → 2004-07-30 (+21d) | 168d → 183d | 39% → 61% | 16d → 1d |  |  |
| 627 | **Fabrication** | 2004-02-09 → 2004-03-08 A (+28d) | 2004-02-23 → 2004-03-19 A (+25d) |  | 0% → 100% | 9d → none |  |  |
| 628 | FM 1 & FM 2 Logic Board Fabrication | 2004-02-09 → 2004-03-08 A (+28d) | 2004-02-23 → 2004-03-19 A (+25d) |  | 0% → 100% | 9d → none |  |  |
| 629 | **Assembly** | 2004-03-09 → 2004-04-14 (+36d) | 2004-07-07 → 2004-07-28 (+21d) | 86d → 75d |  | 9d → -8d |  |  |
| 630 | **FM 1** | 2004-03-09 → 2004-04-14 (+36d) | 2004-05-27 → 2004-07-05 (+39d) |  |  | 9d → -8d |  |  |
| 631 | Assemble FM 1 Logic Board with ETU ACTELs | 2004-03-09 → 2004-04-14 (+36d) | 2004-03-23 → 2004-04-28 (+36d) |  |  | 9d → -8d | 644 → 644FS+9d |  |
| 632 | Disassembel FM 1 Logic Board with ETU ACTELs | 2004-05-24 → 2004-06-30 (+37d) | 2004-05-24 → 2004-06-30 (+37d) |  |  | 9d → -8d |  |  |

| ID | Task | Start | Finish | Duration | Complete | Total float | Predecessors | Other |
| --- | --- | --- | --- | --- | --- | --- | --- | --- |
| 633 | Retrofit/Inspect FM 1 Flight ACTELs | 2004-05-25 → 2004-07-01 (+37d) | 2004-05-26 → 2004-07-02 (+37d) |  |  | 9d → -8d |  |  |
| 634 | Reassemble FM 1 Logic Board with Flight ACTELs | 2004-05-27 → 2004-07-05 (+39d) | 2004-05-27 → 2004-07-05 (+39d) |  |  | 9d → -8d |  |  |
| 635 | **FM 2** | 2004-03-09 → 2004-04-14 (+36d) | 2004-07-07 → 2004-07-28 (+21d) | 86d → 75d |  | 16d → 1d |  |  |
| 636 | Assemble FM 2 Logic Board with ETU ACTELS | 2004-03-09 → 2004-04-14 (+36d) | 2004-03-23 → 2004-04-28 (+36d) |  |  | 44d → 18d | 644 → 644FS+9d |  |
| 637 | Disassemble FM 2 Logic Boards | 2004-07-02 → 2004-07-23 (+21d) | 2004-07-02 → 2004-07-23 (+21d) |  |  | 16d → 1d |  |  |
| 638 | Retrofit/Inspect Flight ACTELS | 2004-07-05 → 2004-07-26 (+21d) | 2004-07-06 → 2004-07-27 (+21d) |  |  | 16d → 1d |  |  |
| 639 | Reassemble FM 2 Logic Boards | 2004-07-07 → 2004-07-28 (+21d) | 2004-07-07 → 2004-07-28 (+21d) |  |  | 16d → 1d |  |  |
| 640 | **Test** |  | 2004-07-09 → 2004-07-30 (+21d) | 168d → 183d | 53% → 72% | 16d → 1d |  |  |
| 641 | **ETU** |  | 2004-02-06 → 2004-03-05 A (+28d) | 60d → 79d | 92% → 100% | 9d → none |  |  |
| 642 | Test New ETU Logic Board |  | 2004-02-06 → 2004-03-05 A (+28d) | 60d → 79d | 92% → 100% | 9d → none |  |  |
| 643 | **FM1 & FM 2** | 2004-02-24 → 2004-03-22 A (+27d) | 2004-03-08 → 2004-03-31 A (+23d) | 10d → 8d | 0% → 100% | 9d → none |  |  |
| 644 | Coupon Testing | 2004-02-24 → 2004-03-22 A (+27d) | 2004-03-08 → 2004-03-31 A (+23d) | 10d → 8d | 0% → 100% | 9d → none |  |  |
| 645 | **FM 1** | 2004-03-24 → 2004-04-29 (+36d) | 2004-06-01 → 2004-07-07 (+36d) |  |  | 9d → -8d |  |  |
| 646 | Functional Test of FM 1 Logic Board w/ETU ACTELS | 2004-03-24 → 2004-04-29 (+36d) | 2004-04-13 → 2004-05-19 (+36d) |  |  | 9d → -8d |  |  |
| 647 | Funtional Test of FM 1 Logic Board w/Flight ACTELS | 2004-05-28 → 2004-07-06 (+39d) | 2004-06-01 → 2004-07-07 (+36d) |  |  | 9d → -8d |  |  |
| 648 | **FM 2** | 2004-04-14 → 2004-05-20 (+36d) | 2004-07-09 → 2004-07-30 (+21d) | 62d → 51d |  | 16d → 1d |  |  |
| 649 | Functional Test of FM 2 Logic Board w/ETU ACTELS | 2004-04-14 → 2004-05-20 (+36d) | 2004-05-04 → 2004-06-10 (+37d) |  |  | 29d → 3d |  |  |
| 650 | Functional Test of FM 2 Logic Board w/Flight ACTELS | 2004-07-08 → 2004-07-29 (+21d) | 2004-07-09 → 2004-07-30 (+21d) |  |  | 16d → 1d |  |  |
| 651 | **Mother Board** |  | 2004-03-25 → 2004-05-24 (+60d) | 65d → 107d | 30% → 59% | 426d → 2d |  |  |
| 652 | **Design** |  | 2004-02-04 → 2004-03-29 A (+54d) | 30d → 67d | 90% → 100% | 27d → none |  |  |
| 653 | **FM 1 & FM 2** |  | 2004-02-04 → 2004-03-29 A (+54d) | 30d → 67d | 90% → 100% | 27d → none |  |  |
| 654 | Finalize Mother Board Layout |  | 2004-02-04 A |  | 90% → 100% | 27d → none |  |  |
| 656 | **Fabrication** | 2004-02-05 A | 2004-02-26 → 2004-04-19 (+53d) | 15d → 52d | 0% → 57% | 27d → 0d |  |  |
| 657 | **FM 1 & FM 2** | 2004-02-05 A | 2004-02-26 → 2004-04-19 (+53d) | 15d → 52d | 0% → 57% | 27d → 0d |  |  |
| 658 | Fabricate FM 1 & FM 2 Mother Boards | 2004-02-05 A | 2004-02-26 A |  | 0% → 100% | 27d → none | 654 → none |  |
| 660 | **Assembly** | 2004-02-27 → 2004-04-27 (+60d) | 2004-03-11 → 2004-05-10 (+60d) |  |  | 27d → -6d |  |  |
| 661 | Assemble FM 1 Mother Board | 2004-02-27 → 2004-04-27 (+60d) | 2004-03-11 → 2004-05-10 (+60d) |  |  | 27d → -6d | 658 → 658, 666 | constraint none → start no earlier than 2004-03-15 |
| 662 | Assemble FM 2 Mother Board | 2004-02-27 → 2004-04-27 (+60d) | 2004-03-11 → 2004-05-10 (+60d) |  |  | 49d → 7d |  |  |
| 663 | **Test** | 2004-02-27 A | 2004-03-25 → 2004-05-24 (+60d) | 20d → 62d | 0% → 25% | 37d → 2d |  |  |
| 664 | **FM 1 & FM 2** | 2004-02-27 A | 2004-03-18 → 2004-04-26 (+39d) | 15d → 42d | 0% → 50% | 431d → -6d |  |  |
| 665 | Coupon Testing of Mother Boards | 2004-02-27 A | 2004-03-18 → 2004-03-04 A (-14d) | 15d → 5d | 0% → 100% | 431d → none | 658 → none |  |
| 667 | **FM 1** | 2004-03-12 → 2004-05-11 (+60d) | 2004-03-18 → 2004-05-17 (+60d) |  |  | 27d → -6d |  |  |
| 668 | Functional Test FM 1 Mother Board | 2004-03-12 → 2004-05-11 (+60d) | 2004-03-18 → 2004-05-17 (+60d) |  |  | 27d → -6d |  |  |
| 669 | **FM 2** | 2004-03-19 → 2004-05-18 (+60d) | 2004-03-25 → 2004-05-24 (+60d) |  |  | 44d → 2d |  |  |
| 670 | Functional Test FM 2 Mother Board | 2004-03-19 → 2004-05-18 (+60d) | 2004-03-25 → 2004-05-24 (+60d) |  |  | 44d → 2d |  |  |
| 671 | **HVPS** |  | 2004-04-27 → 2004-06-08 (+42d) | 75d → 104d | 47% → 75% | 31d → 2d |  |  |
| 672 | **Test** |  | 2004-04-27 → 2004-06-08 (+42d) | 75d → 104d | 47% → 75% | 31d → 2d |  |  |
| 673 | **FM 1** |  | 2004-02-09 → 2004-02-24 A (+15d) | 20d → 30d | 70% → 100% | 51d → none |  |  |
| 674 | Functional Test SIT FM 1 HVPS |  | 2004-02-09 → 2004-02-24 A (+15d) | 20d → 30d | 70% → 100% | 51d → none |  |  |
| 675 | **FM 2** | 2004-04-14 → 2004-05-25 (+41d) | 2004-04-27 → 2004-06-08 (+42d) |  |  | 31d → 2d |  |  |
| 676 | Functional Test SIT FM 2 HVPS | 2004-04-14 → 2004-05-25 (+41d) | 2004-04-27 → 2004-06-08 (+42d) |  |  | 31d → 2d |  |  |
| 677 | **Flight Software** |  |  |  | 80% → 89% | 44d → 53d |  |  |
| 678 | **Test** |  |  |  | 80% → 89% | 44d → 53d |  |  |
| 679 | **FM 1 & FM 2** |  |  |  | 80% → 89% | 44d → 53d |  |  |
| 680 | Validate SIT On-Board Code |  |  |  | 80% → 89% | 44d → 53d |  |  |
| 681 | **Integration & Test (using ETU Telescope for FM 1)** | 2004-03-31 → 2004-02-25 A (-35d) | 2004-07-22 → 2004-08-12 (+21d) | 81d → 121d | 0% → 4% | 16d → 1d |  |  |
| 682 | **FM 1 (Flight Telescope)** | 2004-06-02 → 2004-07-08 (+36d) | 2004-06-17 → 2004-07-23 (+36d) |  |  | 9d → -8d |  |  |
| 683 | Disassemble SIT FM 1 | 2004-06-02 → 2004-07-08 (+36d) | 2004-06-02 → 2004-07-08 (+36d) |  |  | 9d → -8d |  |  |
| 684 | Conformal Coat SIT FM 1 Boards (includes FM 1 LVPS) | 2004-06-03 → 2004-07-09 (+36d) | 2004-06-04 → 2004-07-12 (+38d) |  |  | 9d → -8d |  | was named Conformal Coat SIT FM 1 Boards |
| 685 | Reassemble SIT FM 1 with Flight Telescope | 2004-06-07 → 2004-07-13 (+36d) | 2004-06-07 → 2004-07-13 (+36d) |  |  | 9d → -8d | 684, 399 → 684, 399, 365 |  |
| 686 | Bench Calibration SIT FM 1 w/Flight Telescope | 2004-06-08 → 2004-07-14 (+36d) | 2004-06-10 → 2004-07-16 (+36d) |  |  | 9d → -8d |  |  |
| 687 | Vacuum Test SIT FM 1 w/Flight Telescope | 2004-06-11 → 2004-07-19 (+38d) | 2004-06-17 → 2004-07-23 (+36d) |  |  | 9d → -8d |  |  |
| 688 | **FM 2** | 2004-07-12 → 2004-08-02 (+21d) | 2004-07-22 → 2004-08-12 (+21d) |  |  | 16d → 1d |  |  |
| 689 | Disassemble SIT FM 2 | 2004-07-12 → 2004-08-02 (+21d) | 2004-07-12 → 2004-08-02 (+21d) |  |  | 16d → 1d |  |  |
| 690 | Conformal Coat SIT FM 2 Boards | 2004-07-13 → 2004-08-03 (+21d) | 2004-07-14 → 2004-08-04 (+21d) |  |  | 16d → 1d |  |  |
| 691 | Reassemble SIT FM 2 | 2004-07-15 → 2004-08-05 (+21d) | 2004-07-15 → 2004-08-05 (+21d) |  |  | 16d → 1d |  |  |
| 692 | Post-Coat Retest SIT FM 2 | 2004-07-16 → 2004-08-06 (+21d) | 2004-07-22 → 2004-08-12 (+21d) |  |  | 16d → 1d |  |  |
| 693 | **FM 1 (ETU Telescope)** | 2004-03-31 → 2004-02-25 A (-35d) | 2004-05-21 → 2004-06-29 (+39d) | 38d → 89d | 0% → 10% | 9d → -8d |  |  |
| 694 | Integrate SIT FM 1 HVPS and SIT ETU Telescope Without Electronics | 2004-03-31 → 2004-02-25 A (-35d) | 2004-04-02 → 2004-02-27 A (-35d) |  | 0% → 100% | 16d → none | 674, Alpha Tests FM 1 w/Proto Elect → 674 |  |
| 695 | Integrate Electronics to SIT ETU Telescope | 2004-04-14 → 2004-05-20 (+36d) | 2004-04-15 → 2004-05-21 (+36d) |  |  | 9d → -8d |  |  |
| 696 | SIT FM 1 Debug | 2004-04-16 → 2004-05-24 (+38d) | 2004-04-22 → 2004-05-28 (+36d) |  |  | 9d → -8d |  |  |
| 697 | SIT FM 1 Bench Test | 2004-04-23 → 2004-06-01 (+39d) | 2004-04-29 → 2004-06-07 (+39d) |  |  | 9d → -8d |  |  |
| 698 | SIT FM 1 Alpha TEST | 2004-04-30 → 2004-06-08 (+39d) | 2004-05-06 → 2004-06-14 (+39d) |  |  | 9d → -8d |  |  |
| 699 | SIT FM 1 Noise Removal | 2004-05-07 → 2004-06-15 (+39d) | 2004-05-13 → 2004-06-21 (+39d) |  |  | 9d → -8d |  |  |
| 700 | SIT FM 1 Thermal Test | 2004-05-14 → 2004-06-22 (+39d) | 2004-05-20 → 2004-06-28 (+39d) |  |  | 9d → -8d |  |  |
| 701 | SIT FM 1 Functional Test | 2004-05-21 → 2004-06-29 (+39d) | 2004-05-21 → 2004-06-29 (+39d) |  |  | 9d → -8d |  |  |
| 702 | **FM 2** | 2004-05-19 → 2004-06-10 (+22d) | 2004-07-01 → 2004-07-22 (+21d) |  |  | 16d → 1d |  |  |
| 703 | Integrate SIT FM 2 HVPS and SIT FM 2 Telescope Without Electronics | 2004-05-19 → 2004-06-10 (+22d) | 2004-05-21 → 2004-06-14 (+24d) |  |  | 16d → 1d | 676, Alpha Tests FM 2 w/Proto Elect, 399 → 676, 399, 365 |  |
| 704 | Integrate Electronics to SIT FM 2 Telescope | 2004-05-24 → 2004-06-15 (+22d) | 2004-05-25 → 2004-06-16 (+22d) |  |  | 16d → 1d |  |  |
| 705 | SIT FM 2 Debug | 2004-05-26 → 2004-06-17 (+22d) | 2004-06-02 → 2004-06-23 (+21d) |  |  | 16d → 1d |  |  |

| ID | Task | Start | Finish | Duration | Complete | Total float | Predecessors | Other |
| --- | --- | --- | --- | --- | --- | --- | --- | --- |
| 706 | SIT FM 2 Bench Test | 2004-06-03 → 2004-06-24 (+21d) | 2004-06-09 → 2004-06-30 (+21d) |  |  | 16d → 1d |  |  |
| 707 | SIT FM 2 Alpha Test | 2004-06-10 → 2004-07-01 (+21d) | 2004-06-16 → 2004-07-07 (+21d) |  |  | 16d → 1d |  |  |
| 708 | SIT FM 2 Noise Removal | 2004-06-17 → 2004-07-08 (+21d) | 2004-06-23 → 2004-07-14 (+21d) |  |  | 16d → 1d |  |  |
| 709 | SIT FM 2 Thermal Test | 2004-06-24 → 2004-07-15 (+21d) | 2004-06-30 → 2004-07-21 (+21d) |  |  | 16d → 1d |  |  |
| 710 | SIT FM 2 Functional Test | 2004-07-01 → 2004-07-22 (+21d) | 2004-07-01 → 2004-07-22 (+21d) |  |  | 16d → 1d |  |  |
| 713 | **Environmental Testing at GSFC (FM 1)** | 2004-07-15 → 2004-08-23 (+39d) | 2004-08-31 → 2004-10-08 (+38d) |  |  | 24d → -3d |  |  |
| 714 | SIT FM 1 Vibration and Acoustics | 2004-07-15 → 2004-08-23 (+39d) | 2004-07-28 → 2004-09-03 (+37d) |  |  | 24d → -3d | 595 → 595, 711 | constraint none → start no earlier than 2004-08-23 |
| 715 | Functional Test | 2004-07-29 → 2004-09-07 (+40d) | 2004-07-29 → 2004-09-07 (+40d) |  |  | 24d → -3d |  |  |
| 716 | SIT FM 1 Thermal Balance | 2004-07-30 → 2004-09-08 (+40d) | 2004-08-05 → 2004-09-14 (+40d) |  |  | 24d → -3d |  |  |
| 717 | SIT FM 1 Thermal Vac | 2004-08-06 → 2004-09-15 (+40d) | 2004-08-19 → 2004-09-28 (+40d) |  |  | 24d → -3d |  |  |
| 718 | Disassemble SIT Instruments | 2004-08-20 → 2004-09-29 (+40d) | 2004-08-23 → 2004-09-30 (+38d) |  |  | 24d → -3d |  |  |
| 719 | Bake Out | 2004-08-24 → 2004-10-01 (+38d) | 2004-08-26 → 2004-10-05 (+40d) |  |  | 24d → -3d |  |  |
| 720 | Reassemble Instruments | 2004-08-27 → 2004-10-06 (+40d) | 2004-08-30 → 2004-10-07 (+38d) |  |  | 24d → -3d |  |  |
| 721 | Functional Test | 2004-08-31 → 2004-10-08 (+38d) | 2004-08-31 → 2004-10-08 (+38d) |  |  | 24d → -3d |  |  |
| 722 | **Environmental Testing at GSFC (FM 2)** | 2004-08-23 → 2004-09-03 (+11d) | 2004-10-08 → 2004-10-22 (+14d) |  |  | 11d → 2d |  |  |
| 723 | SIT FM 2 Vibration and Acoustics | 2004-08-23 → 2004-09-03 (+11d) | 2004-09-03 → 2004-09-17 (+14d) |  |  | 11d → 2d | 598 → 598, 712 | constraint none → start no earlier than 2004-09-02 |
| 724 | Functional Test | 2004-09-07 → 2004-09-20 (+13d) | 2004-09-07 → 2004-09-20 (+13d) |  |  | 11d → 2d |  |  |
| 725 | SIT FM 2 Thermal Balance | 2004-09-08 → 2004-09-21 (+13d) | 2004-09-14 → 2004-09-27 (+13d) |  |  | 11d → 2d |  |  |
| 726 | SIT FM 2 Thermal Vac | 2004-09-15 → 2004-09-28 (+13d) | 2004-09-28 → 2004-10-12 (+14d) |  |  | 11d → 2d |  |  |
| 727 | Disassemble SIT Instruments | 2004-09-29 → 2004-10-13 (+14d) | 2004-09-30 → 2004-10-14 (+14d) |  |  | 11d → 2d |  |  |
| 728 | Bake Out | 2004-10-01 → 2004-10-15 (+14d) | 2004-10-05 → 2004-10-19 (+14d) |  |  | 11d → 2d |  |  |
| 729 | Reassemble Instruments | 2004-10-06 → 2004-10-20 (+14d) | 2004-10-07 → 2004-10-21 (+14d) |  |  | 11d → 2d |  |  |
| 730 | Functional Test | 2004-10-08 → 2004-10-22 (+14d) | 2004-10-08 → 2004-10-22 (+14d) |  |  | 11d → 2d |  |  |
| 731 | **Emulators/Simulators/GSE** |  | 2004-10-20 → 2004-10-13 (-7d) | 214d → 209d | 27% → 10% | 280d → 9d |  |  |
| 732 | **Simulators** |  |  |  | 38% → 13% | 414d → 98d |  |  |
| 733 | Labview CPU Ready |  |  |  | 38% → 13% | 414d → 0d |  | constraint start no earlier than 2003-12-17 → must start on 2003-12-17 |
| 734 | Test Simulator |  |  |  | 38% → 13% | 414d → 98d |  |  |
| 735 | **GSE** | 2004-07-27 → 2004-08-17 (+21d) | 2004-10-20 → 2004-10-13 (-7d) | 60d → 40d |  | 280d → 9d |  |  |
| 736 | Pulse Generator | 2004-07-27 → 2004-08-17 (+21d) | 2004-10-20 → 2004-10-13 (-7d) | 60d → 40d |  | 280d → 9d | 594, 597 → 594, 597, 734 |  |
| 737 | **SEP Suite I&T - CIT** |  |  |  | 32% → 33% | 279d → 5d |  |  |
| 740 | **FM 1 & FM 2** | 2004-03-05 → 2004-03-09 (+4d) | 2004-10-21 → 2004-07-22 (-91d) | 162d → 97d |  | 75d → -3d |  |  |
| 741 | Generate SEPT integration & test procedure | 2004-03-05 → 2004-03-09 (+4d) | 2004-03-11 → 2004-06-15 (+96d) | 5d → 70d |  | 76d → 8d |  |  |
| 742 | Generate LET integration & test procedure | 2004-05-05 → 2004-06-03 (+29d) | 2004-05-11 → 2004-06-09 (+29d) |  |  | 34d → 13d |  |  |
| 743 | Generate HET integration & test procedure | 2004-05-20 → 2004-06-21 (+32d) | 2004-05-26 → 2004-06-25 (+30d) |  |  | 24d → 2d |  |  |
| 744 | Generate SIT integration & test procedure | 2004-06-09 → 2004-07-15 (+36d) | 2004-06-15 → 2004-07-21 (+36d) |  |  | 14d → -3d |  |  |
| 745 | Generate SEP system test procedure | 2004-06-10 → 2004-07-16 (+36d) | 2004-06-16 → 2004-07-22 (+36d) |  |  | 14d → -3d |  |  |
| 746 | Generate SEP-IDPU integration procedure | 2004-05-27 → 2004-06-22 (+26d) | 2004-06-03 → 2004-06-28 (+25d) |  |  | 16d → 8d |  |  |
| 747 | Generate SEP-IDPU test procedure | 2004-06-04 → 2004-06-29 (+25d) | 2004-06-10 → 2004-07-05 (+25d) |  |  | 16d → 8d |  |  |
| 748 | **FM 1** | 2004-03-18 → 2004-03-22 (+4d) | 2004-06-28 → 2004-08-03 (+36d) | 72d → 96d |  | 9d → -8d |  |  |
| 749 | Integrate/test SEP Central FM 1 | 2004-05-11 → 2004-06-02 (+22d) | 2004-05-17 → 2004-06-08 (+22d) |  |  | 29d → 13d |  |  |
| 750 | Receive & inspect SEPT FM 1 | 2004-03-18 → 2004-03-22 (+4d) | 2004-03-18 → 2004-03-22 (+4d) |  |  | 71d → 8d |  |  |
| 751 | Integrate & test SEPT FM 1 | 2004-05-18 → 2004-06-16 (+29d) | 2004-05-18 → 2004-06-16 (+29d) |  |  | 29d → 8d |  |  |
| 752 | Integrate & test LET FM 1 | 2004-06-09 → 2004-06-30 (+21d) | 2004-06-09 → 2004-06-30 (+21d) |  |  | 15d → -1d |  |  |
| 753 | Receive & inspect HET FM 1 | 2004-06-03 → 2004-07-02 (+29d) | 2004-06-03 → 2004-07-02 (+29d) |  |  | 19d → -3d |  |  |
| 754 | Integrate & test HET FM 1 | 2004-06-10 → 2004-07-05 (+25d) | 2004-06-10 → 2004-07-05 (+25d) |  |  | 15d → -3d |  |  |
| 755 | Integrate SEP FM 1 - IDPU FM 1 | 2004-06-11 → 2004-07-22 (+41d) | 2004-06-11 → 2004-07-22 (+41d) |  |  | 15d → -5d | 746, 754 → 746, 754, 160, 790, 451 |  |
| 756 | Test SEP FM 1 - IDPU FM 1 | 2004-06-22 → 2004-07-23 (+31d) | 2004-06-22 → 2004-07-23 (+31d) |  |  | 9d → -5d | 747, 755, 351 → 747, 755 |  |
| 757 | Receive & inspect SIT FM 1 | 2004-06-22 → 2004-07-28 (+36d) | 2004-06-22 → 2004-07-28 (+36d) |  |  | 9d → -8d |  |  |
| 758 | Integrate & test SIT FM 1 | 2004-06-23 → 2004-07-29 (+36d) | 2004-06-23 → 2004-07-29 (+36d) |  |  | 9d → -8d |  |  |
| 759 | SEP system test FM 1 | 2004-06-24 → 2004-07-30 (+36d) | 2004-06-28 → 2004-08-03 (+36d) |  |  | 9d → -8d |  |  |
| 760 | **FM 2** | 2004-03-29 → 2004-03-25 (-4d) | 2004-08-11 → 2004-08-23 (+12d) | 97d → 107d |  | 9d → 26d |  |  |
| 761 | Integrate/testSEP Central FM 2 | 2004-05-11 → 2004-06-28 (+48d) | 2004-05-17 → 2004-07-02 (+46d) |  |  | 43d → 37d |  |  |
| 762 | Receive & inspect SEPT FM 2 | 2004-03-29 → 2004-03-25 (-4d) | 2004-03-29 → 2004-03-25 (-4d) |  |  | 78d → 107d |  |  |
| 763 | Integrate & test SEPT FM 2 | 2004-05-18 → 2004-07-05 (+48d) | 2004-05-18 → 2004-07-05 (+48d) |  |  | 43d → 37d |  |  |
| 764 | Integrate & test LET FM 2 | 2004-06-09 → 2004-07-06 (+27d) | 2004-06-09 → 2004-07-06 (+27d) |  |  | 29d → 37d |  |  |
| 765 | Receive & inspect HET FM 2 | 2004-06-24 → 2004-07-09 (+15d) | 2004-06-24 → 2004-07-09 (+15d) |  |  | 18d → 34d |  |  |
| 766 | Integrate & test HET FM 2 | 2004-06-25 → 2004-07-12 (+17d) | 2004-06-25 → 2004-07-12 (+17d) |  |  | 18d → 34d |  |  |
| 767 | Integrate SEP FM 2 - IDPU FM 2 | 2004-06-28 → 2004-08-05 (+38d) | 2004-06-28 → 2004-08-05 (+38d) |  |  | 18d → 37d |  |  |
| 768 | Test SEP FM 2 - IDPU FM 2 | 2004-06-29 → 2004-08-06 (+38d) | 2004-06-29 → 2004-08-06 (+38d) |  |  | 18d → 37d | 747, 767 → 747, 767, 453 |  |
| 769 | Receive & inspect SIT FM 2 | 2004-07-27 → 2004-08-17 (+21d) | 2004-07-27 → 2004-08-17 (+21d) |  |  | 16d → 1d |  |  |
| 770 | Integrate & test SIT FM 2 | 2004-08-06 → 2004-08-18 (+12d) | 2004-08-06 → 2004-08-18 (+12d) |  |  | 9d → 1d | 744, 769, 784 → 744, 769 |  |
| 771 | SEP FM 2 system test | 2004-08-09 → 2004-08-19 (+10d) | 2004-08-11 → 2004-08-23 (+12d) |  |  | 9d → 1d |  |  |
| 772 | **Environmental Test (at JPL)** |  | 2004-09-24 → 2004-10-21 (+27d) | 93d → 111d |  | 23d → 5d |  |  |
| 775 | **FM 1** | 2004-07-23 → 2004-08-23 (+31d) | 2004-09-24 → 2004-10-19 (+25d) | 45d → 40d |  | 9d → -8d |  |  |
| 776 | FM 1 LET/HET/SEP Central Vibration/Acoustics Test | 2004-07-23 → 2004-08-23 (+31d) | 2004-08-05 → 2004-09-03 (+29d) |  |  | 13d → -8d |  |  |
| 777 | FM 1 LET/HET/SEP Central Thermal Balance Test | 2004-08-06 → 2004-09-07 (+32d) | 2004-08-12 → 2004-09-13 (+32d) |  |  | 13d → -8d |  |  |
| 778 | FM 1 LET/HET/SEP Central T/V Test | 2004-08-19 → 2004-09-14 (+26d) | 2004-09-09 → 2004-10-04 (+25d) |  |  | 9d → -8d |  |  |
| 779 | Evaluate SEP performance | 2004-09-10 → 2004-10-05 (+25d) | 2004-09-23 → 2004-10-19 (+26d) |  |  | 9d → -8d |  |  |
| 780 | Generate test reports | 2004-09-10 → 2004-09-23 (+13d) | 2004-09-24 → 2004-10-07 (+13d) |  |  | 9d → -8d |  |  |
| 781 | Bakeout Clean SEP exterior & prepare for delivery | 2004-09-10 → 2004-10-05 (+25d) | 2004-09-14 → 2004-10-07 (+23d) |  |  | 16d → -1d |  |  |

| ID | Task | Start | Finish | Duration | Complete | Total float | Predecessors | Other |
| --- | --- | --- | --- | --- | --- | --- | --- | --- |
| 782 | **FM 2** | 2004-07-23 → 2004-08-24 (+32d) | 2004-09-24 → 2004-10-21 (+27d) | 45d → 41d |  | 9d → 1d |  |  |
| 783 | FM 2 EMI/EMC Test at CalTech | 2004-08-12 → 2004-08-24 (+12d) | 2004-08-18 → 2004-08-30 (+12d) |  |  | 9d → 1d |  |  |
| 784 | FM 2 LET/HET/SEP Central Vibration/Acoustics Test | 2004-07-23 → 2004-08-31 (+39d) | 2004-08-05 → 2004-09-14 (+40d) |  |  | 9d → 5d | 793FS+3d → 793FS+3d, 783 |  |
| 785 | FM 2 LET/HET/SEP Central T/V Test | 2004-08-19 → 2004-09-15 (+27d) | 2004-09-09 → 2004-10-05 (+26d) |  |  | 23d → 5d | 783 → 783, 784 |  |
| 786 | Evaluate SEP performance | 2004-09-10 → 2004-10-06 (+26d) | 2004-09-23 → 2004-10-20 (+27d) |  |  | 23d → 5d |  |  |
| 787 | Generate test reports | 2004-09-10 → 2004-10-06 (+26d) | 2004-09-24 → 2004-10-21 (+27d) |  |  | 23d → 5d |  |  |
| 788 | Bakeout Clean SEP exterior & prepare for delivery | 2004-09-10 → 2004-10-06 (+26d) | 2004-09-14 → 2004-10-08 (+24d) |  |  | 30d → 12d |  |  |
| 789 | **Accelerator Test (at MSU)** | 2004-07-13 → 2004-07-10 (-3d) | 2004-07-19 → 2004-07-16 (-3d) |  |  | 9d → -7d |  |  |
| 790 | FM 1 LET/SEP Cen end-to-end test at Accelerator | 2004-07-13 → 2004-07-10 (-3d) | 2004-07-19 → 2004-07-12 (-7d) | 5d → 3d |  | 9d → -7d | 800, 19, 406 → 800, 406, 754 | constraint none → start no earlier than 2004-07-10 |
| 793 | FM 2 LET/SEP Cen end-to-end test at Accelerator |  | 2004-07-19 → 2004-07-15 (-4d) | 5d → 3d |  | 9d → 34d | 790SS, 768 → 790SS, 766 |  |
| 796 | **GSE** |  |  |  | 55% → 48% | 283d → 9d |  |  |
| 801 | **GSE software** |  |  |  | 34% → 27% | 283d → 9d |  |  |
| 802 | Build GSE software release 2 |  | 2004-03-18 → 2004-07-02 (+106d) | 157d → 232d | 66% → 45% | 306d → 0d |  | constraint start no earlier than 2003-08-01 → must start on 2003-08-01 |
| 803 | Write user's guide | 2004-03-22 → 2004-06-21 (+91d) | 2004-03-31 → 2004-07-02 (+93d) | 8d → 10d |  | 305d → 10d | 802 → 802FS-10d |  |
| 804 | Build GSE software release 3 |  |  |  |  | 283d → 9d | 803 → 803FS-45d |  |
| 805 | Write user's guide supplement | 2004-09-15 → 2004-09-17 (+2d) |  | 22d → 20d |  | 283d → 9d | 804FS-22d → 804FS-20d | constraint none → finish no later than 2004-10-28 |
| 806 | **SWEA and SIT Refurbishment (after S/C Environmental Testing)** |  | 2005-11-18 → 2005-11-21 (+3d) | 39d → 40d |  |  |  |  |
| 815 | Ship SWEA FM 1 & 2 to Launch Site for Re-integration to S/C | 2005-10-07 → 2005-10-14 (+7d) | 2005-10-11 → 2005-10-18 (+7d) |  |  | 24d → 20d | 811 → 811, 813 |  |
| 816 | Ship SIT FM 1 & 2 to Launch Site for Re-integration to S/C | 2005-10-05 → 2005-10-12 (+7d) | 2005-10-07 → 2005-10-14 (+7d) |  |  | 26d → 22d | 812 → 812, 814 |  |
| 817 | Reintegration of SWEA and SIT to S/C (at Launch Site) | 2005-10-12 → 2005-10-19 (+7d) | 2005-10-14 → 2005-10-21 (+7d) |  |  | 24d → 20d |  |  |
| 818 | Target Date for Reintegration to S/C | 2005-11-18 → 2005-11-19 (+1d) | 2005-11-18 → 2005-11-21 (+3d) |  |  |  |  | constraint must start on 2005-11-18 → must start on 2005-11-19 |

## Version 4 (data date 2004-04-30, saved 2004-08-06, file IMPACT Master Schedule_ Aug 6 2004.mpp)

Last finish stays 2005-11-21. Complete tasks 169 → 335.

Added:

| ID | Task | Duration | Start | Finish | Predecessors | Constraint | Resources |
| --- | --- | --- | --- | --- | --- | --- | --- |
| 120 | Replace ACTEL | 1d | 2004-07-29 A | 2004-07-29 A | 119FS+6d |  |  |
| 158 | **Replacement of LTC1877s** | 253.5d | 2003-10-01 | 2004-10-04 |  |  |  |
| 159 | Receive screened units | 0d | 2004-08-27 | 2004-08-27 |  | finish no earlier than 2004-08-27 |  |
| 160 | Receive last units after Tech Characterization | 1d | 2004-09-21 | 2004-09-21 | 159FS+15d |  |  |
| 161 | **FM 1** | 251.5d | 2003-10-01 | 2004-09-30 |  |  |  |
| 162 | **IDPU w/ replacement part** | 6.5d | 2004-08-31 | 2004-09-09 |  |  |  |
| 163 | Replace LTC1877 | 0.5d | 2004-08-31 | 2004-08-31 | 187 |  |  |
| 164 | Test IDPU FM 1 LVPS | 1d | 2004-09-01 | 2004-09-01 | 163 |  |  |
| 165 | Coat & Stake IDPU LVPS FM 1 Boards | 3d | 2004-09-02 | 2004-09-07 | 164 |  |  |
| 166 | Retest/Reassenble IDPU LVPS FM 1 Boards | 2d | 2004-09-08 | 2004-09-09 | 165 |  |  |
| 167 | **SEP w/ replacement part** | 236.5d | 2003-10-01 | 2004-09-09 |  |  |  |
| 168 | Receive SEP FM 1 LVPS from CIT | 1d | 2003-10-01 | 2003-10-01 |  |  |  |
| 169 | Replace LTC1877 | 0.5d | 2004-09-01 | 2004-09-01 | 168, 163 |  |  |
| 170 | Test SEP FM 1 LVPS | 1d | 2004-09-01 | 2004-09-02 | 169 |  |  |
| 171 | Coat & Stake SEP LVPS FM 1 Boards | 2d | 2004-09-02 | 2004-09-07 | 170 |  |  |
| 172 | Retest/ Reassmeble SEP LVPS FM 1 Boards | 2d | 2004-09-07 | 2004-09-09 | 171 |  |  |
| 173 | **SWEA w/ replacement part** | 6.5d | 2004-09-01 | 2004-09-10 |  |  |  |
| 174 | Replace LTC1877 | 0.5d | 2004-09-01 | 2004-09-01 | 169 |  |  |
| 175 | Test SWEA FM 1 LVPS | 1d | 2004-09-02 | 2004-09-02 | 174 |  |  |
| 176 | Coat & Stake SWEA LVPS FM 1 Boards | 3d | 2004-09-03 | 2004-09-08 | 175 |  |  |
| 177 | Retest/ Reassmeble SWEA LVPS FM 1 Boards | 2d | 2004-09-09 | 2004-09-10 | 176 |  |  |
| 178 | **PLASTIC w/ replacement part** | 6.5d | 2004-09-22 | 2004-09-30 |  |  |  |
| 179 | Receive PLASTIC FM 1 LVPS from UNH | 0.5d | 2004-09-22 | 2004-09-22 | 160 | start no earlier than 2004-08-27 |  |
| 180 | Replace LTC1877 | 1d | 2004-09-22 | 2004-09-23 | 179, 174 |  |  |
| 181 | Test PLASTIC FM 1 LVPS | 1d | 2004-09-23 | 2004-09-24 | 180 |  |  |
| 182 | Coat & Stake PLASTIC LVPS FM 1 Boards | 2d | 2004-09-24 | 2004-09-28 | 181 |  |  |
| 183 | Retest/ Reassmeble PLASTIC LVPS FM 1 Boards | 2d | 2004-09-28 | 2004-09-30 | 182 |  |  |
| 184 | **FM 2** | 26.5d | 2004-08-26 | 2004-10-04 | 159 |  |  |
| 185 | **PLASTIC w/ replacement part** | 8.5d | 2004-08-26 | 2004-09-08 |  |  |  |
| 186 | Receive PLASTIC FM 2 LVPS from UNH | 1d | 2004-08-30 | 2004-08-30 | 75 |  |  |
| 187 | Replace LTC1877 | 0.5d | 2004-08-31 | 2004-08-31 | 186 |  |  |
| 188 | Test PLASTIC FM 2 LVPS | 1d | 2004-08-31 | 2004-09-01 | 187 |  |  |
| 189 | Final Coat & Stake PLASTIC LVPS FM 2 Boards | 2d | 2004-09-01 | 2004-09-03 | 188 |  |  |
| 190 | Retest/ Reassmeble PLASTIC LVPS FM 2 Boards | 2d | 2004-09-03 | 2004-09-08 | 189 |  |  |
| 191 | Deliver PLASTIC LVPS FM 2 (to UNH) | 2d | 2004-08-26 | 2004-08-27 | 190 | finish no later than 2004-08-27 |  |
| 192 | **IDPU w/ replacement part** | 6.5d | 2004-09-23 | 2004-10-01 |  |  |  |
| 193 | Replace LTC1877 | 0.5d | 2004-09-23 | 2004-09-23 | 180 |  |  |
| 194 | Test IDPU FM 2 LVPS | 1d | 2004-09-24 | 2004-09-24 | 193 |  |  |
| 195 | Final Coat & Stake IDPU LVPS FM 2 Boards | 3d | 2004-09-27 | 2004-09-29 | 194 |  |  |
| 196 | Retest/Reassenble IDPU LVPS FM 1 Boards | 2d | 2004-09-30 | 2004-10-01 | 195 |  |  |
| 197 | **SEP w/ replacement part** | 23.5d | 2004-08-30 | 2004-10-01 |  |  |  |
| 198 | Receive SEP FM 2 LVPS from CIT | 1d | 2004-08-30 | 2004-08-30 |  |  |  |
| 199 | Replace LTC1877 | 0.5d | 2004-09-24 | 2004-09-24 | 193, 198 |  |  |
| 200 | Test SEP FM 2 LVPS | 1d | 2004-09-24 | 2004-09-27 | 199 |  |  |
| 201 | Final Coat & Stake SEP LVPS FM 2 Boards | 2d | 2004-09-27 | 2004-09-29 | 200 |  |  |
| 202 | Retest/ Reassmeble SEP LVPS FM 2 Boards | 2d | 2004-09-29 | 2004-10-01 | 201 |  |  |
| 203 | **SWEA w/ replacement part** | 24.5d | 2004-08-30 | 2004-10-04 |  |  |  |
| 204 | Replace LTC1877 | 0.5d | 2004-08-30 | 2004-08-30 |  |  |  |
| 205 | Test SWEA FM 2 LVPS | 1d | 2004-09-24 | 2004-09-27 | 204, 199 |  |  |
| 206 | Final Coat & Stake SWEA LVPS FM 2 Boards | 3d | 2004-09-27 | 2004-09-30 | 205 |  |  |
| 207 | Retest/ Reassmeble SWEA LVPS FM 2 Boards | 2d | 2004-09-30 | 2004-10-04 | 206 |  |  |
| 208 | Deliver all LVPS w/ Replacement Parts ( to CIT for re-integration before EMC) | 1d | 2004-09-10 | 2004-09-10 | 161, 184 | finish no later than 2004-09-10 |  |
| 456 | **Remaining LET Brackets (Priority 10)** | 34d | 2004-07-26 | 2004-09-10 |  |  |  |
| 457 | Complete Drawings for Remaining LET Brackets | 13d | 2004-07-26 | 2004-08-18 | 445FS-11d |  | Sandy Shuman |
| 458 | Fabrication of Remaining LET Brackets | 10d | 2004-08-19 | 2004-09-01 | 457 |  |  |
| 459 | Inspection and Final Assembly of Remaining LET Brackets | 5d | 2004-09-02 | 2004-09-09 | 458 |  |  |
| 460 | Deliver Remaining LET Brackets to CIT for SEP I&T | 1d | 2004-09-10 | 2004-09-10 | 459 |  |  |
| 461 | **Rework of SEP Central MDM side panel (Priority 11)** | 21d | 2004-08-05 | 2004-09-02 |  |  |  |
| 462 | Complete Drawings for Reworked SEP Central MDM side panels | 5d | 2004-08-05 | 2004-08-11 | 457FS-10d |  |  |
| 463 | Fabrication of ReworkedSEP Central MDM side panels | 10d | 2004-08-12 | 2004-08-25 | 462 |  |  |
| 464 | Inspection and Final Assembly of Reworked SEP Central MDM side panels | 5d | 2004-08-26 | 2004-09-01 | 463 |  |  |
| 465 | Deliver Reworked SEP Central MDM side panels to CIT for SEP I&T | 1d | 2004-09-02 | 2004-09-02 | 464 |  |  |
| 466 | **Redesign of HET Housings (Priority 12)** | 23d | 2004-08-16 | 2004-09-16 |  |  |  |
| 467 | Complete Design/Drawings for Redesign of HET Housings | 8d | 2004-08-16 | 2004-08-25 | 462 |  | Sandy Shuman |
| 468 | Fabrication of Redesigned HET Housings | 10d | 2004-08-26 | 2004-09-09 | 467 |  |  |
| 469 | Inspection and Final Assembly of Redesigned HET Housings | 5d | 2004-09-10 | 2004-09-16 | 468 |  |  |
| 470 | Deliver Redesigned HET Housings (stays at GSFC) | 0d | 2004-09-16 | 2004-09-16 | 469 |  |  |
| 530 | **Replacement HET Detectors (Batch 3)** | 21d | 2004-08-09 | 2004-09-07 |  |  |  |
| 531 | Receive H1 Detectors | 1d | 2004-08-09 | 2004-08-09 |  | start no earlier than 2004-08-09 |  |
| 532 | Receive H3 Detectors | 1d | 2004-08-16 | 2004-08-16 |  | start no earlier than 2004-08-16 |  |
| 533 | Detector Testing at GSFC | 20d | 2004-08-10 | 2004-09-07 | 531, 532FS-5d |  |  |
| 573 | Performance Test FM 2 with New Flight Detectors | 1d | 2004-09-09 | 2004-09-09 | 572 |  |  |
| 597 | **Rework for L1 Detector Mounts** | 27d | 2004-07-30 | 2004-09-07 |  |  |  |
| 598 | Order boards | 1d | 2004-07-30 | 2004-07-30 |  | start no earlier than 2004-07-30 |  |
| 599 | Receive Boards (from Pioneer) | 1d | 2004-08-09 | 2004-08-09 | 598FS+5d |  |  |
| 600 | Repair Spare Detectors (JPL) | 15d | 2004-08-10 | 2004-08-30 | 599 |  |  |
| 601 | Test Detectors | 5d | 2004-08-31 | 2004-09-07 | 600 | finish no later than 2004-09-28 |  |
| 633 | Repair SEPT-NS FM 2 Electronic Board for use as Spare | 104d | 2004-04-06 A | 2004-08-31 | 679SS |  |  |
| 646 | **SEPT-NS FM 1 Repair** | 82d | 2004-04-06 A | 2004-07-30 | 645FS+20d |  |  |
| 647 | SEPT-NS FM 1 Initial Repair | 45d | 2004-04-06 A | 2004-06-08 A |  |  |  |
| 648 | SEPT-NS FM 1 Titanium Parts Repair (GSFC) | 17d | 2004-06-09 A | 2004-07-01 A | 647 |  |  |
| 649 | SEPT-NS FM 1 Final Repair | 20d | 2004-07-02 | 2004-07-30 | 648 |  |  |
| 650 | SEPT-NS FM 1 Post Repair Integration & Test | 5d | 2004-08-02 | 2004-08-06 | 646 |  |  |
| 651 | Cleaning, Packing, Customs, Transport | 5d | 2004-08-16 | 2004-08-20 | 650, 684SS |  |  |
| 652 | SEPT-NS FM 1 Install Thermal H/W (GSFC) | 4d | 2004-10-19 | 2004-10-22 | 19 |  |  |
| 654 | SEPT-NS FM 1 Post Repair Vibration (ESTEC) | 5d | 2004-11-08 | 2004-11-15 | 653 |  |  |
| 655 | SEPT-NSFM 1 Post Repair Thermal Vac (ESTEC) | 6d | 2004-11-16 | 2004-11-23 | 654 |  |  |
| 662 | **SEPT-E FM 1 Repair** | 82d | 2004-04-06 A | 2004-07-30 | 661FS+20d |  |  |
| 663 | SEPT-E FM 1 Initial Repair | 45d | 2004-04-06 A | 2004-06-08 A |  |  |  |
| 664 | SEPT-E FM 1 Titanium Parts Repair (at GSFC then shipped back to Kiel) | 17d | 2004-06-09 A | 2004-07-01 A | 663 |  |  |
| 665 | SEPT-E FM 1 Final Repair | 20d | 2004-07-02 | 2004-07-30 | 664 |  |  |
| 666 | SEPT-E FM 1 Post Repair Integration & Test | 5d | 2004-08-02 | 2004-08-06 | 662 |  |  |
| 667 | Cleaning, Packing, Customs, Transport | 5d | 2004-08-16 | 2004-08-20 | 666, 700SS |  |  |
| 668 | SEPT-E FM 1 Install Thermal H/W (GSFC) | 4d | 2004-10-19 | 2004-10-22 | 19 |  |  |
| 669 | SEPT-E FM 1Thermal Balance (at GSFC after Suite EMC) | 10d | 2004-10-25 | 2004-11-05 | 668, 702SS |  |  |
| 670 | SEPT-E FM1 Post Repair Vibration (ESTEC) | 5d | 2004-11-08 | 2004-11-15 | 669 |  |  |
| 671 | SEPT-E FM1 Post Repair Thermal Vac (ESTEC) | 6d | 2004-11-16 | 2004-11-23 | 670 |  |  |
| 679 | **SEPT-NS FM 2 Repair** | 82d | 2004-04-06 A | 2004-07-30 | 678FS+15d |  |  |
| 680 | SEPT-NS FM 2 Initial Repair | 45d | 2004-04-06 A | 2004-06-08 A |  |  |  |
| 681 | SEPT-NS FM 2 Titanium Parts Repair (at GSFC then shipped back to Kiel) | 17d | 2004-06-09 A | 2004-07-01 A | 680 |  |  |
| 682 | SEPT-NS FM 2 Final Repair | 20d | 2004-07-02 | 2004-07-30 | 681 |  |  |
| 683 | SEPT-NS FM 2 Post Repair Integration & Test | 5d | 2004-08-09 | 2004-08-13 | 636, 679, 650 |  |  |
| 684 | Cleaning, Packing, Customs, Transport | 5d | 2004-08-16 | 2004-08-20 | 683 |  |  |
| 685 | SEPT-NS FM 2 Install Thermal H/W (GSFC) | 4d | 2004-10-19 | 2004-10-22 | 684, 652SS |  |  |
| 686 | SEPT-NS FM 2 Thermal Balance (GSFC) | 10d | 2004-10-25 | 2004-11-05 | 685 |  |  |
| 687 | SEPT-NS FM 2 Post Repair Vibration (ESTEC) | 5d | 2004-11-08 | 2004-11-15 | 686 |  |  |
| 688 | SEPT-NS FM 2 Post Repair Thermal Vac (ESTEC) | 6d | 2004-11-24 | 2004-12-02 | 687, 655 |  |  |
| 695 | **SEPT-E FM 2 Repair** | 82d | 2004-04-06 A | 2004-07-30 | 694FS+15d |  |  |
| 696 | SEPT-E FM 2 Initial Repair | 45d | 2004-04-06 A | 2004-06-08 A |  |  |  |
| 697 | SEPT-E FM 2 Titanium Parts Repair (at GSFC then shipped back to Kiel) | 17d | 2004-06-09 A | 2004-07-01 A | 696 |  |  |
| 698 | SEPT-E FM 2 Final Repair | 20d | 2004-07-02 | 2004-07-30 | 697 |  |  |
| 699 | SEPT-E FM 2 Post Repair Integration & Test | 5d | 2004-08-09 | 2004-08-13 | 697, 695, 666 |  |  |
| 700 | Cleaning, Packing, Customs, Transport | 5d | 2004-08-16 | 2004-08-20 | 699 |  |  |
| 701 | SEPT-E FM 2 Install Thermal H/W (GSFC) | 4d | 2004-10-19 | 2004-10-22 | 668SS |  |  |
| 702 | SEPT-E FM 2 Thermal Balance (GSFC) | 10d | 2004-10-25 | 2004-11-05 | 701 |  |  |
| 703 | SEPT-E FM 2 Post Repair Vibration (ESTEC) | 5d | 2004-11-08 | 2004-11-15 | 702 |  |  |
| 704 | SEPT-E FM 2 Post Repair Thermal Vac (ESTEC) | 6d | 2004-11-24 | 2004-12-02 | 703, 671 |  |  |
| 788 | SIT FM 1 end-to-end test at Accelerator w/ ETU Telescope (at Brookhaven) | 3d | 2004-08-11 | 2004-08-13 | 806 | must start on 2004-08-11 |  |
| 790 | Test and Trim SIT FM 1 w/Flight Telescope | 1d | 2004-09-20 | 2004-09-20 | 789 |  |  |
| 857 | Re-integrate & test HET FM 1 w/ Flight detectors | 1d | 2004-09-21 | 2004-09-21 | 515, 897 |  |  |
| 858 | Re-integrate & Test LET/SEP Central FM 1 | 1d | 2004-09-13 | 2004-09-13 | 508, 460, 465 |  |  |
| 871 | Re-integrate SEP FM 2 LVPS after Coat and Stake | 1d | 2004-08-10 | 2004-08-10 | 870, 145 |  |  |
| 872 | Re-integrate HET FM 2 after Confromal Coating | 1d | 2004-09-21 | 2004-09-21 | 871, 517 |  |  |
| 895 | Deliver SEP/SIT FM 2 to APL | 1d | 2004-12-31 | 2004-12-31 | 894 |  |  |
| 899 | **Continue I&T for HET, LET and SEP Cen** | 3d | 2004-07-20 A | 2004-07-22 A | 898 |  |  |
| 902 | Deliver LET and SEP Central (Conformal Coating @ CIT) | 0d | 2004-07-20 A | 2004-07-20 A | 900 |  |  |
| 903 | Deliver HET FM 2 (Conformal Coating @ GSFC) | 2d | 2004-07-21 A | 2004-07-22 A | 900, 898 |  |  |
| 904 | Deliver SEP LVPS FM2 (Coat & Stake @UCB) | 1d | 2004-07-21 A | 2004-07-21 A | 900 |  |  |

Removed: 60 SIT Thermal Balance (at GSFC); 213 FM 1 Boom Structure Post Environmental Deployment Test; 235 FM 2 Boom Structure Post Environmental Deployment Test; 578 SEPT-E FM 1 Thermal Balance (at GSFC after Suite EMC); 597 Deliver SIT FM 2 to CIT for SEP I&T; 598 Deliver SIT FM 2 back to GSFC for Environmental Testing; 632 Disassembel FM 1 Logic Board with ETU ACTELs; 633 Retrofit/Inspect FM 1 Flight ACTELs; 634 Reassemble FM 1 Logic Board with Flight ACTELs; 637 Disassemble FM 2 Logic Boards; 638 Retrofit/Inspect Flight ACTELS; 639 Reassemble FM 2 Logic Boards; 647 Funtional Test of FM 1 Logic Board w/Flight ACTELS; 649 Functional Test of FM 2 Logic Board w/ETU ACTELS; 725 SIT FM 2 Thermal Balance; 762 Receive & inspect SEPT FM 2; 769 Receive & inspect SIT FM 2; 794 Detach HET FM2 from SEP Suite; 795 Deliver HET FM2 to GSFC for Replacement Detectors

Changed:

| ID | Task | Start | Finish | Duration | Complete | Total float | Predecessors | Other |
| --- | --- | --- | --- | --- | --- | --- | --- | --- |
| 1 | **IMPACT - Dave Curtis (UCB) & Lil Reichenthal (GSFC)** |  |  | 699d → 698d | 63% → 82% |  |  |  |
| 2 | **Suite Deliveries to APL** | 2004-09-21 → 2004-10-07 (+16d) | 2004-10-28 → 2004-12-31 (+64d) | 25d → 59d |  | 0d → -45d |  |  |
| 5 | Boom Suite FM 1 Ready for Delivery to APL | 2004-09-21 → 2004-11-22 (+62d) | 2004-09-21 → 2004-11-22 (+62d) |  |  | 11d → -31d |  |  |
| 6 | Boom Suite FM 2 Ready for Delivery to APL | 2004-10-06 → 2004-11-30 (+55d) | 2004-10-06 → 2004-11-30 (+55d) |  |  | 14d → -22d |  |  |
| 7 | SEP Suite FM 1 Ready for Delivery to APL | 2004-10-12 → 2004-12-13 (+62d) | 2004-10-12 → 2004-12-13 (+62d) |  |  | -3d → -45d |  |  |
| 8 | SEP Suite FM 2 Ready for Delivery to APL | 2004-10-25 → 2004-12-31 (+67d) | 2004-10-25 → 2004-12-31 (+67d) |  |  | 2d → -45d | 891, 710 → 895 |  |
| 9 | **Environmental Testing - PER, Impact Suite EMC, Snapshots of Boom & SEP Suite Test Flows** |  | 2004-10-19 → 2005-01-04 (+77d) | 195d → 247d | 11% → 29% | 282d → 229d |  |  |
| 10 | **Reviews (PER and TRR's) - TRR Dates are Tentative** |  | 2004-08-16 → 2004-10-15 (+60d) | 151d → 192d |  | 326d → 284d |  |  |
| 15 | TRR 4 - Prior to FM 1 IDPU Vibration | 2004-05-26 → 2004-10-12 (+139d) | 2004-05-26 → 2004-10-12 (+139d) |  |  | 383d → 287d |  |  |
| 16 | TRR 5 - Prior to FM 1 SWEA Vibration | 2004-06-29 → 2004-10-12 (+105d) | 2004-06-29 → 2004-10-12 (+105d) |  |  | 360d → 287d |  |  |
| 17 | TRR 6 - Prior to FM 1 Impact Suite EMC (for Boom and SEP) | 2004-07-28 → 2004-09-27 (+61d) | 2004-07-28 → 2004-09-27 (+61d) |  |  | 339d → 297d |  |  |
| 18 | TRR 7 - Prior to FM 1 SIT Vibration | 2004-08-16 → 2004-10-15 (+60d) | 2004-08-16 → 2004-10-15 (+60d) |  |  | 326d → 284d |  |  |
| 19 | IMPACT Suite FM 1 EMC Testing at UCB | 2004-08-04 → 2004-10-04 (+61d) | 2004-08-17 → 2004-10-18 (+62d) |  |  | -8d → -50d | 400, 865, 487 → 865, 487 |  |
| 20 | **Boom Suite FM 1 Environmental Test Flow Snapshot - UCB** | 2004-04-26 A | 2004-09-07 → 2004-11-15 (+69d) | 95d → 141d | 0% → 62% | 311d → 264d |  |  |
| 21 | STE-U Thermal Vac/Thermal Balance/Bake Out | 2004-04-26 A | 2004-05-13 → 2004-06-16 A (+34d) | 14d → 37d | 0% → 100% | 392d → none |  |  |
| 22 | Boom Structure Vibration | 2004-05-14 → 2004-06-23 A (+40d) | 2004-05-19 → 2004-06-28 A (+40d) |  | 0% → 100% | 388d → none |  |  |
| 23 | IDPU Vibration | 2004-06-03 → 2004-10-19 (+138d) | 2004-06-09 → 2004-10-25 (+138d) |  |  | 374d → 278d |  |  |
| 24 | Boom Structure Thermal Vac & Bake Out | 2004-05-20 → 2004-06-29 A (+40d) | 2004-06-10 → 2004-07-20 A (+40d) |  | 0% → 100% | 373d → none |  |  |
| 25 | IDPU Thermal Vac & Bake Out | 2004-06-10 → 2004-10-26 (+138d) | 2004-06-23 → 2004-11-08 (+138d) |  |  | 364d → 268d |  |  |
| 26 | SWEA/STE Vibration | 2004-07-06 → 2004-10-19 (+105d) | 2004-07-12 → 2004-10-25 (+105d) |  |  | 351d → 278d |  |  |
| 27 | SWEA/STE Thermal Vac/Thermal Balance/Bake Out | 2004-08-18 → 2004-10-26 (+69d) | 2004-09-07 → 2004-11-15 (+69d) |  |  | 311d → 264d |  |  |
| 28 | **Boom Suite FM 2 Environmental Test Flow Snapshot - UCB** | 2004-06-16 → 2004-08-02 (+47d) | 2004-09-22 → 2004-11-22 (+61d) | 70d → 78d |  | 300d → 259d |  |  |
| 29 | STE-U Thermal Vac/Bake Out | 2004-06-16 → 2004-08-02 (+47d) | 2004-06-29 → 2004-08-13 (+45d) |  |  | 360d → 327d |  |  |
| 30 | IDPU Vibration | 2004-07-15 → 2004-09-27 (+74d) | 2004-07-21 → 2004-10-01 (+72d) |  |  | 344d → 293d |  |  |
| 31 | Boom Structure Vibration | 2004-07-06 → 2004-08-20 (+45d) | 2004-07-09 → 2004-08-25 (+47d) |  |  | 352d → 319d |  |  |
| 32 | IDPU Thermal Vac & Bake Out | 2004-07-22 → 2004-10-04 (+74d) | 2004-08-04 → 2004-10-18 (+75d) |  |  | 334d → 283d |  |  |
| 33 | Boom Structure Thermal Vac & Bake Out | 2004-07-12 → 2004-08-26 (+45d) | 2004-07-30 → 2004-09-16 (+48d) |  |  | 337d → 304d |  |  |
| 34 | SWEA/STE Vibration | 2004-08-17 → 2004-10-15 (+59d) | 2004-08-23 → 2004-10-21 (+59d) |  |  | 321d → 280d |  |  |
| 35 | SWEA/STE Thermal Vac & Bake Out | 2004-08-24 → 2004-10-22 (+59d) | 2004-09-07 → 2004-11-04 (+58d) |  |  | 311d → 270d |  |  |
| 36 | Boom Suite FM 2 EMC | 2004-09-16 → 2004-11-16 (+61d) | 2004-09-22 → 2004-11-22 (+61d) |  |  | 300d → 259d |  |  |
| 37 | **SEP Suite FM 1 Environmental Test Flow Snapshot** |  | 2004-10-07 → 2004-12-09 (+63d) | 164d → 205d | 19% → 22% | 289d → 247d |  |  |
| 41 | SEPT (NS & E) Thermal Balance (at GSFC) | 2004-08-18 → 2004-10-25 (+68d) | 2004-08-31 → 2004-11-05 (+66d) |  |  | 315d → 269d | 653SS, SEPT-E FM 1 Thermal Balance (at GSFC after Suite EMC)SS → 653SS, 669SS |  |
| 42 | LET/HET/SEP Cen Accelerator Test (at MSU) | 2004-07-10 A | 2004-07-12 A |  | 0% → 100% | 355d → none |  |  |
| 43 | SIT Vibe and Acoustics (at GSFC) | 2004-08-23 → 2004-10-22 (+60d) | 2004-09-03 → 2004-11-04 (+62d) |  |  | 312d → 270d |  |  |
| 44 | LET/HET/SEP Cen Vibe and Acoustics (at JPL) | 2004-08-23 → 2004-10-22 (+60d) | 2004-09-03 → 2004-11-04 (+62d) |  |  | 312d → 270d |  |  |
| 45 | SIT Thermal Balance (at GSFC) | 2004-09-08 → 2004-11-08 (+61d) | 2004-09-14 → 2004-11-15 (+62d) |  |  | 306d → 264d |  |  |
| 46 | LET/HET/SEP Cen Thermal Balance (at JPL) | 2004-09-07 → 2004-11-05 (+59d) | 2004-09-13 → 2004-11-12 (+60d) |  |  | 307d → 265d |  |  |
| 47 | SIT Thermal Vac (at GSFC) | 2004-09-15 → 2004-11-16 (+62d) | 2004-09-28 → 2004-11-30 (+63d) |  |  | 296d → 254d |  |  |
| 48 | LET/HET/SEP Cen Thermal Vac (at JPL) | 2004-09-14 → 2004-11-15 (+62d) | 2004-10-04 → 2004-12-06 (+63d) |  |  | 292d → 250d |  |  |
| 49 | SIT Bake Out (at GSFC) | 2004-10-01 → 2004-12-03 (+63d) | 2004-10-05 → 2004-12-07 (+63d) |  |  | 291d → 249d |  |  |
| 50 | LET/HET/SEP Cen Bake Out (at JPL) | 2004-10-05 → 2004-12-07 (+63d) | 2004-10-07 → 2004-12-09 (+63d) |  |  | 289d → 247d |  |  |
| 51 | **SEP Suite FM 2 Environmental Test Flow Snapshot** |  | 2004-10-19 → 2005-01-04 (+77d) | 171d → 223d | 17% → 24% | 282d → 229d |  |  |
| 55 | LET/HET/SEP Cen Accelerator Test (at MSU) | 2004-07-13 → 2004-07-10 A (-3d) | 2004-07-27 → 2004-07-12 A (-15d) | 11d → 3d | 0% → 100% | 340d → none |  |  |
| 56 | LET/HET/SEP Cen Vibe and Acoustics (at JPL) | 2004-08-31 → 2004-10-22 (+52d) | 2004-09-14 → 2004-11-04 (+51d) |  |  | 306d → 270d |  |  |
| 57 | SEP Suite FM 2 EMC (at Caltech) | 2004-08-24 → 2004-12-29 (+127d) | 2004-08-30 → 2005-01-04 (+127d) |  |  | 316d → 229d |  |  |
| 58 | LET/HET/SEP Cen Thermal Vac (at JPL) | 2004-09-15 → 2004-11-05 (+51d) | 2004-10-05 → 2004-11-29 (+55d) |  |  | 291d → 255d |  |  |
| 59 | SIT Vibe and Acoustics (at GSFC) | 2004-09-03 → 2004-11-15 (+73d) | 2004-09-17 → 2004-11-29 (+73d) |  |  | 303d → 255d |  |  |
| 60 | LET/HET/SEP Cen Bake Out (at JPL) | 2004-10-06 → 2004-11-30 (+55d) | 2004-10-08 → 2004-12-02 (+55d) |  |  | 288d → 252d |  |  |
| 61 | SIT Thermal Vac (at GSFC) | 2004-09-28 → 2004-12-01 (+64d) | 2004-10-12 → 2004-12-14 (+63d) |  |  | 287d → 244d |  |  |
| 62 | SIT Bake Out (at GSFC) | 2004-10-15 → 2004-12-17 (+63d) | 2004-10-19 → 2004-12-21 (+63d) |  |  | 282d → 239d |  |  |
| 63 | **Power Converters - UCB** |  | 2004-07-07 → 2004-10-04 (+89d) | 345d → 405.5d | 67% → 83% | 37d → -15.5d |  |  |
| 64 | **Deliveries** |  | 2004-07-07 → 2004-08-24 (+48d) | 147d → 180d | 20% → 60% | 37d → -1d |  |  |
| 65 | **FM 1** |  | 2004-05-25 → 2004-07-30 (+66d) | 117d → 163d | 40% → 99% | 15d → -20d |  |  |
| 66 | Deliver IDPU FM 1 LVPS (stays at UCB) | 2004-05-25 → 2004-07-30 (+66d) | 2004-05-25 → 2004-07-30 (+66d) |  |  | 15d → -20d |  |  |
| 67 | Deliver SEP FM 1 LVPS (to Caltech) | 2004-05-03 → 2004-06-01 A (+29d) | 2004-05-03 → 2004-06-01 A (+29d) |  | 0% → 100% | 16d → none |  |  |
| 68 | Deliver SWEA/STE FM 1 LVPS (stays at UCB) | 2004-04-16 → 2004-07-23 (+98d) | 2004-04-16 → 2004-07-23 (+98d) |  |  | 22d → -42d |  |  |
| 69 | Deliver PLASTIC FM 1 LVPS (to UNH) | 2004-05-17 → 2004-05-24 A (+7d) | 2004-05-18 → 2004-05-25 A (+7d) |  | 0% → 100% | 16d → none |  |  |
| 71 | **FM 2** | 2004-05-21 → 2004-06-29 A (+39d) | 2004-07-07 → 2004-08-24 (+48d) | 33d → 40d | 0% → 20% | 2d → -1d |  |  |
| 72 | Deliver IDPU FM 2 LVPS (stays at UCB) | 2004-07-07 → 2004-08-24 (+48d) | 2004-07-07 → 2004-08-24 (+48d) |  |  | 37d → -1d |  |  |
| 73 | Deliver SEP FM 2 LVPS (to Caltech) | 2004-06-25 → 2004-06-29 A (+4d) | 2004-06-25 → 2004-06-29 A (+4d) |  | 0% → 100% | 37d → none | 145 → 142 |  |
| 74 | Deliver SWEA/STE FM 2 LVPS (stays at UCB) | 2004-05-28 → 2004-08-24 (+88d) | 2004-05-28 → 2004-08-24 (+88d) |  |  | 29d → -22d |  |  |
| 75 | Deliver PLASTIC FM 2 LVPS | 2004-06-28 → 2004-07-27 (+29d) | 2004-06-29 → 2004-07-28 (+29d) |  |  | 16d → 13.5d |  | was named Deliver PLASTIC FM 2 LVPS (to UNH); constraint finish no later than 2004-07-21 → finish no later than 2004-08-19 |
| 76 | Deliver SIT FM 2 HVPS (to UMD) | 2004-05-21 → 2004-08-17 (+88d) | 2004-05-24 → 2004-08-18 (+86d) |  |  | 2d → -36d |  |  |
| 98 | **Assembly** |  | 2004-06-02 → 2004-07-20 (+48d) | 109d → 142d | 55% → 88% | 37d → 36.5d |  |  |
| 99 | **FM 1** |  | 2004-04-20 → 2004-04-27 A (+7d) | 79d → 84d | 89% → 100% | 15d → none |  |  |
| 100 | Assemble IDPU FM 1 LVPS | 2004-04-05 A | 2004-04-20 → 2004-04-27 A (+7d) | 12d → 17d | 0% → 100% | 15d → none |  |  |
| 104 | **FM 2** |  | 2004-06-02 → 2004-07-20 (+48d) | 47d → 80d | 4% → 80% | 37d → 36.5d |  |  |
| 105 | Assemble IDPU FM 2 LVPS | 2004-05-12 → 2004-06-28 A (+47d) | 2004-06-02 → 2004-07-12 (+40d) | 15d → 10d | 0% → 30% | 37d → 5d | 94, 118 → 94, 118FS-25d |  |
| 106 | Assemble SEP FM 2 LVPS | 2004-04-26 → 2004-05-24 A (+28d) | 2004-05-14 → 2004-06-21 A (+38d) | 15d → 20d | 0% → 100% | 37d → none |  |  |
| 107 | Assemble SWEA FM 2 LVPS | 2004-04-05 → 2004-06-22 A (+78d) | 2004-04-23 → 2004-07-20 (+88d) | 15d → 14d | 0% → 50% | 29d → -22d |  |  |

| ID | Task | Start | Finish | Duration | Complete | Total float | Predecessors | Other |
| --- | --- | --- | --- | --- | --- | --- | --- | --- |
| 108 | Assemble PLASTIC FM 2 LVPS | 2004-05-03 → 2004-05-10 A (+7d) | 2004-05-20 → 2004-07-20 (+61d) | 14d → 50d | 0% → 74% | 16d → 36.5d |  |  |
| 109 | Assemble SIT FM 2 HVPS |  | 2004-04-15 → 2004-07-12 (+88d) | 14d → 74d | 21% → 91% | 2d → -36d |  |  |
| 110 | **Testing** |  | 2004-07-07 → 2004-08-24 (+48d) | 172d → 205d | 26% → 72% | 37d → 4d |  |  |
| 116 | **FM 1** |  | 2004-05-25 → 2004-07-30 (+66d) | 142d → 188d | 37% → 94% | 15d → -1d |  |  |
| 117 | **IDPU** | 2004-04-21 → 2004-06-21 A (+61d) | 2004-05-25 → 2004-07-30 (+66d) | 25d → 29d | 0% → 96% | 15d → -1d |  |  |
| 118 | Test IDPU FM 1 LVPS | 2004-04-21 → 2004-06-21 A (+61d) | 2004-05-11 → 2004-07-20 A (+70d) | 15d → 21d | 0% → 100% | 15d → none | 100 → 100FS+37d |  |
| 119 | Coat & Stake IDPU LVPS FM 1 Boards | 2004-05-12 → 2004-07-20 A (+69d) | 2004-05-18 → 2004-07-20 A (+63d) | 5d → 0d | 0% → 100% | 15d → none |  |  |
| 121 | Retest & Coat Touch-up IDPU LVPS FM 1 Boards | 2004-05-19 → 2004-07-30 (+72d) | 2004-05-25 → 2004-07-30 (+66d) | 5d → 1d |  | 15d → -20d | 119 → 120 | was named Retest IDPU LVPS FM 1 Boards |
| 122 | **SEP** |  | 2004-04-30 → 2004-05-28 A (+28d) | 38d → 58d | 42% → 100% | 16d → none |  |  |
| 123 | Test SEP FM 1 LVPS |  | 2004-04-16 → 2004-05-14 A (+28d) | 28d → 48d | 57% → 100% | 16d → none |  |  |
| 124 | Coat & Stake SEP LVPS FM 1 Boards | 2004-04-19 → 2004-05-17 A (+28d) | 2004-04-23 → 2004-05-21 A (+28d) |  | 0% → 100% | 16d → none |  |  |
| 125 | Retest SEP LVPS FM 1 Boards | 2004-04-26 → 2004-05-24 A (+28d) | 2004-04-30 → 2004-05-28 A (+28d) |  | 0% → 100% | 16d → none |  |  |
| 126 | **SWEA** |  | 2004-04-16 → 2004-07-23 (+98d) | 25d → 93d | 52% → 83% | 22d → -10d |  |  |
| 127 | Test SWEA FM 1 LVPS |  | 2004-04-02 → 2004-07-09 (+98d) | 15d → 83d | 87% → 93% | 22d → -42d |  |  |
| 128 | Coat & Stake SWEA LVPS FM 1 Boards | 2004-04-05 → 2004-07-12 (+98d) | 2004-04-09 → 2004-07-16 (+98d) |  |  | 22d → -42d |  |  |
| 129 | Retest SWEA LVPS FM 1 Boards | 2004-04-12 → 2004-07-19 (+98d) | 2004-04-16 → 2004-07-23 (+98d) |  |  | 22d → -42d |  |  |
| 130 | **PLASTIC** |  | 2004-05-14 → 2004-05-21 A (+7d) | 68d → 73d | 19% → 100% | 16d → none |  |  |
| 131 | Test PLASTIC FM 1 LVPS |  | 2004-04-30 → 2004-05-07 A (+7d) | 58d → 63d | 22% → 100% | 16d → none |  |  |
| 132 | Coat & Stake PLASTIC LVPS FM 1 Boards | 2004-05-03 → 2004-05-10 A (+7d) | 2004-05-07 → 2004-05-14 A (+7d) |  | 0% → 100% | 16d → none |  |  |
| 133 | Retest PLASTIC LVPS FM 1 Boards | 2004-05-10 → 2004-05-17 A (+7d) | 2004-05-14 → 2004-05-21 A (+7d) |  | 0% → 100% | 16d → none |  |  |
| 136 | **FM 2** | 2004-04-16 → 2004-05-28 A (+42d) | 2004-07-07 → 2004-08-24 (+48d) | 58d → 61d | 0% → 27% | 2d → 4d |  |  |
| 137 | **IDPU** | 2004-06-03 → 2004-07-21 (+48d) | 2004-07-07 → 2004-08-24 (+48d) |  |  | 37d → -1d |  |  |
| 138 | Test IDPU FM 2 LVPS | 2004-06-03 → 2004-07-21 (+48d) | 2004-06-23 → 2004-08-10 (+48d) |  |  | 37d → -1d | 105 → 105, 118 |  |
| 139 | Coat & Stake IDPU LVPS FM 2 Boards | 2004-06-24 → 2004-08-11 (+48d) | 2004-06-30 → 2004-08-17 (+48d) |  |  | 37d → -1d |  |  |
| 140 | Retest IDPU LVPS FM 2 Boards | 2004-07-01 → 2004-08-18 (+48d) | 2004-07-07 → 2004-08-24 (+48d) |  |  | 37d → -1d |  |  |
| 141 | **SEP** | 2004-05-17 → 2004-06-08 A (+22d) | 2004-06-24 → 2004-08-09 (+46d) | 28d → 44d | 0% → 54% | 37d → 15d |  |  |
| 142 | Test SEP FM 2 LVPS | 2004-05-17 → 2004-06-08 A (+22d) | 2004-06-07 → 2004-06-28 A (+21d) |  | 0% → 100% | 37d → none | 106 → 106FS-10d |  |
| 143 | Coat & Stake SEP LVPS FM 2 Boards | 2004-06-08 → 2004-07-22 (+44d) | 2004-06-14 → 2004-07-28 (+44d) |  |  | 37d → 15d | 142 → 142, 904 |  |
| 144 | Retest SEP LVPS FM 2 Boards | 2004-06-15 → 2004-07-29 (+44d) | 2004-06-21 → 2004-08-04 (+44d) |  |  | 37d → 15d |  |  |
| 145 | Bakeout SEP LVPS FM 2 Boards | 2004-06-22 → 2004-08-05 (+44d) | 2004-06-24 → 2004-08-09 (+46d) |  |  | 37d → 15d |  |  |
| 146 | **SWEA** | 2004-04-26 → 2004-07-21 (+86d) | 2004-05-28 → 2004-08-24 (+88d) |  |  | 29d → -22d |  |  |
| 147 | Test SWEA FM 2 LVPS | 2004-04-26 → 2004-07-21 (+86d) | 2004-05-14 → 2004-08-10 (+88d) |  |  | 29d → -22d |  |  |
| 148 | Coat & Stake SWEA LVPS FM 2 Boards | 2004-05-17 → 2004-08-11 (+86d) | 2004-05-21 → 2004-08-17 (+88d) |  |  | 29d → -22d |  |  |
| 149 | Retest SWEA LVPS FM 2 Boards | 2004-05-24 → 2004-08-18 (+86d) | 2004-05-28 → 2004-08-24 (+88d) |  |  | 29d → -22d |  |  |
| 150 | **PLASTIC** | 2004-05-21 → 2004-05-28 A (+7d) | 2004-06-25 → 2004-07-26 (+31d) | 25d → 40d | 0% → 57% | 16d → 13.5d |  |  |
| 151 | Test PLASTIC FM 2 LVPS | 2004-05-21 → 2004-05-28 A (+7d) | 2004-06-11 → 2004-07-12 (+31d) | 15d → 30d | 0% → 77% | 16d → 13.5d | 108 → 108FS-36d |  |
| 152 | Coat & Stake PLASTIC LVPS FM 2 Boards | 2004-06-14 → 2004-07-13 (+29d) | 2004-06-18 → 2004-07-19 (+31d) |  |  | 16d → 13.5d |  |  |
| 153 | Retest PLASTIC LVPS FM 2 Boards | 2004-06-21 → 2004-07-20 (+29d) | 2004-06-25 → 2004-07-26 (+31d) |  |  | 16d → 13.5d |  |  |
| 154 | **SIT** | 2004-04-16 → 2004-06-28 (+73d) | 2004-05-20 → 2004-08-16 (+88d) | 25d → 35d |  | 2d → -36d |  |  |
| 155 | Test SIT FM 2 HVPS | 2004-04-16 → 2004-06-28 (+73d) | 2004-05-06 → 2004-08-02 (+88d) |  |  | 2d → -36d | 109 → 109FS-10d |  |
| 156 | Coat & Stake SIT FM 2 HVPS Boards | 2004-05-07 → 2004-08-03 (+88d) | 2004-05-13 → 2004-08-09 (+88d) |  |  | 2d → -36d |  |  |
| 157 | Retest SIT FM 2 HVPS Boards | 2004-05-14 → 2004-08-10 (+88d) | 2004-05-20 → 2004-08-16 (+88d) |  |  | 2d → -36d |  |  |
| 209 | **IDPU - UCB** |  | 2004-09-07 → 2004-11-08 (+62d) | 340d → 382d | 76% → 86% | 14d → -22d |  |  |
| 210 | **Deliveries** | 2004-06-23 → 2004-08-06 (+44d) | 2004-08-04 → 2004-08-31 (+27d) | 30d → 17d |  | 15d → -20d |  |  |
| 211 | IDPU FM 1 Complete (to UCB for Boom I&T, then to CIT for SEP I&T, Suite EMC, BO & Final Boom I&T) | 2004-06-23 → 2004-08-06 (+44d) | 2004-06-23 → 2004-08-06 (+44d) |  |  | 15d → -20d | 226 → 224 |  |
| 212 | IDPU FM 2 Complete (to CIT for SEP I&T, then to UCB for Boom I&T, Boom EMC, BO & Final Boom I&T) | 2004-08-04 → 2004-08-31 (+27d) | 2004-08-04 → 2004-08-31 (+27d) |  |  | 37d → -1d | 230 → 228 |  |
| 213 | **Flight Software** |  | 2004-05-13 → 2004-08-11 (+90d) | 259d → 321d | 90% → 92% | 85d → 29d |  |  |
| 215 | IDPU S/W Build #3 (also goes to UNH) |  | 2004-05-13 → 2004-08-11 (+90d) | 187d → 249d | 83% → 88% | 85d → 29d |  |  |
| 216 | **GSE** |  | 2004-09-07 → 2004-09-08 (+1d) |  | 72% → 87% |  |  |  |
| 219 | GSE Continued Development (LOE) |  | 2004-09-07 → 2004-09-08 (+1d) |  | 54% → 79% |  |  |  |
| 220 | **Integration & Test** |  | 2004-08-04 → 2004-11-08 (+96d) | 209d → 274d |  | 37d → -22d |  |  |
| 223 | **FM 1** | 2004-05-26 → 2004-08-02 (+68d) | 2004-06-23 → 2004-11-08 (+138d) | 20d → 69d |  | 15d → -27d |  |  |
| 224 | IDPU FM 1 I & T | 2004-05-26 → 2004-08-02 (+68d) | 2004-06-02 → 2004-08-06 (+65d) |  |  | 15d → -20d |  |  |
| 225 | IDPU FM 1 Vibration | 2004-06-03 → 2004-10-19 (+138d) | 2004-06-09 → 2004-10-25 (+138d) |  |  | 15d → -27d | 224 → 224, 19 |  |
| 226 | IDPU FM 1 Thermal Vacuum & Bake Out | 2004-06-10 → 2004-10-26 (+138d) | 2004-06-23 → 2004-11-08 (+138d) |  |  | 15d → -27d |  |  |
| 227 | **FM 2** | 2004-07-08 → 2004-08-25 (+48d) | 2004-08-04 → 2004-10-18 (+75d) | 20d → 37d |  | 37d → -7d |  |  |
| 228 | IDPU FM 2 I & T | 2004-07-08 → 2004-08-25 (+48d) | 2004-07-14 → 2004-08-31 (+48d) |  |  | 37d → -1d |  |  |
| 229 | IDPU FM 2 Vibration | 2004-07-15 → 2004-09-27 (+74d) | 2004-07-21 → 2004-10-01 (+72d) |  |  | 37d → -7d | 228 → 874FS+2d |  |
| 230 | IDPU FM 2 Thermal Vacuum & Bake Out | 2004-07-22 → 2004-10-04 (+74d) | 2004-08-04 → 2004-10-18 (+75d) |  |  | 37d → -7d |  |  |
| 231 | **BOOM Suite - UCB** |  | 2004-10-06 → 2004-11-30 (+55d) | 321d → 356d | 76% → 92% | 14d → -22d |  |  |
| 232 | **BOOM Structure - UCB** |  | 2004-08-05 → 2004-09-16 (+42d) | 229d → 257d | 86% → 96% | 36d → 12d |  |  |
| 233 | **Deliveries** |  | 2004-08-05 → 2004-09-16 (+42d) | 146d → 174d |  | 36d → 12d |  |  |
| 235 | Deliver Boom Structure FM 1 (stays at UCB for Boom Suite FM 1 I&T) | 2004-06-16 → 2004-07-20 A (+34d) | 2004-06-16 → 2004-07-20 A (+34d) |  | 0% → 100% | 20d → none | FM 1 Boom Structure Post Environmental Deployment Test → 263 |  |
| 236 | Deliver Boom Structure FM 2 (stays at UCB for Boom Suite FM 2 I&T) | 2004-08-05 → 2004-09-16 (+42d) | 2004-08-05 → 2004-09-16 (+42d) |  |  | 36d → 12d | FM 2 Boom Structure Post Environmental Deployment Test → 284 |  |
| 243 | **FM 1** |  | 2004-06-16 → 2004-07-20 A (+34d) | 180d → 203d | 82% → 100% | 20d → none |  |  |
| 259 | **Integration & Test** | 2004-03-15 A → 2004-03-16 A (+1d) | 2004-06-16 → 2004-07-20 A (+34d) | 67d → 89d | 22% → 100% | 20d → none |  |  |
| 260 | Integrate FM 1 Boom Structure subassemblies & Harness Completion | 2004-03-15 A → 2004-03-16 A (+1d) | 2004-04-16 → 2004-06-08 A (+53d) | 25d → 60d | 52% → 100% | 25d → none |  |  |
| 261 | FM 1 Boom Structure Deployment Test | 2004-04-19 → 2004-06-09 A (+51d) | 2004-04-30 → 2004-06-11 A (+42d) | 10d → 3d | 0% → 100% | 25d → none |  |  |
| 262 | FM 1 Boom Structure Vibration Test | 2004-05-14 → 2004-06-23 A (+40d) | 2004-05-19 → 2004-06-28 A (+40d) |  | 0% → 100% | 20d → none |  |  |
| 263 | FM 1 Boom Structure Themal Vac & Bake Out | 2004-05-20 → 2004-06-29 A (+40d) | 2004-06-10 → 2004-07-20 A (+40d) |  | 0% → 100% | 20d → none |  |  |

| ID | Task | Start | Finish | Duration | Complete | Total float | Predecessors |
| --- | --- | --- | --- | --- | --- | --- | --- |
| 264 | **FM 2** |  | 2004-08-05 → 2004-09-16 (+42d) | 216d → 244d | 82% → 90% | 36d → 12d |  |
| 280 | **Integration & Test** |  | 2004-08-05 → 2004-09-16 (+42d) | 93d → 121d | 6% → 69% | 36d → 12d |  |
| 281 | Integrate FM 2 Boom Structure subassemblies & Harness Completion |  | 2004-04-16 → 2004-07-13 (+88d) | 15d → 75d | 20% → 89% | 77d → 32d |  |
| 282 | FM 2 Boom Structure Deployment Test | 2004-04-19 → 2004-07-14 (+86d) | 2004-04-30 → 2004-07-16 (+77d) | 10d → 3d |  | 77d → 32d |  |
| 283 | FM 2 Boom Structure Vibration Test | 2004-07-06 → 2004-08-20 (+45d) | 2004-07-09 → 2004-08-25 (+47d) |  |  | 36d → 12d |  |
| 284 | FM 2 Boom Structure Themal Vac & Bake Out | 2004-07-12 → 2004-08-26 (+45d) | 2004-07-30 → 2004-09-16 (+48d) |  |  | 36d → 12d |  |
| 285 | **MAG - GSFC** |  | 2004-05-10 → 2004-05-18 A (+8d) | 57d → 63d | 55% → 100% | 71d → none |  |
| 286 | **Deliveries** | 2004-04-23 → 2004-04-28 A (+5d) | 2004-05-10 → 2004-05-18 A (+8d) | 12d → 15d | 0% → 100% | 29d → none |  |
| 287 | Deliver MAG FM 1 (to UCB for IDPU/BOOM Suite FM 1 I&T) | 2004-04-23 → 2004-04-28 A (+5d) | 2004-04-26 → 2004-04-29 A (+3d) |  | 0% → 100% | 29d → none |  |
| 288 | Deliver MAG FM 2 (to UCB for IDPU/BOOM Suite FM 2 I&T) | 2004-05-07 → 2004-05-17 A (+10d) | 2004-05-10 → 2004-05-18 A (+8d) |  | 0% → 100% | 71d → none |  |
| 289 | **FM 1** |  | 2004-04-22 → 2004-04-27 A (+5d) | 45d → 48d | 62% → 100% | 29d → none |  |
| 291 | MAG FM 1 Calibration |  | 2004-04-22 → 2004-04-27 A (+5d) | 19d → 22d | 21% → 100% | 29d → none |  |
| 292 | **FM 2** |  | 2004-05-06 → 2004-05-14 A (+8d) | 45d → 51d | 54% → 100% | 71d → none |  |
| 293 | FM 2 MAG Testing |  | 2004-04-01 A |  | 95% → 100% | 71d → none |  |
| 294 | MAG FM 2 Calibration | 2004-04-16 A | 2004-05-06 → 2004-05-14 A (+8d) | 15d → 21d | 0% → 100% | 71d → none |  |
| 295 | **SWEA - CESR** |  | 2004-04-20 → 2004-06-07 A (+48d) | 93d → 126d | 53% → 100% | 67d → none |  |
| 296 | **Deliveries** |  | 2004-04-20 → 2004-06-07 A (+48d) | 93d → 126d | 50% → 100% | 67d → none |  |
| 298 | SWEA FM 2 Delivery to UCB | 2004-04-16 → 2004-06-03 A (+48d) | 2004-04-20 → 2004-06-07 A (+48d) |  | 0% → 100% | 67d → none | 301 → 301FS+7d |
| 299 | **FM 2** |  | 2004-04-15 → 2004-05-21 A (+36d) | 24d → 50d | 54% → 100% | 67d → none |  |
| 301 | SWEA FM 2 Calibration |  | 2004-04-15 → 2004-05-21 A (+36d) | 19d → 45d | 42% → 100% | 67d → none |  |
| 302 | **STE - UCB** |  | 2004-06-29 → 2004-08-13 (+45d) | 209d → 241d | 74% → 92% | 36d → 12d |  |
| 303 | **Deliveries** | 2004-05-05 → 2004-06-14 A (+40d) | 2004-06-29 → 2004-08-13 (+45d) | 38d → 43d |  | 19d → 12d |  |
| 304 | Deliver STE-D FM 1 (stays at UCB for SWEA/STE-D FM 1 I&T) | 2004-05-05 → 2004-06-14 A (+40d) | 2004-05-05 → 2004-06-14 A (+40d) |  | 0% → 100% | 19d → none |  |
| 305 | Deliver STE-D FM 2 (stays at UCB for SWEA/STE-D FM 2 I&T) | 2004-06-29 → 2004-08-13 (+45d) | 2004-06-29 → 2004-08-13 (+45d) |  |  | 18d → -5d |  |
| 306 | Deliver STE-U FM 1 (stays at UCB for BOOM Suite FM 1 I&T) | 2004-05-07 → 2004-06-16 A (+40d) | 2004-05-07 → 2004-06-16 A (+40d) |  | 0% → 100% | 20d → none |  |
| 307 | Deliver STE-U FM 2 (stays at UCB for BOOM Suite FM 2 I&T) | 2004-06-29 → 2004-08-13 (+45d) | 2004-06-29 → 2004-08-13 (+45d) |  |  | 36d → 12d |  |
| 311 | **STE-U/D Detector Boards** |  | 2004-06-29 → 2004-08-13 (+45d) | 209d → 241d | 67% → 90% | 36d → 12d |  |
| 313 | **FM 1** |  | 2004-05-07 → 2004-06-16 A (+40d) | 173d → 200d | 74% → 100% | 20d → none |  |
| 317 | **Integration & Test** |  | 2004-05-07 → 2004-06-16 A (+40d) | 57d → 84d | 40% → 100% | 20d → none |  |
| 318 | Integrate & Test STE-U/D FM 1 Detectors W/ FM 1 Housings |  | 2004-04-23 A |  | 64% → 100% | 18d → none |  |
| 319 | Calibrate STE-U/D FM 1 | 2004-04-12 A | 2004-05-05 → 2004-06-14 A (+40d) | 18d → 45d | 0% → 100% | 18d → none |  |
| 320 | STE-U FM 1 Thermal Vacuum/Balance/Bake Out | 2004-04-26 A | 2004-05-07 → 2004-06-16 A (+40d) | 10d → 31d | 0% → 100% | 20d → none | 319FS-8d → 319FS-6d |
| 321 | **FM 2** |  | 2004-06-29 → 2004-08-13 (+45d) | 209d → 241d | 57% → 79% | 36d → 12d |  |
| 324 | Test STE FM 2 Detector Printed Wiring Board |  | 2004-04-30 → 2004-06-14 A (+45d) | 35d → 65d | 37% → 100% | 21d → none |  |
| 325 | **Integration & Test** | 2004-05-06 → 2004-06-15 A (+40d) | 2004-06-29 → 2004-08-13 (+45d) | 38d → 43d | 0% → 21% | 18d → 12d |  |
| 326 | Integrate & Test STE-U/D FM 2 Detectors W/ FM 2 Housings | 2004-05-06 → 2004-06-15 A (+40d) | 2004-06-03 → 2004-07-13 (+40d) |  | 0% → 60% | 18d → -5d |  |
| 327 | Calibrate STE-U/D FM 2 | 2004-05-20 → 2004-07-07 (+48d) | 2004-06-29 → 2004-08-13 (+45d) |  |  | 18d → -5d | 326FS-10d → 326FS-5d |
| 328 | STE-U FM 2 Thermal Vacuum/Bake Out | 2004-06-16 → 2004-08-02 (+47d) | 2004-06-29 → 2004-08-13 (+45d) |  |  | 36d → 12d |  |
| 329 | **STE and SWEA - UCB** |  | 2004-09-07 → 2004-11-15 (+69d) | 300d → 346d | 75% → 90% | 14d → -28d |  |
| 330 | **Deliveries** | 2004-04-16 → 2004-05-14 A (+28d) | 2004-09-07 → 2004-11-04 (+58d) | 100d → 120d |  | 14d → -22d |  |
| 331 | Deliver STE-U FM 1 Interface (stays at UCB for IDPU FM 1 I&T) | 2004-04-16 → 2004-05-14 A (+28d) | 2004-04-16 → 2004-05-14 A (+28d) |  | 0% → 100% | 42d → none |  |
| 332 | Deliver STE-U FM 2 Interface (stays at UCB for IDPU FM 2 I&T) | 2004-04-23 → 2004-06-09 A (+47d) | 2004-04-23 → 2004-06-09 A (+47d) |  | 0% → 100% | 89d → none |  |
| 333 | Deliver SWEA/STE-D FM 1 (stays at UCB for Boom Suite FM 1 I&T) | 2004-07-12 → 2004-09-03 (+53d) | 2004-07-12 → 2004-09-03 (+53d) |  |  | 2d → -42d | 386 → 385 |
| 334 | Deliver SWEA/STE-D FM 2 (stays at UCB for Boom Suite FM 2 I&T) | 2004-09-07 → 2004-11-04 (+58d) | 2004-09-07 → 2004-11-04 (+58d) |  |  | 14d → -22d |  |
| 338 | **STE-D Pre-Amp Board** |  | 2004-04-16 → 2004-05-14 A (+28d) | 143d → 163d | 83% → 100% | 39d → none |  |
| 339 | **FM 1** |  | 2004-04-16 → 2004-05-14 A (+28d) | 143d → 163d | 81% → 100% | 2d → none |  |
| 341 | Load STE-D FM 1 Preamp Printed Wiring Board |  | 2004-04-16 → 2004-05-14 A (+28d) | 29d → 49d | 59% → 100% | 2d → none |  |
| 342 | **FM 2** |  | 2004-04-16 → 2004-05-14 A (+28d) | 143d → 163d | 81% → 100% | 39d → none |  |
| 344 | Load STE-D FM 2 Preamp Printed Wiring Board |  | 2004-04-16 → 2004-05-14 A (+28d) | 29d → 49d | 59% → 100% | 39d → none |  |
| 346 | **STE-D Shaper Board** |  | 2004-05-21 A |  | 89% → 100% | 14d → none |  |
| 350 | **FM 2** |  | 2004-05-21 A |  | 67% → 100% | 14d → none |  |
| 352 | Load STE-D FM 2 Shaper Printed Wiring Board | 2004-05-17 → 2004-05-03 A (-14d) | 2004-05-21 A | 5d → 15d | 0% → 100% | 14d → none | 353, 381 → 353FS+78d |
| 354 | **STE-D Interface Board** |  | 2004-05-21 A |  | 89% → 100% | 14d → none |  |
| 358 | **FM 2** |  | 2004-05-21 A |  | 67% → 100% | 14d → none |  |
| 360 | Load SWEA / STE-D FM 2 Digital to Analog Converter Printed Wiring Board | 2004-05-17 → 2004-05-03 A (-14d) | 2004-05-21 A | 5d → 15d | 0% → 100% | 14d → none |  |
| 362 | **STE-U Pre-Amp Board** |  | 2004-04-16 → 2004-05-11 A (+25d) | 143d → 160d | 90% → 100% | 89d → none |  |
| 366 | **FM 2** |  | 2004-04-16 → 2004-05-11 A (+25d) | 143d → 160d | 81% → 100% | 89d → none |  |
| 368 | Load STE-U FM 2 Preamp Printed Wiring Board |  | 2004-04-16 → 2004-05-11 A (+25d) | 29d → 46d | 59% → 100% | 89d → none |  |
| 378 | **Integration & Test** |  | 2004-09-07 → 2004-11-15 (+69d) | 120d → 166d | 4% → 51% | 14d → -28d |  |
| 379 | **FM 1** |  | 2004-09-07 → 2004-11-15 (+69d) | 120d → 166d | 8% → 56% | 11d → -31d |  |
| 380 | Integrate & Test STE-U FM 1 Interface Boards |  | 2004-04-16 → 2004-05-14 A (+28d) | 20d → 40d | 40% → 100% | 42d → none |  |
| 381 | Integrate & Test SWEA/STE-D FM 1 Interface Boards | 2004-04-19 → 2004-05-24 A (+35d) | 2004-05-14 → 2004-06-21 A (+38d) |  | 0% → 100% | 2d → none | 336, 341, 349, 357 → 336, 341, 349, 357, 352 |
| 382 | Integrate & Test SWEA/STE-D FM 1 Interface with SWEA/STE-D FM 1 LVPS | 2004-05-17 → 2004-07-26 (+70d) | 2004-05-28 → 2004-08-06 (+70d) |  |  | 2d → -42d |  |
| 383 | Clean/Coat/Stake SWEA/STE-D Interface | 2004-05-17 → 2004-06-22 A (+36d) | 2004-05-28 → 2004-07-06 (+39d) |  | 0% → 70% | 2d → -19d |  |
| 384 | Integrate & Test SWEA/STE-D FM 1 Combined | 2004-06-01 → 2004-08-09 (+69d) | 2004-06-07 → 2004-08-13 (+67d) |  |  | 2d → -42d |  |
| 385 | Calibrate SWEA/STE FM 1 | 2004-06-08 → 2004-08-16 (+69d) | 2004-07-05 → 2004-09-03 (+60d) | 20d → 15d |  | 2d → -42d |  |
| 386 | SWEA/STE FM 1 Vibration | 2004-07-06 → 2004-10-19 (+105d) | 2004-07-12 → 2004-10-25 (+105d) |  |  | 2d → -31d | 385 → 385, 19 |
| 387 | SWEA/STE-D FM 1 Thermal Vac/Thermal Balance/Bake Out | 2004-08-18 → 2004-10-26 (+69d) | 2004-09-07 → 2004-11-15 (+69d) |  |  | 11d → -31d | 19 → 386 |
| 388 | **FM 2** | 2004-04-19 → 2004-05-12 A (+23d) | 2004-09-07 → 2004-11-04 (+58d) | 100d → 123d | 0% → 44% | 14d → -22d |  |
| 389 | Integrate & Test STE-U FM 2 Interface Boards | 2004-04-19 → 2004-05-12 A (+23d) | 2004-04-23 → 2004-06-09 A (+47d) | 5d → 20d | 0% → 100% | 89d → none |  |

| ID | Task | Start | Finish | Duration | Complete | Total float | Predecessors | Other |
| --- | --- | --- | --- | --- | --- | --- | --- | --- |
| 390 | Integrate & Test SWEA/STE-D FM 2 Interface Boards | 2004-05-24 A | 2004-06-21 A |  | 0% → 100% | 14d → none |  |  |
| 391 | Integrate & Test SWEA/STE-D FM 2 Interface with SWEA/STE-D FM 2 LVPS | 2004-06-22 → 2004-08-25 (+64d) | 2004-07-05 → 2004-09-08 (+65d) |  |  | 14d → -22d |  |  |
| 392 | Integrate & Test SWEA/STE-D FM 2 Combined | 2004-07-06 → 2004-09-09 (+65d) | 2004-07-19 → 2004-09-22 (+65d) |  |  | 14d → -22d |  |  |
| 393 | Calibrate SWEA/STE FM 2 | 2004-07-20 → 2004-09-23 (+65d) | 2004-08-16 → 2004-10-14 (+59d) | 20d → 15d |  | 14d → -22d |  |  |
| 394 | SWEA/STE FM 2 Vibration | 2004-08-17 → 2004-10-15 (+59d) | 2004-08-23 → 2004-10-21 (+59d) |  |  | 14d → -22d |  |  |
| 395 | SWEA/STE-D FM 2 Thermal Vac & bake Out | 2004-08-24 → 2004-10-22 (+59d) | 2004-09-07 → 2004-11-04 (+58d) |  |  | 14d → -22d |  |  |
| 396 | **Boom Suite I&T - UCB** | 2004-05-10 → 2004-06-17 A (+38d) | 2004-10-06 → 2004-11-30 (+55d) | 106d → 114d | 0% → 11% | 14d → -22d |  |  |
| 397 | **FM 1** | 2004-05-10 → 2004-06-17 A (+38d) | 2004-09-21 → 2004-11-22 (+62d) | 95d → 109d | 0% → 27% | 11d → -31d |  |  |
| 398 | FM 1 Boom/MAG/STE-U I&T | 2004-05-10 → 2004-06-17 A (+38d) | 2004-05-13 → 2004-06-22 A (+40d) |  | 0% → 100% | 20d → none |  |  |
| 399 | FM 1 Boom/SWEA/STE/MAG I&T | 2004-07-13 → 2004-09-07 (+56d) | 2004-07-14 → 2004-09-08 (+56d) |  |  | 2d → -42d |  |  |
| 400 | FM 1 Integrated Boom/IDPU I&T | 2004-07-26 → 2004-09-09 (+45d) | 2004-07-29 → 2004-09-14 (+47d) |  |  | -5d → -42d | 399, 235, 860 → 399, 235, 211 |  |
| 401 | Final BOOM Suite FM 1 I & T | 2004-09-08 → 2004-11-16 (+69d) | 2004-09-21 → 2004-11-22 (+62d) | 10d → 5d |  | 11d → -31d | 400, 387 → 400, 387, 226 |  |
| 402 | **FM 2** | 2004-06-30 → 2004-08-16 (+47d) | 2004-10-06 → 2004-11-30 (+55d) | 70d → 73d |  | 14d → -22d |  |  |
| 403 | FM 2 Boom/MAG/STE-U I&T | 2004-06-30 → 2004-08-16 (+47d) | 2004-07-05 → 2004-08-19 (+45d) |  |  | 36d → 12d |  |  |
| 404 | FM 2 Boom/SWEA/STE/MAG I&T | 2004-09-08 → 2004-11-05 (+58d) | 2004-09-09 → 2004-11-08 (+60d) |  |  | 14d → -22d |  |  |
| 405 | FM 2 Integrated Boom/IDPU I&T | 2004-09-10 → 2004-11-09 (+60d) | 2004-09-15 → 2004-11-15 (+61d) |  |  | 14d → -22d | 404, 236, 874 → 404, 236, 230 |  |
| 406 | Boom Suite FM 2 EMC | 2004-09-16 → 2004-11-16 (+61d) | 2004-09-22 → 2004-11-22 (+61d) |  |  | 14d → -22d |  |  |
| 407 | Final BOOM Suite FM 2 I & T | 2004-09-23 → 2004-11-23 (+61d) | 2004-10-06 → 2004-11-30 (+55d) | 10d → 5d |  | 14d → -22d |  |  |
| 408 | **SEP Suite - CIT** |  | 2004-10-25 → 2004-12-31 (+67d) | 354d → 400d | 57% → 80% | 3d → -44d |  |  |
| 409 | **SEP Mechanical - Sandy Shuman (GSFC)** |  | 2004-07-07 → 2004-10-18 (+103d) | 115d → 185d | 26% → 72% | 29d → -33d |  |  |
| 410 | **SIT Electronics Enclosure (Priority 1)** |  | 2004-05-04 → 2004-05-17 A (+13d) | 61d → 70d | 34% → 100% | 26d → none |  |  |
| 412 | Fabrication of SIT Enclosure | 2004-04-08 A | 2004-04-23 → 2004-05-06 A (+13d) | 12d → 21d | 0% → 100% | 26d → none |  |  |
| 413 | Inspection and Final Assembly of SIT Enclosure | 2004-04-26 → 2004-05-07 A (+11d) | 2004-05-03 → 2004-05-14 A (+11d) |  | 0% → 100% | 26d → none |  |  |
| 414 | Deliver SIT Enclosure to UMD | 2004-05-04 → 2004-05-17 A (+13d) | 2004-05-04 → 2004-05-17 A (+13d) |  | 0% → 100% | 26d → none |  |  |
| 415 | **SEP FM 1 & FM 2 LVPS Boxes (Priority 2)** |  | 2004-04-22 A |  | 70% → 100% | 17d → none |  |  |
| 417 | Fabrication of SEP LVPS Boxes |  | 2004-04-05 A |  | 91% → 100% | 17d → none |  |  |
| 418 | Inspection of SEP LVPS Boxes (Final Assembly at UCB) | 2004-04-06 A | 2004-04-19 A |  | 0% → 100% | 17d → none |  |  |
| 419 | Deliver SEP LVPS Boxes to UCB | 2004-04-20 A | 2004-04-22 A |  | 0% → 100% | 17d → none |  |  |
| 420 | **SEP Electronics Enclosure (Priority 3)** |  | 2004-05-21 → 2004-06-24 A (+34d) | 69d → 92d | 46% → 100% | 19d → none |  |  |
| 421 | Complete Design/Drawings for SEP Enclosure |  | 2004-04-19 → 2004-05-27 A (+38d) | 45d → 73d | 71% → 100% | 2d → none |  |  |
| 422 | Fabrication of SEP Enclosure | 2004-04-20 → 2004-05-21 A (+31d) | 2004-05-10 → 2004-06-11 A (+32d) |  | 0% → 100% | 19d → none | 421 → 421FS-5d |  |
| 423 | Inspection and Final Assembly of SEP Enclosure | 2004-05-11 → 2004-06-14 A (+34d) | 2004-05-18 → 2004-06-21 A (+34d) |  | 0% → 100% | 19d → none |  |  |
| 424 | Deliver SEP Enclosure to CIT | 2004-05-19 → 2004-06-22 A (+34d) | 2004-05-21 → 2004-06-24 A (+34d) |  | 0% → 100% | 19d → none |  |  |
| 425 | **SEP Central Bias Supply Shields (Priority 4)** | 2004-04-15 → 2004-05-25 A (+40d) | 2004-05-12 → 2004-06-22 A (+41d) |  | 0% → 100% | 2d → none |  |  |
| 426 | Complete Design/Drawings for Bias Supply Shields | 2004-04-15 → 2004-05-25 A (+40d) | 2004-04-21 → 2004-06-01 A (+41d) |  | 0% → 100% | 2d → none |  |  |
| 427 | Fabrication of Bias Supply Shields | 2004-04-22 → 2004-06-02 A (+41d) | 2004-05-05 → 2004-06-15 A (+41d) |  | 0% → 100% | 68d → none |  |  |
| 428 | Inspection and Delivery (to CIT) of Bias Supply Shields | 2004-05-06 → 2004-06-16 A (+41d) | 2004-05-12 → 2004-06-22 A (+41d) |  | 0% → 100% | 68d → none |  |  |
| 429 | **LET Telescope (Priority 5)** | 2004-04-15 → 2004-05-25 A (+40d) | 2004-05-20 → 2004-06-28 A (+39d) | 26d → 24d | 0% → 100% | 2d → none |  |  |
| 430 | Complete Design/Drawings for LET Telescope | 2004-04-15 → 2004-05-25 A (+40d) | 2004-04-21 → 2004-06-01 A (+41d) |  | 0% → 100% | 2d → none |  |  |
| 431 | Fabrication of LET Telescope | 2004-04-22 → 2004-06-02 A (+41d) | 2004-05-05 → 2004-06-15 A (+41d) |  | 0% → 100% | 6d → none |  |  |
| 432 | Inspection and Final Assembly of LET Telescope (CIT has detectors) | 2004-05-06 → 2004-06-16 A (+41d) | 2004-05-17 → 2004-06-25 A (+39d) |  | 0% → 100% | 6d → none |  |  |
| 433 | Deliver LET Telescope to CIT | 2004-05-18 → 2004-06-28 A (+41d) | 2004-05-20 → 2004-06-28 A (+39d) | 3d → 1d | 0% → 100% | 6d → none |  |  |
| 434 | **HET Electronics Enclosure (Priority 6)** |  | 2004-05-13 → 2004-06-23 A (+41d) | 39d → 67d | 21% → 100% | 2d → none |  |  |
| 435 | Complete Design/Drawings for HET Enclosure |  | 2004-04-22 → 2004-06-02 A (+41d) |  | 35% → 100% | 2d → none |  |  |
| 436 | Fabrication of HET Enclosure | 2004-04-23 → 2004-06-03 A (+41d) | 2004-05-06 → 2004-06-16 A (+41d) |  | 0% → 100% | 2d → none |  |  |
| 437 | Inspection and Final Assembly of HET Enclosure | 2004-05-07 → 2004-06-17 A (+41d) | 2004-05-13 → 2004-06-23 A (+41d) |  | 0% → 100% | 2d → none |  |  |
| 438 | Deliver HET Enclosure (stays at GSFC) | 2004-05-13 → 2004-06-23 A (+41d) | 2004-05-13 → 2004-06-23 A (+41d) |  | 0% → 100% | 2d → none |  |  |
| 439 | **HET Telescope (Priority 7)** |  | 2004-05-24 → 2004-06-18 A (+25d) | 84d → 102d | 32% → 100% | 2d → none |  |  |
| 440 | On Going work for HET Telescope (Complete Design/Drawings & Prep for Fab) |  | 2004-04-14 → 2004-06-02 A (+49d) | 56d → 89d | 41% → 100% | 1d → none | none → 435FF | constraint start no earlier than 2004-01-27 → finish no earlier than 2004-06-01 |
| 441 | Fabrication of HET Telescope | 2004-04-15 → 2004-05-28 A (+43d) | 2004-04-28 → 2004-06-11 A (+44d) |  | 0% → 100% | 13d → none | 440 → 440FS-3d |  |
| 442 | Inspection and Final Assembly of HET Telescope | 2004-05-14 → 2004-06-14 A (+31d) | 2004-05-24 → 2004-06-18 A (+25d) | 7d → 5d | 0% → 100% | 2d → none | 441, 438 → 441, 437SS-3d, 438FS-8d |  |
| 443 | Deliver HET Telescope (stays at GSFC) | 2004-05-24 → 2004-06-18 A (+25d) | 2004-05-24 → 2004-06-18 A (+25d) |  | 0% → 100% | 2d → none |  |  |
| 444 | **SIT Telescope (Priority 9)** | 2004-04-15 → 2004-07-13 A (+89d) | 2004-06-09 → 2004-09-15 (+98d) | 39d → 46d | 0% → 32% | 1d → -11d |  | was named SIT Telescope (Priority 8) |
| 445 | Complete Design/Drawings for SIT Telescope | 2004-04-15 → 2004-07-13 A (+89d) | 2004-05-10 → 2004-08-09 (+91d) | 18d → 20d | 0% → 70% | 1d → -40d | 440 → 897, 898 |  |
| 446 | Fabrication of SIT Telescope | 2004-05-11 → 2004-07-27 A (+77d) | 2004-05-24 → 2004-08-30 (+98d) | 10d → 25d | 0% → 16% | 1d → -50d | 445 → 445FS-10d |  |
| 447 | Inspection and Final Assembly of SIT Telescope | 2004-05-25 → 2004-08-31 (+98d) | 2004-06-08 → 2004-09-14 (+98d) |  |  | 1d → -50d |  |  |
| 448 | Deliver SIT Telescope to UMD (Includes the Foils and Detectors) | 2004-06-09 → 2004-09-15 (+98d) | 2004-06-09 → 2004-09-15 (+98d) |  |  | 1d → -50d |  |  |
| 449 | **Shipping Containers for HET, SIT & SEP Central (Priority 8)** | 2004-05-11 → 2004-05-10 A (-1d) | 2004-06-11 → 2004-06-24 A (+13d) | 23d → 33d | 0% → 100% | 8d → none |  | was named Shipping Containers for HET, SIT & SEP Central (Priority 9) |
| 450 | Design | 2004-05-11 → 2004-05-10 A (-1d) | 2004-05-17 → 2004-05-28 A (+11d) | 5d → 15d | 0% → 100% | 8d → none | 445 → none | constraint none → start no earlier than 2004-05-10 |
| 451 | Fabrication/Machining | 2004-05-18 → 2004-06-01 A (+14d) | 2004-06-01 → 2004-06-14 A (+13d) |  | 0% → 100% | 12d → none |  |  |
| 452 | Inspection and Assembly | 2004-06-02 → 2004-06-15 A (+13d) | 2004-06-08 → 2004-06-21 A (+13d) |  | 0% → 100% | 12d → none |  |  |
| 453 | HET Container stays at GSFC | 2004-06-08 → 2004-06-21 A (+13d) | 2004-06-08 → 2004-06-21 A (+13d) |  | 0% → 100% | 12d → none |  |  |
| 454 | SIT Container to UMD | 2004-06-09 → 2004-06-22 A (+13d) | 2004-06-09 → 2004-06-22 A (+13d) |  | 0% → 100% | 24d → none |  |  |
| 455 | SEP Central Container to CIT | 2004-06-09 → 2004-06-22 A (+13d) | 2004-06-11 → 2004-06-24 A (+13d) |  | 0% → 100% | 13d → none |  |  |
| 471 | **SIT Door (Priority 13)** | 2004-05-18 → 2004-08-26 (+100d) | 2004-06-24 → 2004-10-04 (+102d) |  |  | 8d → -47d |  | was named SIT Door (Priority 10) |
| 472 | Complete Design/Drawings for SIT Door | 2004-05-18 → 2004-08-26 (+100d) | 2004-06-01 → 2004-09-09 (+100d) |  |  | 8d → -47d | 450 → 467 |  |
| 473 | Fabrication | 2004-06-02 → 2004-09-10 (+100d) | 2004-06-15 → 2004-09-23 (+100d) |  |  | 35d → -36d |  |  |
| 474 | Inspection | 2004-06-16 → 2004-09-24 (+100d) | 2004-06-22 → 2004-09-30 (+100d) |  |  | 35d → -36d |  |  |
| 475 | Final Assembly | 2004-06-23 → 2004-10-01 (+100d) | 2004-06-23 → 2004-10-01 (+100d) |  |  | 35d → -36d |  |  |
| 476 | Deliver SIT Door (stay at GSFC for Environmental Testing) | 2004-06-24 → 2004-10-04 (+102d) | 2004-06-24 → 2004-10-04 (+102d) |  |  | 35d → -36d |  |  |

| ID | Task | Start | Finish | Duration | Complete | Total float | Predecessors | Other |
| --- | --- | --- | --- | --- | --- | --- | --- | --- |
| 477 | **LET Radiation Test Fixture (Priority 14)** | 2004-06-02 → 2004-09-10 (+100d) | 2004-07-07 → 2004-10-18 (+103d) |  |  | 8d → -47d |  | was named LET Radiation Test Fixture (Priority 11) |
| 478 | Design | 2004-06-02 → 2004-09-10 (+100d) | 2004-06-08 → 2004-09-16 (+100d) |  |  | 8d → -47d |  |  |
| 479 | Fabrication | 2004-06-09 → 2004-09-17 (+100d) | 2004-06-22 → 2004-09-30 (+100d) |  |  | 8d → -47d |  |  |
| 480 | Inspection and Assembly | 2004-06-23 → 2004-10-01 (+100d) | 2004-07-06 → 2004-10-15 (+101d) |  |  | 8d → -47d |  |  |
| 481 | Deliver to CIT for SEP I&T | 2004-07-07 → 2004-10-18 (+103d) | 2004-07-07 → 2004-10-18 (+103d) |  |  | 8d → -47d |  |  |
| 482 | **SEP Central - CIT** |  | 2004-06-25 → 2004-09-17 (+84d) | 227d → 285d | 72% → 86% | 37d → -18d |  |  |
| 483 | **Deliveries** | 2004-04-14 → 2004-06-28 A (+75d) | 2004-06-25 → 2004-09-17 (+84d) | 51d → 57d |  | 37d → -18d |  |  |
| 484 | Deliver all SEP Cen FM 1 Boards to SEP I&T (stays at CIT) | 2004-06-01 → 2004-06-28 A (+27d) | 2004-06-01 → 2004-06-28 A (+27d) |  | 0% → 100% | 13d → none | 508 → 493, 496, 503, 67FS+19d |  |
| 485 | Deliver all SEP Cen FM 2 Boards & FM 2 LVPS to SEP I&T (stays at CIT) | 2004-06-25 → 2004-06-29 A (+4d) | 2004-06-25 → 2004-06-29 A (+4d) |  | 0% → 100% | 37d → none | 508, 73, 428 → 73, 428, 494, 497, 504 |  |
| 486 | SEP Central Build 3 Software Complete | 2004-04-14 → 2004-07-29 (+106d) | 2004-04-14 → 2004-07-29 (+106d) |  |  | 46d → 17d |  |  |
| 487 | Final SEP Central Flight Software Complete | 2004-06-03 → 2004-09-17 (+106d) | 2004-06-03 → 2004-09-17 (+106d) |  |  | 35d → -40d |  |  |
| 488 | **Logic Board** |  | 2004-05-06 → 2004-05-28 A (+22d) | 59d → 75d | 71% → 100% | 0d → none |  |  |
| 492 | **Test** |  | 2004-05-06 → 2004-05-28 A (+22d) | 49d → 65d | 62% → 100% | 0d → none |  |  |
| 494 | Test FM 2 SEP Central Logic board (initial) |  | 2004-05-06 → 2004-05-28 A (+22d) | 49d → 65d | 47% → 100% | -1d → none |  |  |
| 498 | **SEP Solid State Detector Bias Supply Board** |  | 2004-04-06 A |  | 93% → 100% | 21d → none |  |  |
| 502 | **Final Test** |  | 2004-04-06 A |  | 73% → 100% | 21d → none |  |  |
| 503 | Final Test FM 1 SSD Bias Supply Board |  | 2004-04-06 A |  | 73% → 100% | 21d → none |  |  |
| 504 | Final Test FM 2 SSD Bias Supply Board |  | 2004-04-06 A |  | 73% → 100% | 21d → none |  |  |
| 505 | **Conformal Coat, Mass Properties and Bake Out (SEP Central, LET, SEP LVPS)** | 2004-05-07 → 2004-07-21 (+75d) | 2004-06-01 → 2004-08-10 (+70d) | 17d → 15d |  | -1d → -17d |  |  |
| 506 | Stake/Conformal Coat All SEP Central and LET Boards | 2004-05-07 → 2004-07-21 (+75d) | 2004-05-20 → 2004-07-30 (+71d) | 10d → 8d |  | -1d → -17d | 493, 494, 496, 497, 503, 504, 588, 589 → 902 |  |
| 507 | Mass Properties/Photo All SEP Central and LET Boards | 2004-05-21 → 2004-08-02 (+73d) | 2004-05-26 → 2004-08-05 (+71d) |  |  | -1d → -17d |  |  |
| 508 | Bake Out All SEP Central/LET Boards and SEP LVPS FM 1 | 2004-05-27 → 2004-08-06 (+71d) | 2004-06-01 → 2004-08-10 (+70d) |  |  | -1d → -17d |  |  |
| 509 | **Flight Software** |  | 2004-06-03 → 2004-09-17 (+106d) | 211d → 285d | 68% → 81% | 35d → -35d |  |  |
| 510 | SEP Central Build 3 |  | 2004-04-14 → 2004-07-29 (+106d) | 176d → 250d | 81% → 92% | 35d → -40d |  |  |
| 511 | Final Flight S/W Build | 2004-04-15 → 2004-07-30 (+106d) | 2004-06-03 → 2004-09-17 (+106d) |  |  | 35d → -40d |  |  |
| 512 | **HET - Tycho (GSFC)** |  | 2004-07-21 → 2004-09-20 (+61d) | 139d → 180d | 55% → 86% | 48d → -13d |  |  |
| 513 | **Deliveries** | 2004-06-02 → 2004-06-28 A (+26d) | 2004-07-21 → 2004-09-20 (+61d) | 36d → 59d | 0% → 60% | 17d → -13d |  |  |
| 514 | Deliver HET FM 1w/o replacement detectors (to CIT for SEP Suite I&T) | 2004-06-30 → 2004-06-28 A (-2d) | 2004-07-01 → 2004-06-29 A (-2d) |  | 0% → 100% | -3d → none |  |  |
| 515 | Deliver HET FM 1 w/ replacement detectors & FM 2 after coating (to CIT for SEP Suite I&T) | 2004-07-20 → 2004-09-17 (+59d) | 2004-07-21 → 2004-09-20 (+61d) |  |  | -5d → -47d | 567 → 470, 567 | was named Deliver HET FM 1 w/ replacement detectors (to CIT for SEP Suite I&T) |
| 516 | Deliver HET FM 2 w/o replacement detectors (to CIT for SEP Suite I&T) | 2004-07-07 → 2004-06-28 A (-9d) | 2004-07-08 → 2004-06-29 A (-9d) |  | 0% → 100% | 34d → none |  | baseline start 2004-06-22 → 2004-06-01; baseline finish 2004-06-23 → 2004-06-02 |
| 517 | Deliver HET FM 2 w/ replacement detectors (to CIT for SEP Suite I&T) | 2004-07-20 → 2004-09-17 (+59d) | 2004-07-21 → 2004-09-20 (+61d) |  |  | 48d → -13d | 572, Detach HET FM2 from SEP Suite → 470, 573 | baseline start 2004-07-19 → 2004-06-22; baseline finish 2004-07-20 → 2004-06-23 |
| 518 | Deliver Final HET Flight Software to SEP I&T | 2004-06-02 → 2004-06-28 A (+26d) | 2004-06-03 → 2004-06-29 A (+26d) |  | 0% → 100% | 17d → none |  |  |
| 524 | **Replacement HET Detectors (Batch 2)** |  | 2004-06-14 → 2004-08-13 (+60d) | 66d → 109d | 0% → 73% | 18d → 8d |  |  |
| 527 | Detector Mounting at Micron | 2004-04-15 A | 2004-05-12 A |  | 0% → 100% | 18d → none |  |  |
| 528 | Detector Delivery to GSFC | 2004-05-13 A | 2004-05-14 → 2004-06-28 A (+45d) | 2d → 32d | 0% → 100% | 18d → none |  |  |
| 529 | Detector Testing at GSFC | 2004-05-17 A | 2004-06-14 → 2004-08-13 (+60d) | 20d → 63d | 0% → 51% | 18d → 8d | 528 → 528FS-20d |  |
| 534 | **Electronics Board** |  | 2004-05-21 → 2004-08-27 (+98d) | 86d → 154d | 56% → 76% | 45d → -2d |  |  |
| 539 | **Test** |  | 2004-05-21 → 2004-08-27 (+98d) | 84d → 152d | 54% → 75% | 45d → -2d |  |  |
| 540 | **FM 1** |  | 2004-05-14 → 2004-08-27 (+105d) | 79d → 152d |  | 8d → -36d |  |  |
| 545 | Clean, Bake, Conformal Coat HET FM 1 Electronics Board | 2004-05-03 → 2004-08-16 (+105d) | 2004-05-07 → 2004-08-20 (+105d) |  |  | 8d → -36d | 544FS+35d → 544FS+61d, 565FS+16d |  |
| 546 | Retest Conformal Coated HET FM 1 Electronics Board | 2004-05-10 → 2004-08-23 (+105d) | 2004-05-14 → 2004-08-27 (+105d) |  |  | 8d → -36d |  |  |
| 547 | **FM 2** |  | 2004-05-21 → 2004-08-27 (+98d) | 48d → 116d | 28% → 71% | 45d → -2d |  |  |
| 548 | Test HET FM 2 Electronics Board |  | 2004-04-27 → 2004-04-20 A (-7d) | 30d → 25d | 37% → 100% | 53d → none |  |  |
| 549 | Clean, Bake, Conformal Coat HET FM 2 Electronics Board | 2004-04-28 → 2004-08-16 (+110d) | 2004-05-04 → 2004-08-20 (+108d) |  |  | 53d → -2d | 548 → 571FS+16d |  |
| 550 | Retest Conformal Coated HET FM 2 Electronics Board | 2004-05-17 → 2004-08-23 (+98d) | 2004-05-21 → 2004-08-27 (+98d) |  |  | 45d → -2d | 549, 546 → 549 |  |
| 551 | **Flight Software** |  | 2004-06-01 → 2004-06-25 A (+24d) | 92d → 110d | 54% → 100% | -3d → none |  |  |
| 552 | **Design** |  | 2004-04-23 → 2004-04-30 A (+7d) | 66d → 71d | 59% → 100% | -2d → none |  |  |
| 554 | Design Change of HET PH Event Processing | 2004-04-05 A | 2004-04-23 → 2004-04-30 A (+7d) | 15d → 20d | 0% → 100% | -2d → none |  |  |
| 555 | **Coding** |  | 2004-04-14 → 2004-05-21 A (+37d) | 37d → 64d | 79% → 100% | 5d → none |  |  |
| 556 | Code HET PH Event Processing Update for Flight |  | 2004-04-01 → 2004-05-14 A (+43d) | 28d → 59d | 96% → 100% | 14d → none |  |  |
| 557 | Code HET Telemetry Formatting Update for Flight |  | 2004-04-14 → 2004-05-21 A (+37d) | 24d → 34d | 58% → 100% | 0d → none |  |  |
| 558 | **Test** |  | 2004-06-01 → 2004-06-25 A (+24d) | 50d → 68d | 18% → 100% | -3d → none |  |  |
| 559 | Test Integrated HET S/W with Simulated Data |  | 2004-04-26 → 2004-06-18 A (+53d) | 15d → 63d | 47% → 100% | 0d → none | 557 → none | constraint none → start no later than 2004-03-23 |
| 560 | Verify HET On-Board Software | 2004-04-27 → 2004-06-21 A (+55d) | 2004-06-01 → 2004-06-25 A (+24d) | 25d → 5d | 0% → 100% | -3d → none |  |  |
| 561 | **Integration & Test** | 2004-06-02 → 2004-06-21 A (+19d) | 2004-07-19 → 2004-09-09 (+52d) | 34d → 57d | 0% → 71% | -3d → -8d |  |  |
| 562 | **FM 1** | 2004-06-02 → 2004-06-21 A (+19d) | 2004-07-19 → 2004-08-31 (+43d) | 34d → 51d | 0% → 71% | -5d → -28d |  |  |
| 563 | Integrate HET FM 1 Electronics Telescope (Ahead) | 2004-06-02 → 2004-06-21 A (+19d) | 2004-06-08 → 2004-06-23 A (+15d) | 5d → 3d | 0% → 100% | -3d → none | 523, 560, 443, 546 → 523, 560FS-10d, 443 |  |
| 564 | Test HET FM 1 Telescope (Ahead) | 2004-06-09 → 2004-06-24 A (+15d) | 2004-06-29 → 2004-06-25 A (-4d) | 15d → 2d | 0% → 100% | -3d → none |  |  |
| 565 | Receive HET FM1 from CIT | 2004-07-15 → 2004-07-22 A (+7d) | 2004-07-15 → 2004-07-22 A (+7d) |  | 0% → 100% | -5d → none |  |  |
| 566 | Install new HET Flight Detectors in FM 1 | 2004-07-16 → 2004-08-30 (+45d) | 2004-07-16 → 2004-08-30 (+45d) |  |  | -5d → -36d | 529, 565 → 565, 546 |  |
| 567 | Performance Test FM 1 with New Flight Detectors | 2004-07-19 → 2004-08-31 (+43d) | 2004-07-19 → 2004-08-31 (+43d) |  |  | -5d → -36d | 566 → 566, 557 |  |
| 568 | **FM 2** | 2004-06-09 → 2004-06-21 A (+12d) | 2004-07-19 → 2004-09-09 (+52d) | 29d → 57d | 0% → 71% | 34d → -8d |  |  |
| 569 | Integrate HET FM 2 Electronics Telescope (Behind) | 2004-06-09 → 2004-06-21 A (+12d) | 2004-06-15 → 2004-06-23 A (+8d) | 5d → 3d | 0% → 100% | 34d → none | 563, 523, 560, 443, 550 → 523, 560FS-10d, 443, 548 |  |
| 570 | Test HET FM 2 Telescope (Behind) | 2004-06-16 → 2004-06-24 A (+8d) | 2004-07-06 → 2004-06-25 A (-11d) | 15d → 2d | 0% → 100% | 34d → none |  |  |
| 571 | Receive HET FM2 from CIT | 2004-07-16 → 2004-07-22 A (+6d) | 2004-07-16 → 2004-07-22 A (+6d) |  | 0% → 100% | 48d → none | Deliver HET FM2 to GSFC for Replacement Detectors, 570 → 903 | baseline start 2004-07-15 → 2004-07-14; baseline finish 2004-07-15 → 2004-07-14 |
| 572 | Install new HET Flight Detectors in FM 2 | 2004-07-19 → 2004-09-08 (+51d) | 2004-07-19 → 2004-09-08 (+51d) |  |  | 48d → -8d | 529, 571 → 529, 571, 550, 533 |  |
| 574 | **LET - CIT** |  | 2004-06-29 → 2004-09-07 (+70d) | 243d → 291d | 78% → 97% | 41d → 15d |  |  |
| 575 | **Deliveries** | 2004-05-04 → 2004-06-25 A (+52d) | 2004-06-29 → 2004-07-01 A (+2d) | 39d → 4d | 0% → 100% | 38d → none |  |  |
| 576 | Deliver LET FM 1 (stays at CIT for SEP I&T) | 2004-06-29 → 2004-07-01 A (+2d) | 2004-06-29 → 2004-07-01 A (+2d) |  | 0% → 100% | -1d → none |  |  |
| 577 | Deliver LET FM 2 (stays at CIT for SEP I&T) | 2004-06-29 → 2004-07-01 A (+2d) | 2004-06-29 → 2004-07-01 A (+2d) |  | 0% → 100% | 41d → none |  |  |

| ID | Task | Start | Finish | Duration | Complete | Total float | Predecessors | Other |
| --- | --- | --- | --- | --- | --- | --- | --- | --- |
| 578 | Deliver LET Flight Software Build 3 | 2004-05-04 → 2004-06-25 A (+52d) | 2004-05-04 → 2004-06-25 A (+52d) |  | 0% → 100% | 38d → none |  |  |
| 583 | **Detector/Misc Board** |  | 2004-05-06 → 2004-06-24 A (+49d) | 48d → 82d | 46% → 100% | 0d → none |  |  |
| 587 | **Test** |  | 2004-05-06 → 2004-06-24 A (+49d) | 38d → 72d | 32% → 100% | 0d → none |  |  |
| 588 | Test LET FM 1 Detector Board |  | 2004-05-06 → 2004-06-24 A (+49d) | 38d → 72d | 32% → 100% | -1d → none |  |  |
| 589 | Test LET FM 2 Detector Board |  | 2004-05-06 → 2004-06-24 A (+49d) | 38d → 72d | 32% → 100% | -1d → none |  |  |
| 590 | **Flight Software** |  | 2004-05-04 → 2004-06-25 A (+52d) | 190d → 227d | 75% → 100% | 38d → none |  |  |
| 591 | Let Flight Software Build 3 |  | 2004-05-04 → 2004-06-25 A (+52d) | 190d → 227d | 75% → 100% | 38d → none |  |  |
| 592 | **Integration & Test** | 2004-06-02 → 2004-06-29 A (+27d) | 2004-06-29 → 2004-07-01 A (+2d) | 20d → 3d | 0% → 100% | -1d → none |  |  |
| 593 | **FM 1** | 2004-06-02 → 2004-06-29 A (+27d) | 2004-06-29 → 2004-07-01 A (+2d) | 20d → 3d | 0% → 100% | -1d → none |  |  |
| 594 | Integrate LET FM 1 Housing With Detectors | 2004-06-02 → 2004-06-29 A (+27d) | 2004-06-29 → 2004-07-01 A (+2d) | 20d → 3d | 0% → 100% | -1d → none | 580, 508, 433 → 580, 433, 588 |  |
| 595 | **FM 2** | 2004-06-02 → 2004-06-29 A (+27d) | 2004-06-29 → 2004-07-01 A (+2d) | 20d → 3d | 0% → 100% | 41d → none |  |  |
| 596 | Integrate LET FM 2 Housing With Detectors | 2004-06-02 → 2004-06-29 A (+27d) | 2004-06-29 → 2004-07-01 A (+2d) | 20d → 3d | 0% → 100% | 41d → none | 580, 508, 433 → 580, 433, 589 |  |
| 602 | **SEPT - Kiel/ESTEC** |  | 2004-09-02 → 2004-12-09 (+98d) | 271d → 336d | 90% → 76% | 23d → -34d |  |  |
| 603 | **Deliveries** | 2004-03-15 → 2004-08-23 (+161d) | 2004-09-02 → 2004-12-09 (+98d) | 123d → 75d |  | 8d → -34d |  |  |
| 604 | Deliver SEPT-NS FM 1 to CIT for SEP I&T and Suite EMC | 2004-03-15 → 2004-08-23 (+161d) | 2004-03-19 → 2004-08-27 (+161d) |  |  | 8d → -31d | 644, 645 → 651 |  |
| 605 | Deliver SEPT-E FM 1 to CIT for SEP I&T and Suite EMC | 2004-03-15 → 2004-08-23 (+161d) | 2004-03-19 → 2004-08-27 (+161d) |  |  | 8d → -31d | 661, 660 → 667 |  |
| 606 | Final Delivery of SEPT FM 1 to APL | 2004-09-01 → 2004-11-24 (+84d) | 2004-09-02 → 2004-11-26 (+85d) |  |  | 23d → -34d | 653, SEPT-E FM 1 Thermal Balance (at GSFC after Suite EMC), 637 → 637, 655, 671 | was named Final Delivery of SEPT FM 1 to APL (after Therm Bal @ GSFC) |
| 607 | Deliver SEPT-NS FM 2 to CIT for Suite EMC and final delivery to APL | 2004-03-18 → 2004-12-03 (+260d) | 2004-03-24 → 2004-12-09 (+260d) |  |  | 107d → -34d | 677, 678 → 688 | was named Deliver SEPT-NS FM 2 to CIT for SEP I&T and Suite EMC |
| 608 | Deliver SEPT-E FM 2 to CIT for Suite EMC and final delivery to APL | 2004-03-18 → 2004-12-03 (+260d) | 2004-03-24 → 2004-12-09 (+260d) |  |  | 107d → -34d | 693, 694 → 704 | was named Deliver SEPT-E FM 2 to CIT for SEP I&T and Suite EMC |
| 618 | **Electronics** |  | 2004-05-21 → 2004-09-07 (+109d) | 198d → 272d | 94% → 91% | 94d → 19d |  |  |
| 619 | **Assembly** |  | 2004-04-15 A |  | 97% → 100% | 105d → none |  |  |
| 623 | **Spare** |  | 2004-04-15 A |  | 94% → 100% | 105d → none |  |  |
| 624 | Assemble SEPT FS Electronics |  | 2004-04-15 A |  | 94% → 100% | 105d → none |  |  |
| 625 | **Test** |  | 2004-05-21 → 2004-09-07 (+109d) | 113d → 187d | 70% → 73% | 94d → 19d |  |  |
| 626 | **FM 2** |  | 2004-01-30 A → 2004-08-31 (+214d) | 34d → 183d | 100% → 69% | none → 19d |  |  |
| 634 | **Spare** | 2004-04-26 A | 2004-05-21 → 2004-09-07 (+109d) | 20d → 94d | 0% → 89% | 94d → 19d |  |  |
| 635 | SEPT Flight Spare Electronics Test | 2004-04-26 A | 2004-04-30 A |  | 0% → 100% | 99d → none |  |  |
| 636 | Coat SEPT FS Electronics Board | 2004-05-10 A | 2004-05-14 → 2004-06-18 A (+35d) | 5d → 29d | 0% → 100% | 94d → none |  |  |
| 637 | SEPT FS Mechanical Integration | 2004-05-17 → 2004-09-01 (+107d) | 2004-05-21 → 2004-09-07 (+109d) | 5d → 4d |  | 94d → 19d | 636 → 636, 633 |  |
| 638 | **Integration & Test** |  | 2004-08-31 → 2004-12-02 (+93d) | 164d → 226d | 84% → 62% | 23d → -34d |  |  |
| 639 | **FM 1** |  | 2004-08-31 → 2004-11-23 (+84d) | 164d → 220d | 73% → 62% | 23d → -34d |  |  |
| 640 | **SEPT-NS** |  | 2004-08-31 → 2004-11-23 (+84d) | 155d → 211d | 73% → 62% | 23d → -34d |  |  |
| 653 | SEPT-NS FM 1 Thermal Balance (at GSFC after Suite EMC) | 2004-08-18 → 2004-10-25 (+68d) | 2004-08-31 → 2004-11-05 (+66d) |  |  | 23d → -34d | 19 → 652 |  |
| 656 | **SEPT-E** |  | 2004-08-31 → 2004-11-23 (+84d) | 164d → 220d | 73% → 62% | 23d → -34d |  |  |
| 672 | **FM 2** |  | 2004-03-17 A → 2004-12-02 (+260d) | 46d → 226d | 100% → 62% | none → -34d |  |  |
| 673 | **SEPT-NS** |  | 2004-03-17 A → 2004-12-02 (+260d) | 41d → 221d | 100% → 62% | none → -34d |  |  |
| 689 | **SEPT-E** |  | 2004-03-17 A → 2004-12-02 (+260d) | 46d → 226d | 100% → 61% | none → -34d |  |  |
| 705 | **SIT - UMD** |  | 2004-10-25 → 2004-12-27 (+63d) | 354d → 396d | 52% → 84% | 2d → -45d |  |  |
| 706 | **Deliveries** | 2004-07-26 → 2004-09-30 (+66d) | 2004-10-25 → 2004-12-27 (+63d) | 64d → 60d |  | -8d → -50d |  |  |
| 707 | Deliver SIT FM 1 to CIT for SEP I&T and Suite EMC | 2004-07-26 → 2004-09-30 (+66d) | 2004-07-27 → 2004-10-01 (+66d) |  |  | -8d → -50d |  |  |
| 708 | Deliver SIT FM 1 back to GSFC for Environmental Testing (after EMC Test) | 2004-08-18 → 2004-10-19 (+62d) | 2004-08-19 → 2004-10-20 (+62d) |  |  | -3d → -45d |  |  |
| 709 | Final Delivery of SIT FM 1 to APL | 2004-10-12 → 2004-12-13 (+62d) | 2004-10-12 → 2004-12-13 (+62d) |  |  | -3d → -45d |  |  |
| 710 | Final Delivery of SIT FM 2 to CIT for Suie EMC | 2004-10-25 → 2004-12-27 (+63d) | 2004-10-25 → 2004-12-27 (+63d) |  |  | 2d → -45d |  | was named Final Delivery of SIT FM 2 to APL |
| 711 | **ACTEL - for SIT Logic Board** | 2004-05-17 → 2004-05-24 A (+7d) | 2004-06-01 → 2004-05-24 A (-8d) | 11d → 1d | 0% → 100% | 13d → none |  |  |
| 712 | Burn Final SIT ACTEL Chip w/latest algorithm (at GSFC) | 2004-05-17 → 2004-05-24 A (+7d) | 2004-05-17 → 2004-05-24 A (+7d) |  | 0% → 100% | 13d → none |  | was named Burn Final SIT ACTEL Chip (at GSFC); constraint start no earlier than 2004-05-17 → start no earlier than 2004-05-24 |
| 713 | Evaluate (Test) SIT Final ACTEL Chip | 2004-05-18 → 2004-05-24 A (+6d) | 2004-06-01 → 2004-05-24 A (-8d) | 10d → 0d | 0% → 100% | 13d → none |  |  |
| 714 | **TOF Boards** |  | 2004-05-05 → 2004-07-30 A (+86d) | 59d → 119d | 48% → 100% | 28d → none |  |  |
| 716 | Receive Analog and Digital TOF Boards (FM 2) |  | 2004-04-21 → 2004-05-28 A (+37d) |  | 25% → 100% | 28d → none | 719 → 719FS+32d |  |
| 717 | **Test** |  | 2004-05-05 → 2004-07-30 A (+86d) | 48d → 108d | 64% → 100% | 28d → none |  |  |
| 720 | **FM 2** | 2004-04-22 → 2004-07-26 A (+95d) | 2004-05-05 → 2004-07-30 A (+86d) | 10d → 5d | 0% → 100% | 28d → none |  |  |
| 721 | FM 2 TOF Boards Functional Test | 2004-04-22 → 2004-07-26 A (+95d) | 2004-05-05 → 2004-07-30 A (+86d) | 10d → 5d | 0% → 100% | 28d → none | 715, 716 → 715, 716FS+38d |  |
| 722 | **Energy Board** |  | 2004-05-14 → 2004-06-04 A (+21d) | 129d → 143d | 83% → 100% | 21d → none |  |  |
| 723 | **Assembly** |  | 2004-04-23 A |  | 94% → 100% | 21d → none |  |  |
| 726 | **FM 2** |  | 2004-04-23 A |  | 88% → 100% | 21d → none |  |  |
| 727 | Assemble FM 2 Energy Board |  | 2004-04-23 A | 84d → 82d | 88% → 100% | 21d → none |  |  |
| 728 | **Test** |  | 2004-05-14 → 2004-06-04 A (+21d) | 37d → 51d | 17% → 100% | 21d → none |  |  |
| 729 | **FM 1** |  | 2004-04-14 → 2004-06-03 A (+50d) | 15d → 50d | 33% → 100% | 17d → none |  |  |
| 730 | Bench Test/Calibration |  | 2004-04-07 → 2004-05-28 A (+51d) | 10d → 47d | 50% → 100% | 17d → none |  |  |
| 731 | Thermal | 2004-04-08 → 2004-06-01 A (+54d) | 2004-04-12 → 2004-06-03 A (+52d) |  | 0% → 100% | 17d → none |  |  |
| 732 | Voltage Margin | 2004-04-13 → 2004-06-01 A (+49d) | 2004-04-14 → 2004-06-02 A (+49d) |  | 0% → 100% | 17d → none | 731 → 731SS |  |
| 733 | **FM 2** | 2004-04-26 → 2004-05-26 A (+30d) | 2004-05-14 → 2004-06-04 A (+21d) | 15d → 7d | 0% → 100% | 21d → none |  |  |
| 734 | FM 2 Energy Board Functional Test | 2004-04-26 → 2004-05-26 A (+30d) | 2004-05-14 → 2004-06-04 A (+21d) | 15d → 7d | 0% → 100% | 21d → none | 727, 732 → 727, 732FS-5d |  |
| 735 | **Logic Board** |  | 2004-07-30 → 2004-07-28 A (-2d) | 183d → 180d | 61% → 100% | 1d → none |  |  |
| 740 | **Assembly** | 2004-04-14 → 2004-05-25 A (+41d) | 2004-07-28 → 2004-07-21 A (-7d) | 75d → 40d | 0% → 100% | -8d → none |  |  |
| 741 | **FM 1** | 2004-04-14 → 2004-05-25 A (+41d) | 2004-07-05 → 2004-06-04 A (-31d) | 58d → 8d | 0% → 100% | -8d → none |  |  |
| 742 | Assemble FM 1 Logic Board with Flight ACTELs | 2004-04-14 → 2004-05-25 A (+41d) | 2004-04-28 → 2004-06-04 A (+37d) | 11d → 8d | 0% → 100% | -8d → none | 749FS+9d → 749, 713 | was named Assemble FM 1 Logic Board with ETU ACTELs |
| 743 | **FM 2** | 2004-04-14 → 2004-07-19 A (+96d) | 2004-07-28 → 2004-07-21 A (-7d) | 75d → 3d | 0% → 100% | 1d → none |  |  |
| 744 | Assemble FM 2 Logic Board with Flight ACTELS | 2004-04-14 → 2004-07-19 A (+96d) | 2004-04-28 → 2004-07-21 A (+84d) | 11d → 3d | 0% → 100% | 18d → none | 749FS+9d → 749, 713, 751FS+18d | was named Assemble FM 2 Logic Board with ETU ACTELS |
| 745 | **Test** |  | 2004-07-30 → 2004-07-28 A (-2d) | 183d → 180d | 72% → 100% | 1d → none |  |  |
| 750 | **FM 1** | 2004-04-29 → 2004-06-07 A (+39d) | 2004-07-07 → 2004-06-21 A (-16d) | 49d → 11d | 0% → 100% | -8d → none |  |  |

| ID | Task | Start | Finish | Duration | Complete | Total float | Predecessors | Other |
| --- | --- | --- | --- | --- | --- | --- | --- | --- |
| 751 | Functional Test of FM 1 Logic Board w/Flight ACTELS | 2004-04-29 → 2004-06-07 A (+39d) | 2004-05-19 → 2004-06-21 A (+33d) | 15d → 11d | 0% → 100% | -8d → none |  | was named Functional Test of FM 1 Logic Board w/ETU ACTELS |
| 752 | **FM 2** | 2004-05-20 → 2004-07-22 A (+63d) | 2004-07-30 → 2004-07-28 A (-2d) | 51d → 5d | 0% → 100% | 1d → none |  |  |
| 753 | Functional Test of FM 2 Logic Board w/Flight ACTELS | 2004-07-29 → 2004-07-22 A (-7d) | 2004-07-30 → 2004-07-28 A (-2d) | 2d → 5d | 0% → 100% | 1d → none | Reassemble FM 2 Logic Boards → 744 | baseline start 2004-07-08 → 2004-04-14; baseline finish 2004-07-09 → 2004-05-04 |
| 754 | **Mother Board** |  | 2004-05-24 → 2004-06-22 A (+29d) | 107d → 127d | 59% → 100% | 2d → none |  |  |
| 759 | **Fabrication** |  | 2004-04-19 A |  | 57% → 100% | 0d → none |  |  |
| 760 | **FM 1 & FM 2** |  | 2004-04-19 A |  | 57% → 100% | 0d → none |  |  |
| 762 | Refabricate FM1 & FM2 Mother Boards |  | 2004-04-19 A |  | 13% → 100% | -6d → none |  |  |
| 763 | **Assembly** | 2004-04-27 → 2004-05-10 A (+13d) | 2004-05-10 → 2004-05-21 A (+11d) |  | 0% → 100% | -6d → none |  |  |
| 764 | Assemble FM 1 Mother Board | 2004-04-27 → 2004-05-10 A (+13d) | 2004-05-10 → 2004-05-21 A (+11d) |  | 0% → 100% | -6d → none | 761, 769 → 761, 769FS+9d |  |
| 765 | Assemble FM 2 Mother Board | 2004-04-27 → 2004-05-10 A (+13d) | 2004-05-10 → 2004-05-21 A (+11d) |  | 0% → 100% | 7d → none |  |  |
| 766 | **Test** |  | 2004-05-24 → 2004-06-22 A (+29d) | 62d → 82d | 25% → 100% | 2d → none |  |  |
| 767 | **FM 1 & FM 2** |  | 2004-04-26 A |  | 50% → 100% | -6d → none |  |  |
| 769 | Coupon Testing of 2nd Mother Boards | 2004-04-20 A | 2004-04-26 A |  | 0% → 100% | -6d → none |  |  |
| 770 | **FM 1** | 2004-05-11 → 2004-06-14 A (+34d) | 2004-05-17 → 2004-06-22 A (+36d) | 5d → 7d | 0% → 100% | -6d → none |  |  |
| 771 | Functional Test FM 1 Mother Board | 2004-05-11 → 2004-06-14 A (+34d) | 2004-05-17 → 2004-06-22 A (+36d) | 5d → 7d | 0% → 100% | -6d → none | 764 → 764FS+14d |  |
| 772 | **FM 2** | 2004-05-18 → 2004-06-15 A (+28d) | 2004-05-24 → 2004-06-22 A (+29d) | 5d → 6d | 0% → 100% | 2d → none |  |  |
| 773 | Functional Test FM 2 Mother Board | 2004-05-18 → 2004-06-15 A (+28d) | 2004-05-24 → 2004-06-22 A (+29d) | 5d → 6d | 0% → 100% | 2d → none | 765, 771 → 765, 771SS+1d |  |
| 774 | **HVPS** |  | 2004-06-08 → 2004-09-01 (+85d) | 104d → 164d |  | 2d → -36d |  |  |
| 775 | **Test** |  | 2004-06-08 → 2004-09-01 (+85d) | 104d → 164d |  | 2d → -36d |  |  |
| 778 | **FM 2** | 2004-05-25 → 2004-08-19 (+86d) | 2004-06-08 → 2004-09-01 (+85d) |  |  | 2d → -36d |  |  |
| 779 | Functional Test SIT FM 2 HVPS | 2004-05-25 → 2004-08-19 (+86d) | 2004-06-08 → 2004-09-01 (+85d) |  |  | 2d → -36d | 76, 773 → 76 |  |
| 780 | **Flight Software** |  | 2004-04-01 → 2004-05-06 A (+35d) | 210d → 235d | 89% → 100% | 53d → none |  |  |
| 781 | **Test** |  | 2004-04-01 → 2004-05-06 A (+35d) | 210d → 235d | 89% → 100% | 53d → none |  |  |
| 782 | **FM 1 & FM 2** |  | 2004-04-01 → 2004-05-06 A (+35d) | 210d → 235d | 89% → 100% | 53d → none |  |  |
| 783 | Validate SIT On-Board Code |  | 2004-04-01 → 2004-05-06 A (+35d) | 210d → 235d | 89% → 100% | 53d → none |  |  |
| 784 | **Integration & Test (using ETU Telescope for FM 1)** |  | 2004-08-12 → 2004-11-12 (+92d) | 121d → 183d | 4% → 29% | 1d → -45d |  |  |
| 785 | **FM 1 (Flight Telescope)** | 2004-07-08 → 2004-08-11 (+34d) | 2004-07-23 → 2004-09-29 (+68d) | 12d → 35d |  | -8d → -32d |  |  |
| 786 | Disassemble SIT FM 1 | 2004-07-08 → 2004-08-16 (+39d) | 2004-07-08 → 2004-08-16 (+39d) |  |  | -8d → -31d | Funtional Test of FM 1 Logic Board w/Flight ACTELS → 788 |  |
| 787 | Conformal Coat SIT FM 1 Boards (includes FM 1 LVPS) | 2004-07-09 → 2004-08-17 (+39d) | 2004-07-12 → 2004-08-18 (+37d) |  |  | -8d → -31d |  |  |
| 789 | Assemble SIT FM 1 with Flight Telescope | 2004-07-13 → 2004-09-16 (+65d) | 2004-07-13 → 2004-09-17 (+66d) | 1d → 2d |  | -8d → -50d |  | was named Reassemble SIT FM 1 with Flight Telescope |
| 791 | Bench Calibration SIT FM 1 w/Flight Telescope | 2004-07-14 → 2004-09-21 (+69d) | 2004-07-16 → 2004-09-23 (+69d) |  |  | -8d → -50d | 789 → 790 |  |
| 792 | Vacuum Test SIT FM 1 w/Flight Telescope | 2004-07-19 → 2004-09-24 (+67d) | 2004-07-23 → 2004-09-29 (+68d) | 5d → 4d |  | -8d → -50d |  |  |
| 793 | **FM 2** | 2004-08-02 → 2004-11-01 (+91d) | 2004-08-12 → 2004-11-12 (+92d) |  |  | 1d → -45d |  |  |
| 794 | Disassemble SIT FM 2 | 2004-08-02 → 2004-11-01 (+91d) | 2004-08-02 → 2004-11-01 (+91d) |  |  | 1d → -45d | 753 → 815 |  |
| 795 | Conformal Coat SIT FM 2 Boards | 2004-08-03 → 2004-11-02 (+91d) | 2004-08-04 → 2004-11-03 (+91d) |  |  | 1d → -45d |  |  |
| 796 | Reassemble SIT FM 2 | 2004-08-05 → 2004-11-04 (+91d) | 2004-08-05 → 2004-11-04 (+91d) |  |  | 1d → -45d |  |  |
| 797 | Post-Coat Retest SIT FM 2 | 2004-08-06 → 2004-11-05 (+91d) | 2004-08-12 → 2004-11-12 (+92d) |  |  | 1d → -45d |  |  |
| 798 | **FM 1 (ETU Telescope)** |  | 2004-06-29 → 2004-08-17 (+49d) | 89d → 123d | 10% → 64% | -8d → -5d |  |  |
| 800 | Integrate Electronics to SIT ETU Telescope | 2004-05-20 → 2004-06-23 A (+34d) | 2004-05-21 → 2004-07-09 A (+49d) | 2d → 12d | 0% → 100% | -8d → none |  |  |
| 801 | SIT FM 1 Debug | 2004-05-24 → 2004-07-12 A (+49d) | 2004-05-28 → 2004-07-16 A (+49d) |  | 0% → 100% | -8d → none |  |  |
| 802 | SIT FM 1 Bench Test | 2004-06-01 → 2004-07-19 A (+48d) | 2004-06-07 → 2004-07-23 A (+46d) |  | 0% → 100% | -8d → none |  |  |
| 803 | SIT FM 1 Alpha TEST | 2004-06-08 → 2004-07-26 A (+48d) | 2004-06-14 → 2004-08-09 (+56d) | 5d → 11d | 0% → 45% | -8d → -5d |  |  |
| 804 | SIT FM 1 Noise Removal | 2004-06-15 → 2004-08-03 (+49d) | 2004-06-21 → 2004-08-09 (+49d) |  |  | -8d → -5d | 803 → 803FS-5d |  |
| 805 | SIT FM 1 Thermal Test | 2004-06-22 → 2004-08-10 (+49d) | 2004-06-28 → 2004-08-16 (+49d) |  |  | -8d → -5d |  |  |
| 806 | SIT FM 1 Functional Test | 2004-06-29 → 2004-08-17 (+49d) | 2004-06-29 → 2004-08-17 (+49d) |  |  | -8d → -5d |  |  |
| 807 | **FM 2** | 2004-06-10 → 2004-09-16 (+98d) | 2004-07-22 → 2004-10-29 (+99d) |  |  | 1d → -45d |  |  |
| 808 | Integrate SIT FM 2 HVPS and SIT FM 2 Telescope Without Electronics | 2004-06-10 → 2004-09-16 (+98d) | 2004-06-14 → 2004-09-20 (+98d) |  |  | 1d → -45d |  |  |
| 809 | Integrate Electronics to SIT FM 2 Telescope | 2004-06-15 → 2004-09-21 (+98d) | 2004-06-16 → 2004-09-22 (+98d) |  |  | 1d → -45d | Functional Test of FM 2 Logic Board w/ETU ACTELS, 721, 773, 734, 808 → 753, 721, 773, 734, 808 |  |
| 810 | SIT FM 2 Debug | 2004-06-17 → 2004-09-23 (+98d) | 2004-06-23 → 2004-09-29 (+98d) |  |  | 1d → -45d |  |  |
| 811 | SIT FM 2 Bench Test | 2004-06-24 → 2004-09-30 (+98d) | 2004-06-30 → 2004-10-06 (+98d) |  |  | 1d → -45d |  |  |
| 812 | SIT FM 2 Alpha Test | 2004-07-01 → 2004-10-07 (+98d) | 2004-07-07 → 2004-10-14 (+99d) |  |  | 1d → -45d |  |  |
| 813 | SIT FM 2 Noise Removal | 2004-07-08 → 2004-10-15 (+99d) | 2004-07-14 → 2004-10-21 (+99d) |  |  | 1d → -45d |  |  |
| 814 | SIT FM 2 Thermal Test | 2004-07-15 → 2004-10-22 (+99d) | 2004-07-21 → 2004-10-28 (+99d) |  |  | 1d → -45d |  |  |
| 815 | SIT FM 2 Functional Test | 2004-07-22 → 2004-10-29 (+99d) | 2004-07-22 → 2004-10-29 (+99d) |  |  | 1d → -45d |  |  |
| 816 | Integrate SIT Door FM 1 | 2004-08-20 → 2004-10-21 (+62d) | 2004-08-20 → 2004-10-21 (+62d) |  |  | -3d → -45d |  |  |
| 817 | Integrate SIT Door FM 2 | 2004-09-02 → 2004-10-22 (+50d) | 2004-09-02 → 2004-10-22 (+50d) |  |  | 2d → -31d | Deliver SIT FM 2 back to GSFC for Environmental Testing, 816 → 816 |  |
| 818 | **Environmental Testing at GSFC (FM 1)** | 2004-08-23 → 2004-10-22 (+60d) | 2004-10-08 → 2004-12-10 (+63d) |  |  | -3d → -45d |  |  |
| 819 | SIT FM 1 Vibration and Acoustics | 2004-08-23 → 2004-10-22 (+60d) | 2004-09-03 → 2004-11-04 (+62d) |  |  | -3d → -45d |  |  |
| 820 | Functional Test | 2004-09-07 → 2004-11-05 (+59d) | 2004-09-07 → 2004-11-05 (+59d) |  |  | -3d → -45d |  |  |
| 821 | SIT FM 1 Thermal Balance | 2004-09-08 → 2004-11-08 (+61d) | 2004-09-14 → 2004-11-15 (+62d) |  |  | -3d → -45d |  |  |
| 822 | SIT FM 1 Thermal Vac | 2004-09-15 → 2004-11-16 (+62d) | 2004-09-28 → 2004-11-30 (+63d) |  |  | -3d → -45d |  |  |
| 823 | Disassemble SIT Instruments | 2004-09-29 → 2004-12-01 (+63d) | 2004-09-30 → 2004-12-02 (+63d) |  |  | -3d → -45d |  |  |
| 824 | Bake Out | 2004-10-01 → 2004-12-03 (+63d) | 2004-10-05 → 2004-12-07 (+63d) |  |  | -3d → -45d |  |  |
| 825 | Reassemble Instruments | 2004-10-06 → 2004-12-08 (+63d) | 2004-10-07 → 2004-12-09 (+63d) |  |  | -3d → -45d |  |  |
| 826 | Functional Test | 2004-10-08 → 2004-12-10 (+63d) | 2004-10-08 → 2004-12-10 (+63d) |  |  | -3d → -45d |  |  |
| 827 | **Environmental Testing at GSFC (FM 2)** | 2004-09-03 → 2004-11-15 (+73d) | 2004-10-22 → 2004-12-24 (+63d) | 34d → 29d |  | 2d → -45d |  |  |
| 828 | SIT FM 2 Vibration and Acoustics | 2004-09-03 → 2004-11-15 (+73d) | 2004-09-17 → 2004-11-29 (+73d) |  |  | 2d → -45d | Deliver SIT FM 2 back to GSFC for Environmental Testing, 817 → 817, 797 |  |
| 829 | Functional Test | 2004-09-20 → 2004-11-30 (+71d) | 2004-09-20 → 2004-11-30 (+71d) |  |  | 2d → -45d |  |  |
| 830 | SIT FM 2 Thermal Vac | 2004-09-28 → 2004-12-01 (+64d) | 2004-10-12 → 2004-12-14 (+63d) |  |  | 2d → -45d | SIT FM 2 Thermal Balance → 829 |  |
| 831 | Disassemble SIT Instruments | 2004-10-13 → 2004-12-15 (+63d) | 2004-10-14 → 2004-12-16 (+63d) |  |  | 2d → -45d |  |  |

| ID | Task | Start | Finish | Duration | Complete | Total float | Predecessors | Other |
| --- | --- | --- | --- | --- | --- | --- | --- | --- |
| 832 | Bake Out | 2004-10-15 → 2004-12-17 (+63d) | 2004-10-19 → 2004-12-21 (+63d) |  |  | 2d → -45d |  |  |
| 833 | Reassemble Instruments | 2004-10-20 → 2004-12-22 (+63d) | 2004-10-21 → 2004-12-23 (+63d) |  |  | 2d → -45d |  |  |
| 834 | Functional Test | 2004-10-22 → 2004-12-24 (+63d) | 2004-10-22 → 2004-12-24 (+63d) |  |  | 2d → -45d |  |  |
| 835 | **Emulators/Simulators/GSE** |  | 2004-10-13 → 2004-12-01 (+49d) | 209d → 241d | 10% → 84% | 9d → -28d |  |  |
| 836 | **Simulators** |  | 2004-04-12 → 2004-05-14 A (+32d) | 80d → 104d | 13% → 100% | 98d → none |  |  |
| 837 | Labview CPU Ready |  | 2004-04-12 → 2004-05-14 A (+32d) | 80d → 104d | 13% → 100% | 0d → none |  |  |
| 838 | Test Simulator |  | 2004-04-12 → 2004-05-14 A (+32d) | 80d → 104d | 13% → 100% | 98d → none |  |  |
| 839 | **GSE** | 2004-08-17 → 2004-10-04 (+48d) | 2004-10-13 → 2004-12-01 (+49d) |  |  | 9d → -28d |  |  |
| 840 | Pulse Generator | 2004-08-17 → 2004-10-04 (+48d) | 2004-10-13 → 2004-12-01 (+49d) |  |  | 9d → -28d | 707, Deliver SIT FM 2 to CIT for SEP I&T, 838 → 707, 838 |  |
| 841 | **SEP Suite I&T - CIT** |  | 2004-10-21 → 2004-12-31 (+71d) | 309d → 357d | 33% → 65% | 5d → -44d |  |  |
| 844 | **FM 1 & FM 2** | 2004-03-09 → 2004-06-16 A (+99d) | 2004-07-22 → 2004-09-28 (+68d) | 97d → 73d | 0% → 29% | -3d → -46d |  |  |
| 845 | Generate HET integration & test procedure | 2004-06-21 → 2004-06-17 A (-4d) | 2004-06-25 → 2004-06-23 A (-2d) |  | 0% → 100% | 2d → none |  |  |
| 846 | Generate LET integration & test procedure | 2004-06-03 → 2004-06-16 A (+13d) | 2004-06-09 → 2004-06-22 A (+13d) |  | 0% → 100% | 13d → none | 864FS-10d → 855FS-10d |  |
| 847 | Generate SEPT integration & test procedure | 2004-03-09 → 2004-09-09 (+184d) | 2004-06-15 → 2004-09-15 (+92d) | 70d → 5d |  | 8d → -42d |  |  |
| 848 | Generate SEP-IDPU integration procedure | 2004-06-22 → 2004-09-08 (+78d) | 2004-06-28 → 2004-09-14 (+78d) |  |  | 8d → -46d | 855FS-10d → 857FS-10d |  |
| 849 | Generate SEP-IDPU test procedure | 2004-06-29 → 2004-09-15 (+78d) | 2004-07-05 → 2004-09-21 (+78d) |  |  | 8d → -46d |  |  |
| 850 | Generate SIT integration & test procedure | 2004-07-15 → 2004-09-21 (+68d) | 2004-07-21 → 2004-09-27 (+68d) |  |  | -3d → -45d |  |  |
| 851 | Generate SEP system test procedure | 2004-07-16 → 2004-09-22 (+68d) | 2004-07-22 → 2004-09-28 (+68d) |  |  | -3d → -50d |  |  |
| 852 | **FM 1** | 2004-03-22 → 2004-06-29 A (+99d) | 2004-08-03 → 2004-10-05 (+63d) | 96d → 69d | 0% → 31% | -8d → -50d |  |  |
| 853 | Integrate/test SEP Central FM 1 | 2004-06-02 → 2004-07-01 A (+29d) | 2004-06-08 → 2004-07-02 A (+24d) | 5d → 2d | 0% → 100% | 13d → none |  |  |
| 854 | Receive & inspect HET FM 1 | 2004-07-02 → 2004-06-30 A (-2d) | 2004-07-02 → 2004-06-30 A (-2d) |  | 0% → 100% | -3d → none |  |  |
| 855 | Integrate & test HET FM 1 | 2004-07-05 → 2004-06-29 A (-6d) | 2004-07-05 → 2004-06-29 A (-6d) |  | 0% → 100% | -3d → none | 845, 856, 854 → 845, 853FS-4d |  |
| 856 | Integrate & test LET FM 1 | 2004-06-30 → 2004-07-02 A (+2d) | 2004-06-30 → 2004-07-02 A (+2d) |  | 0% → 100% | -1d → none | 846, 864, 576, 578 → 855, 846, 576 |  |
| 859 | Integrate SEP FM 1 - IDPU FM 1 | 2004-07-22 → 2004-09-15 (+55d) | 2004-07-22 → 2004-09-15 (+55d) |  |  | -5d → -42d | 848, 855, 211, 897, 515 → 848, 400 |  |
| 860 | Test SEP FM 1 - IDPU FM 1 | 2004-07-23 → 2004-09-22 (+61d) | 2004-07-23 → 2004-09-22 (+61d) |  |  | -5d → -46d |  |  |
| 861 | Receive & inspect SIT FM 1 | 2004-07-28 → 2004-10-04 (+68d) | 2004-07-28 → 2004-10-04 (+68d) |  |  | -8d → -50d |  |  |
| 862 | Integrate & test SIT FM 1 | 2004-07-29 → 2004-10-05 (+68d) | 2004-07-29 → 2004-10-05 (+68d) |  |  | -8d → -50d | 850, 855, 861, 860 → 861, 850 |  |
| 863 | Receive & inspect SEPT FM 1 | 2004-03-22 → 2004-09-22 (+184d) | 2004-03-22 → 2004-09-22 (+184d) |  |  | 8d → -47d | 604, 605 → 604, 605, 857 |  |
| 864 | Integrate & test SEPT FM 1 | 2004-06-16 → 2004-09-23 (+99d) | 2004-06-16 → 2004-09-23 (+99d) |  |  | 8d → -47d | 847, 853, 863 → 863, 847 |  |
| 865 | SEP system test FM 1 | 2004-07-30 → 2004-09-29 (+61d) | 2004-08-03 → 2004-10-01 (+59d) |  |  | -8d → -50d | 851, 862, 481 → 851, 864, 860, 858 |  |
| 866 | **FM 2** | 2004-03-25 → 2004-06-30 A (+97d) | 2004-08-23 → 2004-10-01 (+39d) | 107d → 66d | 0% → 20% | 26d → -18d |  |  |
| 867 | Receive & inspect HET FM 2 | 2004-07-09 → 2004-06-30 A (-9d) | 2004-07-09 → 2004-06-30 A (-9d) |  | 0% → 100% | 34d → none |  |  |
| 868 | Integrate & test HET FM 2 | 2004-07-12 → 2004-07-01 A (-11d) | 2004-07-12 → 2004-07-01 A (-11d) |  | 0% → 100% | 34d → none | 845, 869, 867 → 867, 845 |  |
| 869 | Integrate & test LET FM 2 | 2004-07-06 → 2004-07-02 A (-4d) | 2004-07-06 → 2004-07-02 A (-4d) |  | 0% → 100% | 37d → none | 846, 892, 577, 578 → 577, 578, 846 |  |
| 870 | Integrate/testSEP Central FM 2 | 2004-06-28 → 2004-07-30 (+32d) | 2004-07-02 → 2004-08-05 (+34d) |  |  | 37d → 17d | 485, 486, 424 → 485, 486, 424, 869, 868 |  |
| 873 | Integrate SEP FM 2 - IDPU FM 2 | 2004-08-05 → 2004-09-15 (+41d) | 2004-08-05 → 2004-09-15 (+41d) |  |  | 37d → -10d | 848, 868, 212 → 212, 848 |  |
| 874 | Test SEP FM 2 - IDPU FM 2 | 2004-08-06 → 2004-09-22 (+47d) | 2004-08-06 → 2004-09-22 (+47d) |  |  | 37d → -14d | 849, 873, 517 → 873, 849 |  |
| 875 | SEP FM 2 system test | 2004-08-19 → 2004-09-29 (+41d) | 2004-08-23 → 2004-10-01 (+39d) |  |  | 1d → -18d | 851, 893 → 851, 874, 872 |  |
| 876 | **Environmental Test (at JPL)** | 2004-05-17 → 2004-06-28 A (+42d) | 2004-10-21 → 2004-12-31 (+71d) | 111d → 130d | 0% → 4% | 5d → -44d |  |  |
| 877 | Generate Environmental Test Procedures | 2004-05-17 → 2004-06-28 A (+42d) | 2004-06-07 → 2004-07-19 (+42d) |  | 0% → 20% | 46d → 16d |  | constraint start no earlier than 2004-05-17 → start no earlier than 2004-06-28 |
| 878 | Manufacture test cables (JPL) | 2004-06-01 → 2004-06-28 A (+27d) | 2004-06-28 → 2004-07-26 (+28d) |  | 0% → 15% | 31d → 11d |  | constraint start no earlier than 2004-06-01 → start no earlier than 2004-06-28 |
| 879 | **FM 1** | 2004-08-23 → 2004-09-23 (+31d) | 2004-10-19 → 2004-12-20 (+62d) | 40d → 60d |  | -8d → -49d |  |  |
| 880 | FM 1 LET/HET/SEP Central Vibration/Acoustics Test | 2004-08-23 → 2004-10-22 (+60d) | 2004-09-03 → 2004-11-04 (+62d) |  |  | -8d → -50d | 19FS+3d, 877, 878, 897FS+3d → 19FS+3d, 877, 878, 897, 481 |  |
| 881 | FM 1 LET/HET/SEP Central Thermal Balance Test | 2004-09-07 → 2004-11-05 (+59d) | 2004-09-13 → 2004-11-12 (+60d) |  |  | -8d → -50d |  |  |
| 882 | FM 1 LET/HET/SEP Central T/V Test | 2004-09-14 → 2004-11-15 (+62d) | 2004-10-04 → 2004-12-06 (+63d) |  |  | -8d → -50d | 881, 894 → 881 |  |
| 883 | Evaluate SEP performance | 2004-10-05 → 2004-12-07 (+63d) | 2004-10-19 → 2004-12-20 (+62d) |  |  | -8d → -50d |  |  |
| 885 | Bakeout Clean SEP exterior & prepare for delivery | 2004-10-05 → 2004-12-07 (+63d) | 2004-10-07 → 2004-12-09 (+63d) |  |  | -1d → -43d |  |  |
| 886 | **FM 2** | 2004-08-24 → 2004-10-14 (+51d) | 2004-10-21 → 2004-12-31 (+71d) | 41d → 55d |  | 1d → -44d |  |  |
| 887 | FM 2 LET/HET/SEP Central Vibration/Acoustics Test | 2004-08-31 → 2004-10-22 (+52d) | 2004-09-14 → 2004-11-04 (+51d) |  |  | 5d → -31d | 898FS+3d, 894 → 875, 880SS |  |
| 888 | FM 2 LET/HET/SEP Central T/V Test | 2004-09-15 → 2004-11-05 (+51d) | 2004-10-05 → 2004-11-29 (+55d) |  |  | 5d → -31d | 894, 887 → 887 |  |
| 889 | Evaluate SEP performance | 2004-10-06 → 2004-11-30 (+55d) | 2004-10-20 → 2004-12-13 (+54d) |  |  | 5d → -31d |  |  |
| 890 | Generate test reports | 2004-10-06 → 2004-10-14 (+8d) | 2004-10-21 → 2004-10-28 (+7d) |  |  | 5d → -31d |  |  |
| 891 | Bakeout Clean SEP exterior & prepare for delivery | 2004-10-06 → 2004-11-30 (+55d) | 2004-10-08 → 2004-12-02 (+55d) |  |  | 12d → -29d |  |  |
| 892 | Integrate & test SEPT FM 2 | 2004-07-05 → 2004-12-10 (+158d) | 2004-07-05 → 2004-12-10 (+158d) |  |  | 37d → -34d | 847, 870, Receive & inspect SEPT FM 2 → 891, 607, 608 | baseline start 2004-05-18 → 2004-11-30; baseline finish 2004-05-18 → 2004-11-30 |
| 893 | Integrate & test SIT FM 2 | 2004-08-18 → 2004-12-28 (+132d) | 2004-08-18 → 2004-12-28 (+132d) |  |  | 1d → -45d | 850, Receive & inspect SIT FM 2 → 892, 710 | baseline start 2004-08-06 → 2004-12-15; baseline finish 2004-08-06 → 2004-12-15 |
| 894 | FM 2 EMI/EMC Test at CalTech | 2004-08-24 → 2004-12-29 (+127d) | 2004-08-30 → 2004-12-30 (+122d) | 5d → 2d |  | 1d → -45d | 875 → 885, 893 |  |
| 896 | **Accelerator Test (at MSU)** | 2004-07-10 A | 2004-07-16 → 2004-07-22 A (+6d) | 5d → 9d | 0% → 100% | -7d → none |  |  |
| 897 | FM 1 LET-HET/SEP Cen end-to-end test at Accelerator | 2004-07-10 A | 2004-07-12 A |  | 0% → 100% | -7d → none | 909, 455, 855 → 909, 455, 856 | was named FM 1 LET/SEP Cen end-to-end test at Accelerator |
| 898 | FM 2 LET/SEP Cen end-to-end test at Accelerator | 2004-07-13 → 2004-07-10 A (-3d) | 2004-07-15 → 2004-07-12 A (-3d) |  | 0% → 100% | 34d → none | 897SS, 868 → 909, 869 | constraint none → start no earlier than 2004-07-10 |
| 900 | Detach HET LET and SEP Cen from SEP Suite | 2004-07-13 → 2004-07-20 A (+7d) | 2004-07-13 → 2004-07-20 A (+7d) |  | 0% → 100% | -5d → none | 897 → 897, 898FS+5d | was named Detach HET FM1 from SEP Suite |
| 901 | Deliver HET FM 1 (Rplcmnt Detectors and Conformal Coating @ GSFC) | 2004-07-14 → 2004-07-21 A (+7d) | 2004-07-15 → 2004-07-22 A (+7d) |  | 0% → 100% | -5d → none |  | was named Deliver HET FM1 to GSFC for Replacement Detectors |
| 905 | **GSE** |  | 2004-10-15 → 2004-10-18 (+3d) |  | 48% → 82% | 9d → 8d |  |  |
| 906 | **End-to-End Test Equipment** |  | 2004-06-22 A |  | 84% → 100% | 6d → none |  |  |
| 907 | Design |  | 2004-05-14 A |  | 95% → 100% | 6d → none |  |  |
| 908 | Assemble | 2004-05-17 A | 2004-06-15 A |  | 0% → 100% | 6d → none |  |  |
| 909 | Test | 2004-06-16 A | 2004-06-22 A |  | 0% → 100% | 6d → none |  |  |
| 910 | **GSE software** |  | 2004-10-15 → 2004-10-18 (+3d) |  | 27% → 72% | 9d → 8d |  |  |
| 911 | Build GSE software release 2 |  |  |  | 45% → 99% |  |  |  |
| 912 | Write user's guide | 2004-06-21 → 2004-07-27 (+36d) | 2004-07-02 → 2004-08-09 (+38d) |  |  | 10d → 26d | 911FS-10d → 911FS+15d |  |
| 913 | Build GSE software release 3 | 2004-05-03 A | 2004-10-15 → 2004-10-18 (+3d) |  | 0% → 36% | 9d → 8d |  |  |

| ID | Task | Start | Finish | Total float | Other |
| --- | --- | --- | --- | --- | --- |
| 914 | Write user's guide supplement | 2004-09-17 → 2004-09-20 (+3d) | 2004-10-15 → 2004-10-18 (+3d) | 9d → 8d |  |
| 915 | **SWEA and SIT Retest (after S/C Environmental Testing)** |  |  |  | was named SWEA and SIT Refurbishment (after S/C Environmental Testing) |
